# BINAK OILFIELD DEVELOPMENT

Schedule from MS Project, 2023-12-16 to 2025-11-22, A marks actual dates.

## Calendars

- Standard: Mon-Thu 08:00-12:00, 13:00-17:00; Fri off; Sat-Sun 08:00-12:00, 13:00-17:00. Exceptions (off unless hours are given): 2024-03-16 to 2024-04-01 (نوروز 1403), 2025-03-16 to 2025-04-01 (نوروز 1404).

## Schedule

| ID | WBS | Task | Type | Duration | Start | Finish | Predecessors | Complete | Remaining | Total slack | Free slack | Constraint | شروع | پایان | Text3 |
| --- | --- | --- | --- | --- | --- | --- | --- | --- | --- | --- | --- | --- | --- | --- | --- |
| 1 | 1 | **Key milestones** |  | 545d | 2024-01-22 A | 2025-11-22 |  |  | 545d | 0d |  |  | 1402/11/2 | 1404/9/1 |  |
| 2 | 1.1 | DP - (Effective Date) پس از تکمیل پیش پرداخت | milestone | 0d | 2024-09-22 A | 2024-09-22 A |  | 100% |  |  |  | start no earlier than 2024-09-22 | 1403/7/1 | 1403/7/1 |  |
| 3 | 1.2 | Engineering Start | milestone | 0d | 2024-01-22 A | 2024-01-22 A |  | 100% |  |  |  | start no earlier than 2024-01-22 | 1402/11/2 | 1402/11/2 |  |
| 4 | 1.3 | procument start | milestone | 0d | 2025-01-23 | 2025-01-23 | 209SS |  |  | 245d |  | start no earlier than 2024-10-09 | 1403/11/4 | 1403/11/4 |  |
| 5 | 1.4 | Procument Finish | milestone | 0d | 2025-09-25 | 2025-09-25 | 245 |  |  | 49d |  |  | 1404/7/3 | 1404/7/3 |  |
| 6 | 1.5 | Project Finish | milestone | 0d | 2025-11-22 | 2025-11-22 | 1099, 1101, 1103, 1105, 1107, 1109, 1111, 1113, 1115, 1117, 1119, 1121, 1123, 1125, 1127 |  |  | 0d |  |  | 1404/9/1 | 1404/9/1 |  |
| 7 | 2 | **Engineering** |  | 470d | 2024-01-22 A | 2025-08-26 |  | 3% | 455.42d | 75d |  |  | 1402/11/2 | 1404/6/4 |  |
| 8 | 2.1 | **General Document** |  | 353d | 2024-01-22 A | 2025-04-12 |  | 6% | 330.71d | 192d |  |  | 1402/11/2 | 1404/1/23 |  |
| 9 | 2.1.1 | **PROJECT MANAGEMENT DOCUMENTS** |  | 353d | 2024-01-22 A | 2025-04-12 |  | 24% | 268.28d | 192d |  |  | 1402/11/2 | 1404/1/23 |  |
| 10 | 2.1.1.1 | WORK BREAKDOWN STRUCTURE FOR GAS DEHYDRATION PACKAGE |  | 40d | 2024-01-22 A | 2024-11-02 | 3 | 50% | 20d | 315d | 0d |  | 1402/11/2 | 1403/8/12 |  |
| 11 | 2.1.1.2 | VENDOR PRINT INDEX & SCHEDULE (VPIS) FOR GAS DEHYDRATION PACKAGE |  | 40d | 2024-01-29 A | 2024-11-02 | 3FS+6d | 50% | 20d | 315d | 0d |  | 1402/11/9 | 1403/8/12 |  |
| 12 | 2.1.1.3 | TIME SCHEDULE FOR GAS DEHYDRATION PACKAGE |  | 40d | 2024-01-28 A | 2024-11-02 | 10SS+5d | 50% | 20d | 285d | 93d |  | 1402/11/8 | 1403/8/12 |  |
| 13 | 2.1.1.4 | FINAL VENDOR DATA BOOK INDEX FOR GAS DEHYDRATION PACKAGE |  | 30d | 2025-02-19 | 2025-04-12 | 36SS+45d, 12, 18, 25, 26, 27 |  |  | 192d |  | start no earlier than 2024-10-09 | 1403/12/1 | 1404/1/23 |  |
| 14 | 2.1.1.5 | SPARE PART LIST FOR GAS DEHYDRATION PACKAGE |  | 50d | 2024-11-30 | 2025-01-26 | 63SS |  |  | 235d | 160d | start no earlier than 2024-10-09 | 1403/9/10 | 1403/11/7 |  |
| 15 | 2.1.1.6 | SUB-VENDOR LIST FOR GAS DEHYDRATION PACKAGE |  | 50d | 2024-11-30 | 2025-01-26 | 63SS |  |  | 235d | 160d | start no earlier than 2024-10-09 | 1403/9/10 | 1403/11/7 |  |
| 16 | 2.1.2 | **QUALITY CONTROL DOCUMENTS** |  | 50d | 2024-12-23 | 2025-02-18 |  |  |  | 77d |  |  | 1403/10/3 | 1403/11/30 |  |
| 17 | 2.1.2.1 | WPS & PQR FOR GAS DEHYDRATION PACKAGE (TOWER, COLUMNS, REBOILER, DRUMS, FILTERS & EXCHANGERS) |  | 50d | 2024-12-23 | 2025-02-18 | 64SS+20d |  |  | 77d | 0d | start no earlier than 2024-10-09 | 1403/10/3 | 1403/11/30 | 20 |
| 18 | 2.1.2.2 | INSPECTION AND TEST PLAN FOR GAS DEHYDRATION PACKAGE |  | 50d | 2024-12-23 | 2025-02-18 | 17SS |  |  | 222d |  | start no earlier than 2024-10-09 | 1403/10/3 | 1403/11/30 |  |
| 19 | 2.1.2.3 | QUALITY CONTROL PLAN (QCP) FOR GAS DEHYDRATION PACKAGE |  | 50d | 2024-12-23 | 2025-02-18 | 17SS |  |  | 222d |  | start no earlier than 2024-10-09 | 1403/10/3 | 1403/11/30 |  |
| 20 | 2.1.2.4 | N2 PURGING PROCEDURE |  | 50d | 2024-12-23 | 2025-02-18 | 17SS |  |  | 195d | 146d | start no earlier than 2024-10-09 | 1403/10/3 | 1403/11/30 |  |
| 21 | 2.1.2.5 | MARKING & PACKING PROCEDURE FOR GLYCOL CIRCULATION PUMPS |  | 50d | 2024-12-23 | 2025-02-18 | 17SS |  |  | 222d |  |  | 1403/10/3 | 1403/11/30 |  |
| 22 | 2.1.2.6 | SURFACE PREPARATION AND INTERNAL/EXTERNAL PAINTING PROCEDURE FOR TOWER, COLUMNS, REBOILER, DRUMS, FILTERS & EXCHANGERS |  | 50d | 2024-12-23 | 2025-02-18 | 17SS |  |  | 178d | 127d | start no earlier than 2024-10-09 | 1403/10/3 | 1403/11/30 |  |
| 23 | 2.1.2.7 | PICKLING AND PASSIVATION PROCEDURE FOR GAS DEHYDRATION PACKAGE |  | 50d | 2024-12-23 | 2025-02-18 | 17SS |  |  | 222d |  | start no earlier than 2024-10-09 | 1403/10/3 | 1403/11/30 |  |
| 24 | 2.1.2.8 | POSTWELD HEAT TREATMENT PROCEDURE FOR GAS DEHYDRATION PACKAGE (TOWER, COLUMNS, REBOILER, DRUMS, FILTERS & EXCHANGERS) |  | 50d | 2024-12-23 | 2025-02-18 | 17SS |  |  | 195d | 146d | start no earlier than 2024-10-09 | 1403/10/3 | 1403/11/30 |  |
| 25 | 2.1.2.9 | OPERATION, COMMISSIONING & MAINTENANCE MANUAL FOR GAS DEHYDRATION PACKAGE |  | 50d | 2024-12-23 | 2025-02-18 | 17SS |  |  | 222d |  | start no earlier than 2024-10-09 | 1403/10/3 | 1403/11/30 |  |
| 26 | 2.1.2.10 | PMI PROCEDURE FOR GAS DEHYDRATION PACKAGE (TOWER, COLUMNS, REBOILER, DRUMS, FILTERS & EXCHANGERS) |  | 50d | 2024-12-23 | 2025-02-18 | 17SS |  |  | 222d |  | start no earlier than 2024-10-09 | 1403/10/3 | 1403/11/30 |  |
| 27 | 2.1.2.11 | NDT PROCEDURE FOR GAS DEHYDRATION PACKAGE (TOWER, COLUMNS, REBOILER, DRUMS, FILTERS & EXCHANGERS) |  | 50d | 2024-12-23 | 2025-02-18 | 17SS |  |  | 222d |  | start no earlier than 2024-10-09 | 1403/10/3 | 1403/11/30 |  |
| 28 | 2.1.2.12 | HYDROSTATIC TESTING PROCEDURE FOR GAS DEHYDRATION PACKAGE (TOWER, COLUMNS, REBOILER, DRUMS & FILTERS) |  | 50d | 2024-12-23 | 2025-02-18 | 17SS |  |  | 206d | 149d | start no earlier than 2024-10-09 | 1403/10/3 | 1403/11/30 |  |
| 29 | 2.1.2.13 | HYDROSTATIC TEST PROCEDURE FOR HEAT EXCHANGERS |  | 50d | 2024-12-23 | 2025-02-18 | 17SS |  |  | 208d | 169d | start no earlier than 2024-10-09 | 1403/10/3 | 1403/11/30 |  |
| 30 | 2.1.2.14 | WELD REPAIR PROCEDURE FOR GAS DEHYDRATION PACKAGE |  | 50d | 2024-12-23 | 2025-02-18 | 17SS |  |  | 222d |  | start no earlier than 2024-10-09 | 1403/10/3 | 1403/11/30 |  |

| ID | WBS | Task | Duration | Start | Finish | Predecessors | Complete | Remaining | Total slack | Free slack | Constraint | شروع | پایان | Text3 |
| --- | --- | --- | --- | --- | --- | --- | --- | --- | --- | --- | --- | --- | --- | --- |
| 31 | 2.2 | **Technical Document** | 436d | 2024-03-02 A | 2025-08-26 |  | 3% | 423.95d | 75d |  |  | 1402/12/12 | 1404/6/4 |  |
| 32 | 2.2.1 | **PROCESS DOCUMENTS** | 413d | 2024-03-02 A | 2025-07-30 |  | 9% | 375.23d | 98d |  |  | 1402/12/12 | 1404/5/8 |  |
| 33 | 2.2.1.1 | PROCESS FLOW DIAGRAM FOR GAS DEHYDRATION PACKAGE | 201d | 2024-03-02 A | 2024-11-07 | 35SS | 12% | 176d | 310d |  |  | 1402/12/12 | 1403/8/17 | PR-2 |
| 34 | 2.2.1.2 | BASIS OF PROCESS DESIGN FOR GAS DEHYDRATION PACKAGEFOR GAS DEHYDRATION PACKAGE | 199d | 2024-03-04 A | 2024-11-07 | 35SS+2d | 13% | 174d | 310d |  |  | 1402/12/14 | 1403/8/17 | PR-2 |
| 35 | 2.2.1.3 | HEAT AND MASS BALANCE FOR GAS DEHYDRATION PACKAGE | 201d | 2024-03-02 A | 2024-11-07 | 11SS+28d | 12% | 176d | 310d | 0d |  | 1402/12/12 | 1403/8/17 | PR-2 |
| 36 | 2.2.1.4 | PIPING & INSTRUMENTATION DIAGRAM FOR GAS DEHYDRATION PACKAGE | 50d | 2024-10-10 | 2024-12-07 | 35SS+15d |  |  | 0d |  | start no earlier than 2024-10-09 | 1403/7/19 | 1403/9/17 | PR-2 |
| 37 | 2.2.1.5 | CAUSE AND EFFECT DIAGRAM FOR GAS DEHYDRATION PACKAGE | 50d | 2024-11-12 | 2025-01-08 | 53SS+10d |  |  | 257d |  | start no earlier than 2024-10-09 | 1403/8/22 | 1403/10/19 | PR-2 |
| 38 | 2.2.1.6 | CONTROL PHILOSOPHY FOR GAS DEHYDRATION PACKAGE | 50d | 2024-11-12 | 2025-01-08 | 53SS+10d |  |  | 257d |  | start no earlier than 2024-10-09 | 1403/8/22 | 1403/10/19 | PR-2 |
| 39 | 2.2.1.7 | PROCESS DATA SHEET FOR DEHYDRATION COLUMN | 161d | 2024-05-05 A | 2024-11-07 | 35SS+40d | 16% | 136d | 310d | 0d |  | 1403/2/16 | 1403/8/17 | PR-1 |
| 40 | 2.2.1.8 | PROCESS DATA SHEET FOR GLYCOL FLASH DRUM | 161d | 2024-05-05 A | 2024-11-07 | 39SS | 16% | 136d | 310d | 179d |  | 1403/2/16 | 1403/8/17 | PR-1 |
| 41 | 2.2.1.9 | PROCESS DATA SHEET FOR GLYCOL CARBON FILTER | 161d | 2024-05-05 A | 2024-11-07 | 39SS | 16% | 136d | 189d | 0d |  | 1403/2/16 | 1403/8/17 | PR-1 |
| 42 | 2.2.1.10 | PROCESS DATA SHEET FOR GLYCOL REBOILER | 161d | 2024-05-05 A | 2024-11-07 | 39SS | 16% | 136d | 310d | 179d |  | 1403/2/16 | 1403/8/17 | PR-1 |
| 43 | 2.2.1.11 | PROCESS DATA SHEET FOR GLYCOL SURGE DRUM | 161d | 2024-05-05 A | 2024-11-07 | 39SS | 16% | 136d | 310d | 179d |  | 1403/2/16 | 1403/8/17 | PR-1 |
| 44 | 2.2.1.12 | PROCESS DATA SHEET FOR GLYCOL STILL COLUMN | 161d | 2024-05-05 A | 2024-11-07 | 39SS | 16% | 136d | 91d | 18d |  | 1403/2/16 | 1403/8/17 | PR-1 |
| 45 | 2.2.1.13 | PROCESS DATA SHEET FOR GLYCOL PARTICLE FILTER | 148d | 2024-05-20 A | 2024-11-07 | 39SS+13d | 17% | 123d | 189d | 0d |  | 1403/2/31 | 1403/8/17 | PR-1 |
| 46 | 2.2.1.14 | PROCESS DATA SHEET FOR GLYCOL STRIPPING COLUMN | 50d | 2024-11-03 | 2024-12-30 | 36SS+20d |  |  | 18d | 0d | start no earlier than 2024-10-09 | 1403/8/13 | 1403/10/10 | PR-1 |
| 47 | 2.2.1.15 | PROCESS DATA SHEET FOR GLYCOL CIRCULATION PUMPS | 50d | 2024-11-03 | 2024-12-30 | 46SS |  |  | 39d | 0d | start no earlier than 2024-10-09 | 1403/8/13 | 1403/10/10 | PR-1 |
| 48 | 2.2.1.16 | PROCESS DATA SHEET FOR GLYCOL REFLUX CONDENSER | 50d | 2024-11-03 | 2024-12-30 | 47SS |  |  | 96d | 23d | start no earlier than 2024-10-09 | 1403/8/13 | 1403/10/10 | PR-1 |
| 49 | 2.2.1.17 | PROCESS DATA SHEET FOR LEAN GLYCOL DRY GAS HEAT EXCHSNGER | 50d | 2024-11-03 | 2024-12-30 | 47SS |  |  | 164d | 23d | start no earlier than 2024-10-09 | 1403/8/13 | 1403/10/10 | PR-1 |
| 50 | 2.2.1.18 | PROCESS DATA SHEET FOR RICH / LEAN GLYCOL HEAT EXCHANGER | 50d | 2024-11-03 | 2024-12-30 | 47SS |  |  | 102d | 23d | start no earlier than 2024-10-09 | 1403/8/13 | 1403/10/10 | PR-1 |
| 51 | 2.2.1.19 | PROCESS DATA SHEET FOR ANTI-FOAM PACKAGE | 50d | 2024-11-03 | 2024-12-30 | 47SS |  |  | 75d | 0d |  | 1403/8/13 | 1403/10/10 | PR-1 |
| 52 | 2.2.1.20 | PROCESS DATA SHEET FOR PH-CONTROLLER PACKAGE | 50d | 2024-11-03 | 2024-12-30 | 47SS |  |  | 49d | 0d | start no earlier than 2024-10-09 | 1403/8/13 | 1403/10/10 | PR-1 |
| 53 | 2.2.1.21 | ALARM & TRIP SET POINT LIST FOR GAS DEHYDRATION PACKAGE | 50d | 2024-10-31 | 2024-12-28 | 36SS+18d |  |  | 98d | 0d | start no earlier than 2024-10-09 | 1403/8/10 | 1403/10/8 | PR-3 |
| 54 | 2.2.1.22 | PRESSURE SAFETY VALVE CALCULATION SHEETS FOR GAS DEHYDRATION PACKAGE | 50d | 2024-10-31 | 2024-12-28 | 53SS |  |  | 98d | 0d | start no earlier than 2024-10-09 | 1403/8/10 | 1403/10/8 | PR-3 |
| 55 | 2.2.1.23 | EQUIPMENT LIST FOR GAS DEHYDRATION PACKAGE | 219d | 2024-10-31 | 2025-07-30 | 53SS, 54SS |  |  | 98d | 0d |  | 1403/8/10 | 1404/5/8 | PR-3 |
| 56 | 2.2.1.24 | UTILITY CONSUMPTION LIST FOR GAS DEHYDRATION PACKAGE | 50d | 2024-10-31 | 2024-12-28 | 53SS, 55SS |  |  | 267d | 0d | start no earlier than 2024-10-09 | 1403/8/10 | 1403/10/8 | PR-3 |
| 57 | 2.2.1.25 | CHEMICAL CONSUMPTION LIST FOR GAS DEHYDRATION PACKAGE | 50d | 2024-10-31 | 2024-12-28 | 56SS, 53SS |  |  | 267d |  | start no earlier than 2024-10-09 | 1403/8/10 | 1403/10/8 | PR-3 |
| 58 | 2.2.1.26 | HAZOP STUDY REPORT FOR GAS DEHYDRATION PACKAGE | 50d | 2024-12-31 | 2025-02-26 | 36FS+20d |  |  | 215d |  | start no earlier than 2024-10-09 | 1403/10/11 | 1403/12/8 | PR-4 |
| 59 | 2.2.1.27 | SIL STUDY REPORT (SAT Procedure)) | 50d | 2024-12-31 | 2025-02-26 | 36FS+20d |  |  | 215d |  | start no earlier than 2024-10-09 | 1403/10/11 | 1403/12/8 | PR-4 |

| ID | WBS | Task | Duration | Start | Finish | Predecessors | Total slack | Free slack | Constraint | شروع | پایان | Text3 |
| --- | --- | --- | --- | --- | --- | --- | --- | --- | --- | --- | --- | --- |
| 60 | 2.2.2 | **MECHANICAL DOCUMENT** | 137d | 2024-11-21 | 2025-05-17 |  | 25d |  |  | 1403/9/1 | 1404/2/27 |  |
| 61 | 2.2.2.1 | **FIXED EQUIPMENT** | 130d | 2024-11-30 | 2025-05-17 |  | 18d |  |  | 1403/9/10 | 1404/2/27 |  |
| 62 | 2.2.2.1.1 | **Glycol Contactor (C-100)** | 130d | 2024-11-30 | 2025-05-17 |  | 18d |  |  | 1403/9/10 | 1404/2/27 |  |
| 63 | 2.2.2.1.1.1 | Mechanical Calculation Book for C-100 | 50d | 2024-11-30 | 2025-01-26 | 46SS+23d | 18d | 0d | start no earlier than 2024-10-09 | 1403/9/10 | 1403/11/7 | ME-1 |
| 64 | 2.2.2.1.1.2 | General Arrangement for C-100 | 50d | 2024-11-30 | 2025-01-26 | 63SS | 18d | 0d | start no earlier than 2024-10-09 | 1403/9/10 | 1403/11/7 | ME-1 |
| 65 | 2.2.2.1.1.3 | TEMPLATE DRAWING FOR GLYCOL CONTACTOR (C-100) | 50d | 2025-01-15 | 2025-03-13 | 64SS+40d | 18d | 0d | start no earlier than 2024-10-09 | 1403/10/26 | 1403/12/23 | ME-2 |
| 66 | 2.2.2.1.1.4 | DETAILS DRAWING FOR GLYCOL CONTACTOR (C-100) | 50d | 2025-01-15 | 2025-03-13 | 65SS | 18d | 0d | start no earlier than 2024-10-09 | 1403/10/26 | 1403/12/23 | ME-2 |
| 67 | 2.2.2.1.1.5 | Name Plate Detail Drawing for C-100 | 50d | 2025-01-15 | 2025-03-13 | 66SS | 202d | 0d | start no earlier than 2024-10-09 | 1403/10/26 | 1403/12/23 | ME-2 |
| 68 | 2.2.2.1.1.6 | Welding & NDT Map for C-100 | 50d | 2025-03-03 | 2025-05-17 | 17FS+10d | 77d | 24d | start no earlier than 2024-10-09 | 1403/12/13 | 1404/2/27 | ME-3 |
| 69 | 2.2.2.1.2 | **Still Column (C-200)** | 130d | 2024-11-30 | 2025-05-17 |  | 73d |  |  | 1403/9/10 | 1404/2/27 |  |
| 70 | 2.2.2.1.2.1 | Mechanical Calculation Book for C-200 | 50d | 2024-11-30 | 2025-01-26 | 44, 48SS, 63SS | 73d | 0d | start no earlier than 2024-10-09 | 1403/9/10 | 1403/11/7 | ME-1 |
| 71 | 2.2.2.1.2.2 | General Arrangement for C-200 | 50d | 2024-11-30 | 2025-01-26 | 70SS | 73d | 20d | start no earlier than 2024-10-09 | 1403/9/10 | 1403/11/7 | ME-1 |
| 72 | 2.2.2.1.2.3 | Details Drawing for C-200 | 50d | 2025-01-15 | 2025-03-13 | 71SS+20d, 66SS | 53d | 0d | start no earlier than 2024-10-09 | 1403/10/26 | 1403/12/23 | ME-2 |
| 73 | 2.2.2.1.2.4 | Name Plate Detail Drawing for C-200 | 50d | 2025-01-15 | 2025-03-13 | 72SS, 67SS | 202d |  | start no earlier than 2024-10-09 | 1403/10/26 | 1403/12/23 | ME-2 |
| 74 | 2.2.2.1.2.5 | Welding & NDT Map for C-200 | 50d | 2025-03-03 | 2025-05-17 | 17FS+10d | 112d | 24d | start no earlier than 2024-10-09 | 1403/12/13 | 1404/2/27 | ME-3 |
| 75 | 2.2.2.1.3 | **Lean Glycol Filter (F-300)** | 130d | 2024-11-30 | 2025-05-17 |  | 78d |  |  | 1403/9/10 | 1404/2/27 |  |
| 76 | 2.2.2.1.3.1 | Mechanical Calculation Book for F-300 | 50d | 2024-11-30 | 2025-01-26 | 41SS, 63SS | 78d | 0d | start no earlier than 2024-10-09 | 1403/9/10 | 1403/11/7 | ME-1 |
| 77 | 2.2.2.1.3.2 | General Arrangement Drawing for F-300 | 50d | 2024-11-30 | 2025-01-26 | 76SS | 78d | 25d | start no earlier than 2024-10-09 | 1403/9/10 | 1403/11/7 | ME-1 |
| 78 | 2.2.2.1.3.3 | Detail drawing for F-300 | 50d | 2025-01-15 | 2025-03-13 | 77SS+15d, 72SS | 53d | 0d | start no earlier than 2024-10-09 | 1403/10/26 | 1403/12/23 | ME-2 |
| 79 | 2.2.2.1.3.4 | Name Plate Detail Drawing for F-300 | 50d | 2025-01-15 | 2025-03-13 | 78SS | 202d |  | start no earlier than 2024-10-09 | 1403/10/26 | 1403/12/23 | ME-2 |
| 80 | 2.2.2.1.3.5 | Welding & NDT for F-300 | 50d | 2025-03-03 | 2025-05-17 | 17FS+10d | 162d |  | start no earlier than 2024-10-09 | 1403/12/13 | 1404/2/27 | ME-3 |
| 81 | 2.2.2.1.4 | **Glycol Flash Drum (V-120)** | 130d | 2024-11-30 | 2025-05-17 |  | 139d |  |  | 1403/9/10 | 1404/2/27 |  |
| 82 | 2.2.2.1.4.1 | Mechanical Calculation Book for V-120 | 50d | 2024-11-30 | 2025-01-26 | 40SS, 70SS | 139d | 0d | start no earlier than 2024-10-09 | 1403/9/10 | 1403/11/7 | ME-1 |
| 83 | 2.2.2.1.4.2 | General Arrangement for V-120 | 50d | 2024-11-30 | 2025-01-26 | 82SS | 139d | 26d | start no earlier than 2024-10-09 | 1403/9/10 | 1403/11/7 | ME-1 |
| 84 | 2.2.2.1.4.3 | Details Drawing for V-120 | 50d | 2025-01-15 | 2025-03-13 | 83SS+14d, 66SS | 113d | 0d | start no earlier than 2024-10-09 | 1403/10/26 | 1403/12/23 | ME-2 |
| 85 | 2.2.2.1.4.4 | Name Plate Detail Drawing for V-120 | 50d | 2025-01-15 | 2025-03-13 | 84SS | 202d |  | start no earlier than 2024-10-09 | 1403/10/26 | 1403/12/23 | ME-2 |
| 86 | 2.2.2.1.4.5 | Welding & NDT Map for V-120 | 50d | 2025-03-03 | 2025-05-17 | 17FS+10d | 162d |  | start no earlier than 2024-10-09 | 1403/12/13 | 1404/2/27 | ME-3 |

| ID | WBS | Task | Duration | Start | Finish | Predecessors | Total slack | Free slack | Constraint | شروع | پایان | Text3 |
| --- | --- | --- | --- | --- | --- | --- | --- | --- | --- | --- | --- | --- |
| 87 | 2.2.2.1.5 | **Glycol Particle Filter (F-100 A/B)** | 130d | 2024-11-30 | 2025-05-17 |  | 160d |  |  | 1403/9/10 | 1404/2/27 |  |
| 88 | 2.2.2.1.5.1 | Mechanical Calculation Book for (F-100 A/B) | 50d | 2024-11-30 | 2025-01-26 | 45SS, 63SS | 160d | 0d | start no earlier than 2024-10-09 | 1403/9/10 | 1403/11/7 | ME-1 |
| 89 | 2.2.2.1.5.2 | General Arrangement for (F-100 A/B) | 50d | 2024-11-30 | 2025-01-26 | 88SS | 160d | 30d | start no earlier than 2024-10-09 | 1403/9/10 | 1403/11/7 | ME-1 |
| 90 | 2.2.2.1.5.3 | Details Drawing for (F-100 A/B) | 50d | 2025-01-15 | 2025-03-13 | 89SS+10d, 66SS | 144d | 0d | start no earlier than 2024-10-09 | 1403/10/26 | 1403/12/23 | ME-2 |
| 91 | 2.2.2.1.5.4 | Name Plate Detail Drawing for (F-100 A/B) | 50d | 2025-01-15 | 2025-03-13 | 90SS | 202d | 0d | start no earlier than 2024-10-09 | 1403/10/26 | 1403/12/23 | ME-2 |
| 92 | 2.2.2.1.5.5 | Welding & NDT Map for (F-100 A/B) | 50d | 2025-03-03 | 2025-05-17 | 17FS+10d | 162d |  | start no earlier than 2024-10-09 | 1403/12/13 | 1404/2/27 | ME-3 |
| 93 | 2.2.2.1.6 | **Glycol Carbon Filter (F-200)** | 130d | 2024-11-30 | 2025-05-17 |  | 79d |  |  | 1403/9/10 | 1404/2/27 |  |
| 94 | 2.2.2.1.6.1 | Mechanical Calculation Book for F-200 | 50d | 2024-11-30 | 2025-01-26 | 41SS, 63SS | 79d | 0d | start no earlier than 2024-10-09 | 1403/9/10 | 1403/11/7 | ME-1 |
| 95 | 2.2.2.1.6.2 | General Arrangement for F-200 | 50d | 2024-11-30 | 2025-01-26 | 94SS | 79d | 26d | start no earlier than 2024-10-09 | 1403/9/10 | 1403/11/7 | ME-1 |
| 96 | 2.2.2.1.6.3 | Details Drawing for F-200 | 50d | 2025-01-15 | 2025-03-13 | 95SS+14d, 66SS | 53d | 0d | start no earlier than 2024-10-09 | 1403/10/26 | 1403/12/23 | ME-2 |
| 97 | 2.2.2.1.6.4 | Name Plate Detail Drawing for F-200 | 50d | 2025-01-15 | 2025-03-13 | 96SS, 91SS | 202d | 0d | start no earlier than 2024-10-09 | 1403/10/26 | 1403/12/23 | ME-2 |
| 98 | 2.2.2.1.6.5 | Welding & NDT Map for F-200 | 50d | 2025-03-03 | 2025-05-17 | 17FS+10d | 162d |  | start no earlier than 2024-10-09 | 1403/12/13 | 1404/2/27 | ME-3 |
| 99 | 2.2.2.1.7 | **Glycol Reflux Condenser (E-100)** | 130d | 2024-11-30 | 2025-05-17 |  | 83d |  |  | 1403/9/10 | 1404/2/27 |  |
| 100 | 2.2.2.1.7.1 | Thermal/Mechanical Calculation Book for E-100 | 50d | 2024-11-30 | 2025-01-26 | 48SS, 63SS | 83d | 0d | start no earlier than 2024-10-09 | 1403/9/10 | 1403/11/7 | ME-1 |
| 101 | 2.2.2.1.7.2 | General Arrangement for E-100 | 50d | 2024-11-30 | 2025-01-26 | 100SS | 181d | 44d | start no earlier than 2024-10-09 | 1403/9/10 | 1403/11/7 | ME-1 |
| 102 | 2.2.2.1.7.3 | Details Drawing for E-100 | 50d | 2025-01-15 | 2025-03-13 | 100SS+10d, 66SS | 53d | 0d | start no earlier than 2024-10-09 | 1403/10/26 | 1403/12/23 | ME-2 |
| 103 | 2.2.2.1.7.4 | Name Plate Detail Drawing for E-100 | 50d | 2025-01-15 | 2025-03-13 | 102SS, 97SS | 202d | 0d | start no earlier than 2024-10-09 | 1403/10/26 | 1403/12/23 | ME-2 |
| 104 | 2.2.2.1.7.5 | Welding & NDT Map for E-100 | 50d | 2025-03-03 | 2025-05-17 | 17FS+10d | 162d |  | start no earlier than 2024-10-09 | 1403/12/13 | 1404/2/27 | ME-3 |
| 105 | 2.2.2.1.8 | **Rich-Lean Glycol Heat Exchanger (E-200)** | 130d | 2024-11-30 | 2025-05-17 |  | 79d |  |  | 1403/9/10 | 1404/2/27 |  |
| 106 | 2.2.2.1.8.1 | Thermal/Mechanical Calculation Book for E-200 | 50d | 2024-11-30 | 2025-01-26 | 50SS, 63SS | 79d | 0d | start no earlier than 2024-10-09 | 1403/9/10 | 1403/11/7 | ME-1 |
| 107 | 2.2.2.1.8.2 | General Arrangement for E-200 | 50d | 2024-11-30 | 2025-01-26 | 106SS | 79d | 26d | start no earlier than 2024-10-09 | 1403/9/10 | 1403/11/7 | ME-1 |
| 108 | 2.2.2.1.8.3 | Details Drawing for E-200 | 50d | 2025-01-15 | 2025-03-13 | 107SS+14d, 66SS | 53d | 0d | start no earlier than 2024-10-09 | 1403/10/26 | 1403/12/23 | ME-2 |
| 109 | 2.2.2.1.8.4 | Name Plate Detail Drawing for E-200 | 50d | 2025-01-15 | 2025-03-13 | 108SS, 103SS | 202d | 0d | start no earlier than 2024-10-09 | 1403/10/26 | 1403/12/23 | ME-2 |
| 110 | 2.2.2.1.8.5 | Welding & NDT Map for F-200 | 50d | 2025-03-03 | 2025-05-17 | 17FS+10d | 162d |  | start no earlier than 2024-10-09 | 1403/12/13 | 1404/2/27 | ME-3 |

| ID | WBS | Task | Duration | Start | Finish | Predecessors | Total slack | Free slack | Constraint | شروع | پایان | Text3 |
| --- | --- | --- | --- | --- | --- | --- | --- | --- | --- | --- | --- | --- |
| 111 | 2.2.2.1.9 | **Lean Glycol-Dry Gas Heat Exchanger (E-300)** | 130d | 2024-11-30 | 2025-05-17 |  | 141d |  |  | 1403/9/10 | 1404/2/27 |  |
| 112 | 2.2.2.1.9.1 | Thermal/Mechanical Calculation Book for E-300 | 50d | 2024-11-30 | 2025-01-26 | 49SS, 63SS | 141d | 0d | start no earlier than 2024-10-09 | 1403/9/10 | 1403/11/7 | ME-1 |
| 113 | 2.2.2.1.9.2 | General Arrangement Drawing for E-300 | 50d | 2024-11-30 | 2025-01-26 | 112SS | 141d | 25d | start no earlier than 2024-10-09 | 1403/9/10 | 1403/11/7 | ME-1 |
| 114 | 2.2.2.1.9.3 | Details Drawing for E-300 | 50d | 2025-01-15 | 2025-03-13 | 113SS+15d, 66SS | 116d | 0d | start no earlier than 2024-10-09 | 1403/10/26 | 1403/12/23 | ME-2 |
| 115 | 2.2.2.1.9.4 | Name Plate Detail Drawing for E-300 | 50d | 2025-01-15 | 2025-03-13 | 114SS, 109SS | 202d | 0d | start no earlier than 2024-10-09 | 1403/10/26 | 1403/12/23 | ME-2 |
| 116 | 2.2.2.1.9.5 | Welding & NDT Map for E-300 | 50d | 2025-03-03 | 2025-05-17 | 17FS+10d | 162d |  | start no earlier than 2024-10-09 | 1403/12/13 | 1404/2/27 | ME-3 |
| 117 | 2.2.2.1.10 | **Reboiler (R-100)** | 130d | 2024-11-30 | 2025-05-17 |  | 79d |  |  | 1403/9/10 | 1404/2/27 |  |
| 118 | 2.2.2.1.10.1 | Thermal/Mechanical Calculation Book for R-100 | 50d | 2024-11-30 | 2025-01-26 | 42SS, 63SS | 79d | 0d | start no earlier than 2024-10-09 | 1403/9/10 | 1403/11/7 | ME-1 |
| 119 | 2.2.2.1.10.2 | General Arrangement for R-100 | 50d | 2024-11-30 | 2025-01-26 | 118SS | 79d | 26d | start no earlier than 2024-10-09 | 1403/9/10 | 1403/11/7 | ME-1 |
| 120 | 2.2.2.1.10.3 | Details Drawing for R-100 | 50d | 2025-01-15 | 2025-03-13 | 119SS+14d, 66SS | 53d | 0d | start no earlier than 2024-10-09 | 1403/10/26 | 1403/12/23 | ME-2 |
| 121 | 2.2.2.1.10.4 | Name Plate Detail Drawing for R-100 | 50d | 2025-01-15 | 2025-03-13 | 120SS, 115SS | 202d |  | start no earlier than 2024-10-09 | 1403/10/26 | 1403/12/23 | ME-2 |
| 122 | 2.2.2.1.10.5 | Welding & NDT Map for R-100 | 50d | 2025-03-03 | 2025-05-17 | 17FS+10d | 162d |  | start no earlier than 2024-10-09 | 1403/12/13 | 1404/2/27 | ME-3 |
| 123 | 2.2.2.1.11 | **Surge Drum (V-130)** | 130d | 2024-11-30 | 2025-05-17 |  | 79d |  |  | 1403/9/10 | 1404/2/27 |  |
| 124 | 2.2.2.1.11.1 | Mechanical Calculation Book for V-130 | 50d | 2024-11-30 | 2025-01-26 | 43SS, 63SS | 79d | 0d | start no earlier than 2024-10-09 | 1403/9/10 | 1403/11/7 | ME-1 |
| 125 | 2.2.2.1.11.2 | General Arrangement Drawing for V-130 | 50d | 2024-11-30 | 2025-01-26 | 124SS | 79d | 26d | start no earlier than 2024-10-09 | 1403/9/10 | 1403/11/7 | ME-1 |
| 126 | 2.2.2.1.11.3 | Details Drawing for V-130 | 50d | 2025-01-15 | 2025-03-13 | 125SS+14d, 66SS | 53d | 0d | start no earlier than 2024-10-09 | 1403/10/26 | 1403/12/23 | ME-2 |
| 127 | 2.2.2.1.11.4 | Name Plate Detail Drawing for V-130 | 50d | 2025-01-15 | 2025-03-13 | 126SS | 202d |  | start no earlier than 2024-10-09 | 1403/10/26 | 1403/12/23 | ME-2 |
| 128 | 2.2.2.1.11.5 | Welding & NDT Map for V-130 | 50d | 2025-03-03 | 2025-05-17 | 17FS+10d | 162d |  | start no earlier than 2024-10-09 | 1403/12/13 | 1404/2/27 | ME-3 |
| 129 | 2.2.2.2 | **MACHINERY** | 106d | 2024-11-21 | 2025-04-10 |  | 39d |  |  | 1403/9/1 | 1404/1/21 |  |
| 130 | 2.2.2.2.1 | BURNER DATA SHEET FOR GLYCOL REBOILER | 50d | 2024-11-21 | 2025-01-18 | 47SS+16d | 39d | 0d | start no earlier than 2024-10-09 | 1403/9/1 | 1403/10/29 | ME-5 |
| 131 | 2.2.2.2.2 | BURNER DRAWING FOR GLYCOL REBOILER | 50d | 2024-11-21 | 2025-01-18 | 130SS | 249d |  | start no earlier than 2024-10-09 | 1403/9/1 | 1403/10/29 | ME-5 |
| 132 | 2.2.2.2.3 | LUBRICATION LIST FOR GAS DEHYDRATION PACKAGE | 50d | 2025-01-15 | 2025-03-13 | 126SS | 193d | 0d | start no earlier than 2024-10-09 | 1403/10/26 | 1403/12/23 | ME-2 |
| 133 | 2.2.2.2.4 | GENERAL ASSEMBLY DRAWING FOR GLYCOL CIRCULATION PUMPS | 50d | 2025-01-19 | 2025-04-03 | 132SS+3d | 193d | 0d | start no earlier than 2024-10-09 | 1403/10/30 | 1404/1/14 | ME-4 |
| 134 | 2.2.2.2.5 | PUMPS CROSS SECTIONAL DRAWING FOR GLYCOL CIRCULATION PUMPS | 50d | 2025-01-23 | 2025-04-08 | 133SS+4d | 195d |  | start no earlier than 2024-10-09 | 1403/11/4 | 1404/1/19 | ME-4 |
| 135 | 2.2.2.2.6 | NAME PLATE FOR GLYCOL CIRCULATION PUMPS | 50d | 2025-01-26 | 2025-04-10 | 133SS+6d | 193d |  | start no earlier than 2024-10-09 | 1403/11/7 | 1404/1/21 | ME-4 |

| ID | WBS | Task | Duration | Start | Finish | Predecessors | Total slack | Free slack | Constraint | شروع | پایان | Text3 |
| --- | --- | --- | --- | --- | --- | --- | --- | --- | --- | --- | --- | --- |
| 136 | 2.2.3 | **STRUCTURE DOCUMENTS** | 70d | 2025-01-30 | 2025-05-08 |  | 89d |  |  | 1403/11/11 | 1404/2/18 |  |
| 137 | 2.2.3.1 | STRUCTURAL DESIGN CALCULATION FOR GAS DEHYDRATION PACKAGE | 50d | 2025-01-30 | 2025-04-15 | 64FS+3d | 89d | 0d | start no earlier than 2024-10-09 | 1403/11/11 | 1404/1/26 | ST-1 |
| 138 | 2.2.3.2 | FOUNDATION LOADING DATA FOR GAS DEHYDRATION PACKAGE | 50d | 2025-02-11 | 2025-04-27 | 137SS+10d | 89d | 0d | start no earlier than 2024-10-09 | 1403/11/23 | 1404/2/7 | ST-2 |
| 139 | 2.2.3.3 | STEEL STRUCTURAL DETAIL DRAWING FOR GAS DEHYDRATION PACKAGE | 50d | 2025-02-23 | 2025-05-08 | 138SS+10d | 89d | 0d | start no earlier than 2024-10-09 | 1403/12/5 | 1404/2/18 | ST-3 |
| 140 | 2.2.4 | **PIPING DOCUMENTS** | 140d | 2025-01-23 | 2025-07-22 |  | 0d |  |  | 1403/11/4 | 1404/4/31 |  |
| 141 | 2.2.4.1 | 3D MODEL NAVIS FILE AND PDMS DATA BASE (60%) FOR GAS DEHYDRATION PACKAGE | 40d | 2025-04-21 | 2025-06-05 | 149FS+20d | 0d |  | start no earlier than 2024-10-09 | 1404/2/1 | 1404/3/15 | PI-3 |
| 142 | 2.2.4.2 | 3D MODEL NAVIS FILE AND PDMS DATA BASE (90%) FOR GAS DEHYDRATION PACKAGE | 40d | 2025-06-07 | 2025-07-22 | 141 | 0d |  | start no earlier than 2024-10-09 | 1404/3/17 | 1404/4/31 | PI-4 |
| 143 | 2.2.4.3 | PIPING ISOMETRIC DRAWING FOR GAS DEHYDRATION PACKAGE | 40d | 2025-05-03 | 2025-06-17 | 141SS+10d | 135d |  | start no earlier than 2024-10-09 | 1404/2/13 | 1404/3/27 | PI-1 |
| 144 | 2.2.4.4 | PIPING GENERAL ARRANGEMENT DRAWING FOR GAS DEHYDRATION PACKAGE | 40d | 2025-05-03 | 2025-06-17 | 141SS+10d, 143SS | 45d | 0d | start no earlier than 2024-10-09 | 1404/2/13 | 1404/3/27 | PI-1 |
| 145 | 2.2.4.5 | PACKAGE PLOT PLAN FOR GAS DEHYDRATION PACKAGE | 40d | 2025-05-03 | 2025-06-17 | 141SS+10d, 144SS | 135d |  | start no earlier than 2024-10-09 | 1404/2/13 | 1404/3/27 | PI-1 |
| 146 | 2.2.4.6 | LINE LIST FOR GAS DEHYDRATION PACKAGE | 40d | 2025-01-23 | 2025-03-10 | 36FS+40d | 0d |  | start no earlier than 2024-10-09 | 1403/11/4 | 1403/12/20 | P-2 |
| 147 | 2.2.4.7 | TIE-IN-LIST FOR GAS DEHYDRATION PACKAGE | 40d | 2025-01-23 | 2025-03-10 | 36FS+40d, 146SS | 0d |  | start no earlier than 2024-10-09 | 1403/11/4 | 1403/12/20 | P-2 |
| 148 | 2.2.4.8 | SUPPORT LIST FOR GAS DEHYDRATION PACKAGE | 40d | 2025-01-23 | 2025-03-10 | 36FS+40d, 147SS | 0d |  | start no earlier than 2024-10-09 | 1403/11/4 | 1403/12/20 | P-2 |
| 149 | 2.2.4.9 | STRESS ANALYSIS REPORT FOR GAS DEHYDRATION PACKAGE | 40d | 2025-01-23 | 2025-03-10 | 36FS+40d, 148SS | 0d |  | start no earlier than 2024-10-09 | 1403/11/4 | 1403/12/20 | P-2 |
| 150 | 2.2.5 | **ELECTRICAL DOCUMENTS** | 220d | 2024-11-26 | 2025-08-26 |  | 41d |  |  | 1403/9/6 | 1404/6/4 |  |
| 151 | 2.2.5.1 | Electrical single line diagram | 50d | 2024-11-26 | 2025-01-22 | 36SS+40d | 41d | 0d | start no earlier than 2024-10-09 | 1403/9/6 | 1403/11/3 | El-1 |
| 152 | 2.2.5.2 | ELECTRICAL PANEL LAYOUT AND WIRING DIAGRAM | 50d | 2024-11-26 | 2025-01-22 | 36SS, 151SS | 177d | 167d | start no earlier than 2024-10-09 | 1403/9/6 | 1403/11/3 | El-1 |
| 153 | 2.2.5.3 | Local control station (LCS) panel layout and wiring diagram | 50d | 2024-11-26 | 2025-01-22 | 151SS | 110d | 10d | start no earlier than 2024-10-09 | 1403/9/6 | 1403/11/3 | El-1 |
| 154 | 2.2.5.4 | Earthing detail layout | 50d | 2025-06-30 | 2025-08-26 | 151SS+1d, 160SS+2d, 152SS+1d, 161SS+2d, 162SS+2d, 163SS+2d, 142SS+20d | 75d | 0d | start no earlier than 2024-10-09 | 1404/4/9 | 1404/6/4 | El-2 |
| 155 | 2.2.5.5 | ELECTRICAL EQUIPMENT LAYOUT | 50d | 2025-06-30 | 2025-08-26 | 151SS+1d, 152SS+1d, 161SS+2d, 162SS+2d, 154SS | 75d | 0d | start no earlier than 2024-10-09 | 1404/4/9 | 1404/6/4 | El-2 |
| 156 | 2.2.5.6 | Electrical Cable Route | 50d | 2025-06-30 | 2025-08-26 | 155SS | 75d |  | start no earlier than 2024-10-09 | 1404/4/9 | 1404/6/4 | El-2 |
| 157 | 2.2.5.7 | Power and control cable list | 50d | 2025-06-30 | 2025-08-26 | 151SS+3d, 152SS+3d, 142SS+20d | 10d | 0d | start no earlier than 2024-10-09 | 1404/4/9 | 1404/6/4 | El-3 |
| 158 | 2.2.5.8 | Electrical load list | 50d | 2025-06-30 | 2025-08-26 | 15SS+7d, 47SS+7d, 14SS+7d, 157SS | 75d | 0d | start no earlier than 2024-10-09 | 1404/4/9 | 1404/6/4 | El-3 |
| 159 | 2.2.5.9 | ELECTRICAL SIGNAL LIST | 50d | 2025-06-30 | 2025-08-26 | 15SS+7d, 47SS+7d, 14SS+7d, 158SS | 75d |  | start no earlier than 2024-10-09 | 1404/4/9 | 1404/6/4 | El-3 |
| 160 | 2.2.5.10 | Electrical motor data sheets , CURVES, DRAWINGS AND CERTIFICATES | 50d | 2025-04-03 | 2025-05-31 | 247FS+20d | 148d | 0d | start no earlier than 2024-10-09 | 1404/1/14 | 1404/3/10 | El-4 |
| 161 | 2.2.5.11 | CABLE DATASHEETS | 50d | 2025-04-03 | 2025-05-31 | 160SS | 148d | 0d | start no earlier than 2024-10-09 | 1404/1/14 | 1404/3/10 | El-4 |
| 162 | 2.2.5.12 | ELECTRICAL PANEL DATASHEETS | 50d | 2025-04-03 | 2025-05-31 | 161SS | 148d | 0d | start no earlier than 2024-10-09 | 1404/1/14 | 1404/3/10 | El-4 |
| 163 | 2.2.5.13 | LOCAL CONTROL STATION (LCS) DATASHEETS | 50d | 2025-04-03 | 2025-05-31 | 162SS | 148d | 73d | start no earlier than 2024-10-09 | 1404/1/14 | 1404/3/10 | El-4 |

| ID | WBS | Task | Duration | Start | Finish | Predecessors | Total slack | Free slack | Constraint | شروع | پایان | Text3 |
| --- | --- | --- | --- | --- | --- | --- | --- | --- | --- | --- | --- | --- |
| 164 | 2.2.6 | **INSTRUMENT DOCUMENTS** | 190d | 2024-12-08 | 2025-08-03 |  | 41d |  |  | 1403/9/18 | 1404/5/12 |  |
| 165 | 2.2.6.1 | Instrument list | 50d | 2024-12-19 | 2025-02-15 | 36SS+60d | 31d | 0d | start no earlier than 2024-10-09 | 1403/9/29 | 1403/11/27 | IN-7 |
| 166 | 2.2.6.2 | Input/Output signal list | 50d | 2024-12-19 | 2025-02-15 | 165SS | 31d | 0d | start no earlier than 2024-10-09 | 1403/9/29 | 1403/11/27 | IN-7 |
| 167 | 2.2.6.3 | Instrument cable list | 50d | 2024-12-19 | 2025-02-15 | 166SS, 36SS, 173SS | 160d | 0d | start no earlier than 2024-10-09 | 1403/9/29 | 1403/11/27 | IN-7 |
| 168 | 2.2.6.4 | UCP and BMS system power consumption list | 50d | 2024-12-19 | 2025-02-15 | 167SS | 225d | 0d | start no earlier than 2024-10-09 | 1403/9/29 | 1403/11/27 | IN-7 |
| 169 | 2.2.6.5 | Modbus IO list (Modbus mapping list) | 50d | 2024-12-19 | 2025-02-15 | 168SS | 225d |  | start no earlier than 2024-10-09 | 1403/9/29 | 1403/11/27 | IN-7 |
| 170 | 2.2.6.6 | CONTROL SYSTEM CONFIGURATION BLOCK DIAGRAM | 50d | 2024-12-08 | 2025-02-03 | 36, 151SS+10d | 41d | 0d | start no earlier than 2024-10-09 | 1403/9/18 | 1403/11/15 | IN-2 |
| 171 | 2.2.6.7 | ESD/BMS SYSTEM CONFIGURATION BLOCK DIAGRAM | 50d | 2024-12-08 | 2025-02-03 | 170SS | 41d | 10d | start no earlier than 2024-10-09 | 1403/9/18 | 1403/11/15 | IN-2 |
| 172 | 2.2.6.8 | Instrument junction box layout and wiring termination diagram | 50d | 2024-12-08 | 2025-02-03 | 170SS | 100d | 0d | start no earlier than 2024-10-09 | 1403/9/18 | 1403/11/15 | IN-2 |
| 173 | 2.2.6.9 | Burner operation panel layout & wiring diagram with connections & dimensions | 50d | 2024-12-08 | 2025-02-03 | 172SS | 100d | 0d | start no earlier than 2024-10-09 | 1403/9/18 | 1403/11/15 | IN-2 |
| 174 | 2.2.6.10 | Instrument D.S. for control valves | 50d | 2024-12-31 | 2025-02-26 | 36FS+20d | 21d | 0d | start no earlier than 2024-10-09 | 1403/10/11 | 1403/12/8 | IN-5 |
| 175 | 2.2.6.11 | Instrument D.S. for On/Off valves | 50d | 2024-12-31 | 2025-02-26 | 174SS, 37SS, 38SS | 21d | 0d | start no earlier than 2024-10-09 | 1403/10/11 | 1403/12/8 | IN-5 |
| 176 | 2.2.6.12 | Instrument D.S. for H2O analyzer | 50d | 2024-12-31 | 2025-02-26 | 175SS | 85d | 0d | start no earlier than 2024-10-09 | 1403/10/11 | 1403/12/8 | IN-5 |
| 177 | 2.2.6.13 | Instrument D.S. for temperature gauge | 50d | 2024-12-31 | 2025-02-26 | 176SS | 211d | 0d | start no earlier than 2024-10-09 | 1403/10/11 | 1403/12/8 | IN-5 |
| 178 | 2.2.6.14 | Instrument D.S. for temperature transmitters | 50d | 2024-12-31 | 2025-02-26 | 177SS | 211d | 0d | start no earlier than 2024-10-09 | 1403/10/11 | 1403/12/8 | IN-5 |
| 179 | 2.2.6.15 | Instrument D.S. for pressure gauges and differential gauges | 50d | 2024-12-31 | 2025-02-26 | 178SS | 211d | 0d | start no earlier than 2024-10-09 | 1403/10/11 | 1403/12/8 | IN-5 |
| 180 | 2.2.6.16 | Instrument D.S. for pressure transmitters and differentia pressure transmitters | 50d | 2024-12-31 | 2025-02-26 | 179SS | 211d | 0d | start no earlier than 2024-10-09 | 1403/10/11 | 1403/12/8 | IN-5 |
| 181 | 2.2.6.17 | INSTRUMENT D.S. FOR SAFETY VALVES | 50d | 2024-12-31 | 2025-02-26 | 180SS | 211d | 0d | start no earlier than 2024-10-09 | 1403/10/11 | 1403/12/8 | IN-5 |
| 182 | 2.2.6.18 | Instrument D.S. for pressure regulator valves | 50d | 2024-12-31 | 2025-02-26 | 181SS | 211d | 0d | start no earlier than 2024-10-09 | 1403/10/11 | 1403/12/8 | IN-5 |
| 183 | 2.2.6.19 | Instrument D.S. for flow elements | 50d | 2024-12-31 | 2025-02-26 | 182SS | 211d | 0d | start no earlier than 2024-10-09 | 1403/10/11 | 1403/12/8 | IN-5 |
| 184 | 2.2.6.20 | Instrument D.S. for level gauges | 50d | 2024-12-31 | 2025-02-26 | 183SS | 211d | 0d | start no earlier than 2024-10-09 | 1403/10/11 | 1403/12/8 | IN-5 |
| 185 | 2.2.6.21 | Instrument D.S. for level transmitters | 50d | 2024-12-31 | 2025-02-26 | 184SS | 211d | 16d | start no earlier than 2024-10-09 | 1403/10/11 | 1403/12/8 | IN-5 |
| 186 | 2.2.6.22 | Flame scanner data sheet | 50d | 2024-12-31 | 2025-02-26 | 184SS | 215d |  | start no earlier than 2024-10-09 | 1403/10/11 | 1403/12/8 | IN-5 |
| 187 | 2.2.6.23 | Instrument location layout | 50d | 2025-06-07 | 2025-08-03 | 142SS | 0d |  | start no earlier than 2024-10-09 | 1404/3/17 | 1404/5/12 | IN-4 |
| 188 | 2.2.6.24 | INSTRUMENT EARTH DISTRIBUTION DIAGRAM | 50d | 2025-06-07 | 2025-08-03 | 187SS | 0d |  | start no earlier than 2024-10-09 | 1404/3/17 | 1404/5/12 | IN-4 |
| 189 | 2.2.6.25 | INSTRUMENT CABLE ROUTE/ MAIN TUBING LAYOUT DRAWING | 50d | 2025-06-07 | 2025-08-03 | 188SS | 0d |  | start no earlier than 2024-10-09 | 1404/3/17 | 1404/5/12 | IN-4 |
| 190 | 2.2.6.26 | CONTROL PANEL LAYOUT AND ARRANGEMENT | 50d | 2025-01-23 | 2025-04-08 | 36FS+8d, 208 | 125d | 0d | start no earlier than 2024-10-09 | 1403/11/4 | 1404/1/19 | IN-3 |
| 191 | 2.2.6.27 | ESD/BMS PANEL LAYOUT AND ARRANGEMENT | 50d | 2025-01-23 | 2025-04-08 | 190SS | 195d |  | start no earlier than 2024-10-09 | 1403/11/4 | 1404/1/19 | IN-3 |
| 192 | 2.2.6.28 | CONTROL SYSTEM WIRING DIAGRAM AND CONNECTIONS | 50d | 2025-01-23 | 2025-04-08 | 190SS, 191SS | 195d | 0d | start no earlier than 2024-10-09 | 1403/11/4 | 1404/1/19 | IN-3 |
| 193 | 2.2.6.29 | ESD/BMS SYSTEM WIRING DIAGRAM AND CONNECTIONS | 50d | 2025-01-23 | 2025-04-08 | 190SS, 192SS | 195d | 0d | start no earlier than 2024-10-09 | 1403/11/4 | 1404/1/19 | IN-3 |
| 194 | 2.2.6.30 | CONTROL SYSTEM CABINETS AND CONSOLES LAYOUT DRAWING | 50d | 2025-01-23 | 2025-04-08 | 190SS, 193SS | 195d | 0d | start no earlier than 2024-10-09 | 1403/11/4 | 1404/1/19 | IN-3 |
| 195 | 2.2.6.31 | CONTROL SYSTEM LOGIC DIAGRAM | 50d | 2025-01-23 | 2025-04-08 | 190SS, 194SS | 195d | 0d | start no earlier than 2024-10-09 | 1403/11/4 | 1404/1/19 | IN-3 |
| 196 | 2.2.6.32 | ESD/BMS SYSTEM LOGIC DIAGRAM | 50d | 2025-01-23 | 2025-04-08 | 190SS, 195SS | 195d | 0d | start no earlier than 2024-10-09 | 1403/11/4 | 1404/1/19 | IN-3 |
| 197 | 2.2.6.33 | PRINT OUT OF HMI FOR BMS and UCP | 50d | 2025-01-23 | 2025-04-08 | 190SS, 196SS | 195d |  | start no earlier than 2024-10-09 | 1403/11/4 | 1404/1/19 | IN-3 |
| 198 | 2.2.6.34 | Hook up drawing | 50d | 2025-01-23 | 2025-04-08 | 36SS+31d, 185SS+4d, 64SS, 71SS, 77SS+3d, 83SS+3d, 89SS+3d, 95SS+3d, 101SS+3d, 107SS+3d, 113SS+3d, 119SS+3d, 125SS+3d, 133SS+3d, 190SS | 195d |  | start no earlier than 2024-10-09 | 1403/11/4 | 1404/1/19 | IN-3 |
| 199 | 2.2.6.35 | ESD LEVEL HIERARCHY | 50d | 2025-01-23 | 2025-04-08 | 36SS+31d, 185SS+4d, 64SS, 71SS, 77SS+3d, 83SS+3d, 89SS+3d, 95SS+3d, 101SS+3d, 107SS+3d, 113SS+3d, 119SS+3d, 125SS+3d, 133SS+3d, 190SS | 195d |  | start no earlier than 2024-10-09 | 1403/11/4 | 1404/1/19 | IN-3 |
| 200 | 2.2.6.36 | FAT PROCEDURE FOR CONTROL SYSTEM | 50d | 2025-05-03 | 2025-06-29 | 190FS+20d | 125d |  | start no earlier than 2024-10-09 | 1404/2/13 | 1404/4/8 | IN-6 |
| 201 | 2.2.6.37 | FAT PROCEDURE FOR ESD/BMS SYSTEM | 50d | 2025-05-03 | 2025-06-29 | 190FS+20d, 200SS | 125d | 0d | start no earlier than 2024-10-09 | 1404/2/13 | 1404/4/8 | IN-6 |
| 202 | 2.2.6.38 | SAT PROCEDURE FOR CONTROL SYSTEM | 50d | 2025-05-03 | 2025-06-29 | 190FS+20d, 201SS | 125d | 0d | start no earlier than 2024-10-09 | 1404/2/13 | 1404/4/8 | IN-6 |
| 203 | 2.2.6.39 | SAT PROCEDURE FOR ESD/BMS SYSTEM | 50d | 2025-05-03 | 2025-06-29 | 190FS+20d, 202SS | 125d | 0d | start no earlier than 2024-10-09 | 1404/2/13 | 1404/4/8 | IN-6 |
| 204 | 2.2.6.40 | ITP FOR CONTROL SYSTEM | 50d | 2025-05-03 | 2025-06-29 | 190FS+20d, 203SS | 125d | 0d | start no earlier than 2024-10-09 | 1404/2/13 | 1404/4/8 | IN-6 |
| 205 | 2.2.6.41 | ITP FOR ESD/BMS SYSTEM | 50d | 2025-05-03 | 2025-06-29 | 190FS+20d, 204SS | 125d |  | start no earlier than 2024-10-09 | 1404/2/13 | 1404/4/8 | IN-6 |

| ID | WBS | Task | Duration | Start | Finish | Predecessors | Total slack | Free slack | Constraint | شروع | پایان |
| --- | --- | --- | --- | --- | --- | --- | --- | --- | --- | --- | --- |
| 206 | 3 | **RAW MATERIAL** | 300d | 2024-11-09 | 2025-11-10 |  | 9d |  |  | 1403/8/19 | 1404/8/19 |
| 207 | 3.1 | **BMS & UCP** | 240d | 2024-12-19 | 2025-10-12 |  | 31d |  |  | 1403/9/29 | 1404/7/20 |
| 208 | 3.1.1 | PO | 30d | 2024-12-19 | 2025-01-22 | 166SS, 170SS, 171SS, 36 | 31d | 0d | start no earlier than 2024-10-09 | 1403/9/29 | 1403/11/3 |
| 209 | 3.1.2 | Supply/Receive | 210d | 2025-01-23 | 2025-10-12 | 208 | 31d | 0d | start no earlier than 2024-10-09 | 1403/11/4 | 1404/7/20 |
| 210 | 3.2 | **Field Instrument** | 135d | 2025-02-27 | 2025-08-20 |  | 70d |  |  | 1403/12/9 | 1404/5/29 |
| 211 | 3.2.1 | PO | 15d | 2025-02-27 | 2025-04-02 | 174 | 70d | 0d | start no earlier than 2024-10-09 | 1403/12/9 | 1404/1/13 |
| 212 | 3.2.2 | Supply/Receive | 120d | 2025-04-03 | 2025-08-20 | 211 | 70d | 0d | start no earlier than 2024-10-09 | 1404/1/14 | 1404/5/29 |
| 213 | 3.3 | **Pipe** | 30d | 2025-03-15 | 2025-05-05 |  | 35d |  |  | 1403/12/25 | 1404/2/15 |
| 214 | 3.3.1 | PO | 5d | 2025-03-15 | 2025-04-06 | 66 | 35d | 0d | start no earlier than 2024-10-09 | 1403/12/25 | 1404/1/17 |
| 215 | 3.3.2 | Supply/Receive | 25d | 2025-04-07 | 2025-05-05 | 214 | 35d | 0d | start no earlier than 2024-10-09 | 1404/1/18 | 1404/2/15 |
| 216 | 3.4 | **plate** | 60d | 2025-02-08 | 2025-05-05 |  | 53d |  |  | 1403/11/20 | 1404/2/15 |
| 217 | 3.4.1 | PO | 10d | 2025-02-08 | 2025-02-18 | 65SS+20d, 72SS+20d, 78SS+20d, 96SS+20d, 102SS+20d, 108SS+20d, 120SS+20d, 126SS+20d | 53d | 0d | start no earlier than 2024-10-09 | 1403/11/20 | 1403/11/30 |
| 218 | 3.4.2 | Supply/Receive | 50d | 2025-02-19 | 2025-05-05 | 217 | 53d | 0d | start no earlier than 2024-10-09 | 1403/12/1 | 1404/2/15 |
| 219 | 3.5 | **Flange** | 110d | 2025-03-15 | 2025-08-06 |  | 18d |  |  | 1403/12/25 | 1404/5/15 |
| 220 | 3.5.1 | PO | 5d | 2025-03-15 | 2025-04-06 | 66 | 18d | 0d | start no earlier than 2024-10-09 | 1403/12/25 | 1404/1/17 |
| 221 | 3.5.2 | Supply/Receive | 105d | 2025-04-07 | 2025-08-06 | 220 | 18d | 0d | start no earlier than 2024-10-09 | 1404/1/18 | 1404/5/15 |
| 222 | 3.6 | **Gasket** | 45d | 2025-07-29 | 2025-09-18 |  | 49d |  |  | 1404/5/7 | 1404/6/27 |
| 223 | 3.6.1 | PO | 5d | 2025-07-29 | 2025-08-03 | 239FS+40d | 49d | 0d |  | 1404/5/7 | 1404/5/12 |
| 224 | 3.6.2 | Supply/Receive | 40d | 2025-08-04 | 2025-09-18 | 223 | 49d | 0d |  | 1404/5/13 | 1404/6/27 |
| 225 | 3.7 | **Fitting** | 30d | 2025-03-15 | 2025-05-05 |  | 98d |  |  | 1403/12/25 | 1404/2/15 |
| 226 | 3.7.1 | PO | 5d | 2025-03-15 | 2025-04-06 | 65, 72, 78, 96, 102, 108, 120, 126 | 98d | 0d | start no earlier than 2024-10-09 | 1403/12/25 | 1404/1/17 |
| 227 | 3.7.2 | Supply/Receive | 25d | 2025-04-07 | 2025-05-05 | 226 | 98d | 80d | start no earlier than 2024-10-09 | 1404/1/18 | 1404/2/15 |
| 228 | 3.8 | **Bolt & Nut** | 45d | 2025-07-29 | 2025-09-18 |  | 49d |  |  | 1404/5/7 | 1404/6/27 |
| 229 | 3.8.1 | PO | 5d | 2025-07-29 | 2025-08-03 | 239FS+40d | 49d | 0d |  | 1404/5/7 | 1404/5/12 |
| 230 | 3.8.2 | Supply/Receive | 40d | 2025-08-04 | 2025-09-18 | 229 | 49d | 0d |  | 1404/5/13 | 1404/6/27 |

| ID | WBS | Task | Duration | Start | Finish | Predecessors | Total slack | Free slack | Constraint | شروع | پایان |
| --- | --- | --- | --- | --- | --- | --- | --- | --- | --- | --- | --- |
| 231 | 3.9 | **Valves** | 184d | 2025-02-27 | 2025-10-16 |  | 21d |  |  | 1403/12/9 | 1404/7/24 |
| 232 | 3.9.1 | PO | 15d | 2025-02-27 | 2025-04-02 | 174, 175 | 21d | 0d | start no earlier than 2024-10-09 | 1403/12/9 | 1404/1/13 |
| 233 | 3.9.2 | Supply/Receive | 169d | 2025-04-03 | 2025-10-16 | 232 | 21d | 0d | start no earlier than 2024-10-09 | 1404/1/14 | 1404/7/24 |
| 234 | 3.10 | **TEG Pumps - 2 Sets** | 170d | 2024-12-31 | 2025-08-03 |  | 85d |  |  | 1403/10/11 | 1404/5/12 |
| 235 | 3.10.1 | PO | 20d | 2024-12-31 | 2025-01-22 | 47 | 85d | 0d | start no earlier than 2024-10-09 | 1403/10/11 | 1403/11/3 |
| 236 | 3.10.2 | Supply/Receive | 150d | 2025-01-23 | 2025-08-03 | 235 | 85d | 0d | start no earlier than 2024-10-09 | 1403/11/4 | 1404/5/12 |
| 237 | 3.11 | **Internals** | 125d | 2024-12-31 | 2025-06-11 |  | 49d |  |  | 1403/10/11 | 1404/3/21 |
| 238 | 3.11.1 | PO | 15d | 2024-12-31 | 2025-01-16 | 52 | 49d | 0d | start no earlier than 2024-10-09 | 1403/10/11 | 1403/10/27 |
| 239 | 3.11.2 | Supply/Receive | 110d | 2025-01-18 | 2025-06-11 | 238 | 49d | 0d | start no earlier than 2024-10-09 | 1403/10/29 | 1404/3/21 |
| 240 | 3.12 | **Analyzer** | 170d | 2024-12-31 | 2025-08-03 |  | 85d |  |  | 1403/10/11 | 1404/5/12 |
| 241 | 3.12.1 | PO | 20d | 2024-12-31 | 2025-01-22 | 166SS, 176SS | 85d | 0d | start no earlier than 2024-10-09 | 1403/10/11 | 1403/11/3 |
| 242 | 3.12.2 | Supply/Receive | 150d | 2025-01-23 | 2025-08-03 | 241 | 85d |  | start no earlier than 2024-10-09 | 1403/11/4 | 1404/5/12 |
| 243 | 3.13 | **Burner** | 220d | 2024-12-26 | 2025-09-25 |  | 39d |  |  | 1403/10/6 | 1404/7/3 |
| 244 | 3.13.1 | PO | 20d | 2024-12-26 | 2025-01-18 | 130SS+30d | 39d | 0d | start no earlier than 2024-10-09 | 1403/10/6 | 1403/10/29 |
| 245 | 3.13.2 | Supply/Receive | 200d | 2025-01-19 | 2025-09-25 | 244 | 39d | 0d | start no earlier than 2024-10-09 | 1403/10/30 | 1404/7/3 |
| 246 | 3.14 | **Panel & Junction Box** | 125d | 2025-02-04 | 2025-07-16 |  | 100d |  |  | 1403/11/16 | 1404/4/25 |
| 247 | 3.14.1 | PO | 15d | 2025-02-04 | 2025-02-20 | 172, 153, 173 | 100d | 0d | start no earlier than 2024-10-09 | 1403/11/16 | 1403/12/2 |
| 248 | 3.14.2 | Supply/Receive | 110d | 2025-02-22 | 2025-07-16 | 247 | 100d | 0d | start no earlier than 2024-10-09 | 1403/12/4 | 1404/4/25 |
| 249 | 3.15 | **Profile** | 30d | 2025-03-15 | 2025-05-05 |  | 92d |  |  | 1403/12/25 | 1404/2/15 |
| 250 | 3.15.1 | PO | 5d | 2025-03-15 | 2025-04-06 | 65, 72, 78, 96, 102, 108, 120, 126 | 92d | 0d | start no earlier than 2024-10-09 | 1403/12/25 | 1404/1/17 |
| 251 | 3.15.2 | Supply/Receive | 25d | 2025-04-07 | 2025-05-05 | 250 | 92d | 3d | start no earlier than 2024-10-09 | 1404/1/18 | 1404/2/15 |
| 252 | 3.16 | **Injection Package** | 180d | 2024-12-31 | 2025-08-14 |  | 75d |  |  | 1403/10/11 | 1404/5/23 |
| 253 | 3.16.1 | PO | 15d | 2024-12-31 | 2025-01-16 | 52, 51 | 75d | 0d | start no earlier than 2024-10-09 | 1403/10/11 | 1403/10/27 |
| 254 | 3.16.2 | Supply/Receive | 165d | 2025-01-18 | 2025-08-14 | 253 | 75d | 0d | start no earlier than 2024-10-09 | 1403/10/29 | 1404/5/23 |

| ID | WBS | Task | Duration | Start | Finish | Predecessors | Total slack | Free slack | Constraint | شروع | پایان |
| --- | --- | --- | --- | --- | --- | --- | --- | --- | --- | --- | --- |
| 255 | 3.17 | **INSTRUMEN and Electrical Tray,support,ladder,Connection,…(Installation Cable Accessory)** | 135d | 2025-06-07 | 2025-11-10 |  | 0d |  |  | 1404/3/17 | 1404/8/19 |
| 256 | 3.17.1 | PO | 15d | 2025-06-07 | 2025-06-23 | 187SS, 188SS, 189SS | 0d |  | start no earlier than 2024-10-09 | 1404/3/17 | 1404/4/2 |
| 257 | 3.17.2 | Supply/Receive | 120d | 2025-06-24 | 2025-11-10 | 256 | 0d |  | start no earlier than 2024-10-09 | 1404/4/3 | 1404/8/19 |
| 258 | 3.18 | **Cable** | 55d | 2025-08-27 | 2025-10-29 |  | 10d |  |  | 1404/6/5 | 1404/8/7 |
| 259 | 3.18.1 | PO | 10d | 2025-08-27 | 2025-09-07 | 167, 157 | 10d | 0d | start no earlier than 2024-10-09 | 1404/6/5 | 1404/6/16 |
| 260 | 3.18.2 | Supply/Receive | 45d | 2025-09-08 | 2025-10-29 | 259 | 10d | 0d | start no earlier than 2024-10-09 | 1404/6/17 | 1404/8/7 |
| 261 | 3.19 | **Filter** | 120d | 2024-11-09 | 2025-04-14 |  | 189d |  |  | 1403/8/19 | 1404/1/25 |
| 262 | 3.19.1 | PO | 15d | 2024-11-09 | 2024-11-25 | 41, 45 | 189d | 0d | start no earlier than 2024-10-09 | 1403/8/19 | 1403/9/5 |
| 263 | 3.19.2 | Supply/Receive | 105d | 2024-11-26 | 2025-04-14 | 262 | 189d | 0d | start no earlier than 2024-10-09 | 1403/9/6 | 1404/1/25 |
| 264 | 3.20 | **Paint** | 35d | 2025-08-04 | 2025-09-13 |  | 51d | 0d |  | 1404/5/13 | 1404/6/22 |
| 265 | 3.20.1 | PO | 5d | 2025-08-04 | 2025-08-09 | 22, 239FS+45d | 51d | 0d |  | 1404/5/13 | 1404/5/18 |
| 266 | 3.20.2 | Supply/Receive | 30d | 2025-08-10 | 2025-09-13 | 265 | 51d | 0d |  | 1404/5/19 | 1404/6/22 |
| 267 | 4 | **Construction** | 168d | 2025-05-06 | 2025-11-17 |  | 4d |  |  | 1404/2/16 | 1404/8/26 |
| 268 | 4.1 | **Pressure Vessel** | 150d | 2025-05-06 | 2025-10-27 |  | 18d |  |  | 1404/2/16 | 1404/8/5 |
| 269 | 4.1.1 | **C-100 Glycol Contactor** | 150d | 2025-05-06 | 2025-10-27 |  | 18d |  |  | 1404/2/16 | 1404/8/5 |
| 270 | 4.1.1.1 | **Shell** | 11d | 2025-05-06 | 2025-05-18 |  | 76d |  |  | 1404/2/16 | 1404/2/28 |
| 271 | 4.1.1.1.1 | Marking & Cutting & Beveling | 3d | 2025-05-06 | 2025-05-08 | 64, 65, 218 | 76d | 0d |  | 1404/2/16 | 1404/2/18 |
| 272 | 4.1.1.1.2 | Pre- Assembling & Per-Welding of Plates | 3d | 2025-05-10 | 2025-05-12 | 271, 878 | 76d | 0d |  | 1404/2/20 | 1404/2/22 |
| 273 | 4.1.1.1.3 | Rolling | 2d | 2025-05-13 | 2025-05-14 | 272 | 76d | 0d |  | 1404/2/23 | 1404/2/24 |
| 274 | 4.1.1.1.4 | Assemble & Welding of Plates | 2d | 2025-05-15 | 2025-05-17 | 273 | 76d | 0d |  | 1404/2/25 | 1404/2/27 |
| 275 | 4.1.1.1.5 | Rerolling | 1d | 2025-05-18 | 2025-05-18 | 274 | 76d | 23d |  | 1404/2/28 | 1404/2/28 |
| 276 | 4.1.1.2 | **Head** | 34d | 2025-05-06 | 2025-06-14 |  | 53d |  |  | 1404/2/16 | 1404/3/24 |
| 277 | 4.1.1.2.1 | Marking & Cutting & Beveling head plate | 4d | 2025-05-06 | 2025-05-10 | 64, 65, 218 | 53d | 0d |  | 1404/2/16 | 1404/2/20 |
| 278 | 4.1.1.2.2 | Forming Head plate (sub contractor) | 30d | 2025-05-11 | 2025-06-14 | 277 | 53d | 0d |  | 1404/2/21 | 1404/3/24 |

| ID | WBS | Task | Duration | Start | Finish | Predecessors | Total slack | Free slack | Constraint | شروع | پایان |
| --- | --- | --- | --- | --- | --- | --- | --- | --- | --- | --- | --- |
| 279 | 4.1.1.3 | **External Part** | 86d | 2025-05-06 | 2025-08-13 |  | 25d |  |  | 1404/2/16 | 1404/5/22 |
| 280 | 4.1.1.3.1 | **Nozzles & Manholes** | 26d | 2025-07-15 | 2025-08-13 |  | 18d |  |  | 1404/4/24 | 1404/5/22 |
| 281 | 4.1.1.3.1.1 | Cutting & Beveling Pipe | 3d | 2025-07-15 | 2025-07-17 | 66, 215FS+60d | 35d | 17d | start no earlier than 2024-10-09 | 1404/4/24 | 1404/4/26 |
| 282 | 4.1.1.3.1.2 | Assembling of Pipe To Flange | 2d | 2025-08-07 | 2025-08-09 | 281, 221, 227 | 18d | 0d |  | 1404/5/16 | 1404/5/18 |
| 283 | 4.1.1.3.1.3 | Welding of Pipe To Flange | 4d | 2025-08-10 | 2025-08-13 | 282 | 18d | 0d |  | 1404/5/19 | 1404/5/22 |
| 284 | 4.1.1.3.2 | **Lifting & Other External Part** | 20d | 2025-05-06 | 2025-05-28 |  | 91d |  |  | 1404/2/16 | 1404/3/7 |
| 285 | 4.1.1.3.2.1 | Marking & Cutting & Beveling Lifting & Other External Part | 5d | 2025-05-06 | 2025-05-11 | 218 | 91d | 0d |  | 1404/2/16 | 1404/2/21 |
| 286 | 4.1.1.3.2.2 | Drilling Lifting & Other External Part | 6d | 2025-05-12 | 2025-05-18 | 285 | 91d | 0d |  | 1404/2/22 | 1404/2/28 |
| 287 | 4.1.1.3.2.3 | Assembling of external parts together | 4d | 2025-05-19 | 2025-05-22 | 286 | 91d | 0d |  | 1404/2/29 | 1404/3/1 |
| 288 | 4.1.1.3.2.4 | Welding of external parts together | 5d | 2025-05-24 | 2025-05-28 | 287 | 91d | 73d |  | 1404/3/3 | 1404/3/7 |
| 289 | 4.1.1.4 | **Internal Part** | 9d | 2025-05-06 | 2025-05-15 |  | 120d |  |  | 1404/2/16 | 1404/2/25 |
| 290 | 4.1.1.4.1 | Marking & Cutting & Beveling Internal Part | 1d | 2025-05-06 | 2025-05-06 | 218 | 120d | 0d |  | 1404/2/16 | 1404/2/16 |
| 291 | 4.1.1.4.2 | Drilling Internal Part | 3d | 2025-05-07 | 2025-05-10 | 290 | 120d | 0d |  | 1404/2/17 | 1404/2/20 |
| 292 | 4.1.1.4.3 | Assembling of Internal parts together | 3d | 2025-05-11 | 2025-05-13 | 291 | 120d | 0d |  | 1404/2/21 | 1404/2/23 |
| 293 | 4.1.1.4.4 | Welding of Internal parts together | 2d | 2025-05-14 | 2025-05-15 | 292 | 120d | 102d |  | 1404/2/24 | 1404/2/25 |
| 294 | 4.1.1.5 | **Final Assembly** | 91d | 2025-06-15 | 2025-09-28 |  | 18d |  |  | 1404/3/25 | 1404/7/6 |
| 295 | 4.1.1.5.1 | Assembling Shell course & head | 6d | 2025-06-15 | 2025-06-21 | 275, 278, 68, 879, 882 | 53d | 0d |  | 1404/3/25 | 1404/3/31 |
| 296 | 4.1.1.5.2 | Welding Shell course & head | 8d | 2025-06-22 | 2025-06-30 | 295 | 53d | 0d |  | 1404/4/1 | 1404/4/9 |
| 297 | 4.1.1.5.3 | Marking & Opening Nozzle | 3d | 2025-07-01 | 2025-07-03 | 296, 881 | 53d | 35d |  | 1404/4/10 | 1404/4/12 |
| 298 | 4.1.1.5.4 | Assembling nozzel & manhole | 2d | 2025-08-14 | 2025-08-16 | 283, 297 | 18d | 0d |  | 1404/5/23 | 1404/5/25 |
| 299 | 4.1.1.5.5 | Welding of nozzel & manhole | 5d | 2025-08-17 | 2025-08-21 | 298, 880 | 18d | 0d |  | 1404/5/26 | 1404/5/30 |
| 300 | 4.1.1.5.6 | Assembling of Lifting & Other External Part | 10d | 2025-08-23 | 2025-09-02 | 288, 299 | 18d | 0d |  | 1404/6/1 | 1404/6/11 |
| 301 | 4.1.1.5.7 | Welding of Lifting & Other External Part | 8d | 2025-09-03 | 2025-09-11 | 300 | 18d | 0d |  | 1404/6/12 | 1404/6/20 |
| 302 | 4.1.1.5.8 | Assembling of internal parts | 5d | 2025-09-13 | 2025-09-17 | 293, 301 | 18d | 0d |  | 1404/6/22 | 1404/6/26 |
| 303 | 4.1.1.5.9 | Welding of Internal parts | 5d | 2025-09-18 | 2025-09-23 | 302 | 18d | 0d |  | 1404/6/27 | 1404/7/1 |
| 304 | 4.1.1.5.10 | Final dimensional Inspection | 4d | 2025-09-24 | 2025-09-28 | 303 | 18d | 0d |  | 1404/7/2 | 1404/7/6 |

| ID | WBS | Task | Duration | Start | Finish | Predecessors | Total slack | Free slack | شروع | پایان |
| --- | --- | --- | --- | --- | --- | --- | --- | --- | --- | --- |
| 305 | 4.1.1.6 | **Final Activity** | 25d | 2025-09-29 | 2025-10-27 |  | 18d |  | 1404/7/7 | 1404/8/5 |
| 306 | 4.1.1.6.1 | prepare for PWHT | 2d | 2025-09-29 | 2025-09-30 | 304 | 18d | 0d | 1404/7/7 | 1404/7/8 |
| 307 | 4.1.1.6.2 | PWHT | 4d | 2025-10-01 | 2025-10-05 | 306, 24, 20 | 18d | 0d | 1404/7/9 | 1404/7/13 |
| 308 | 4.1.1.6.3 | NDT after PWHT | 4d | 2025-10-06 | 2025-10-09 | 307 | 18d | 0d | 1404/7/14 | 1404/7/17 |
| 309 | 4.1.1.6.4 | Prepare for Hydrotest | 3d | 2025-10-11 | 2025-10-13 | 308 | 18d | 0d | 1404/7/19 | 1404/7/21 |
| 310 | 4.1.1.6.5 | Hydrotest | 5d | 2025-10-14 | 2025-10-19 | 309, 28, 883, 884, 886, 887, 888 | 18d | 0d | 1404/7/22 | 1404/7/27 |
| 311 | 4.1.1.6.6 | Sanblasting & Painting | 5d | 2025-10-22 | 2025-10-27 | 310, 264, 890, 891, 266 | 18d | 0d | 1404/7/30 | 1404/8/5 |
| 312 | 4.1.2 | **C-200 Still Column** | 125d | 2025-05-06 | 2025-09-28 |  | 43d |  | 1404/2/16 | 1404/7/6 |
| 313 | 4.1.2.1 | **Shell** | 7d | 2025-05-06 | 2025-05-13 |  | 115d |  | 1404/2/16 | 1404/2/23 |
| 314 | 4.1.2.1.1 | Marking & Cutting & Beveling | 2d | 2025-05-06 | 2025-05-07 | 71, 72, 218 | 115d | 0d | 1404/2/16 | 1404/2/17 |
| 315 | 4.1.2.1.2 | Pre- Assembling & Per-Welding of Plates | 1d | 2025-05-08 | 2025-05-08 | 314, 894 | 115d | 0d | 1404/2/18 | 1404/2/18 |
| 316 | 4.1.2.1.3 | Rolling | 1d | 2025-05-10 | 2025-05-10 | 315 | 115d | 0d | 1404/2/20 | 1404/2/20 |
| 317 | 4.1.2.1.4 | Assemble & Welding of Plates | 2d | 2025-05-11 | 2025-05-12 | 316 | 115d | 0d | 1404/2/21 | 1404/2/22 |
| 318 | 4.1.2.1.5 | Rerolling | 1d | 2025-05-13 | 2025-05-13 | 317 | 115d | 27d | 1404/2/23 | 1404/2/23 |
| 319 | 4.1.2.2 | **Head** | 34d | 2025-05-06 | 2025-06-14 |  | 88d |  | 1404/2/16 | 1404/3/24 |
| 320 | 4.1.2.2.1 | Marking & Cutting & Beveling head plate | 4d | 2025-05-06 | 2025-05-10 | 71, 72, 218 | 88d | 0d | 1404/2/16 | 1404/2/20 |
| 321 | 4.1.2.2.2 | Forming Head plate (sub contractor) | 30d | 2025-05-11 | 2025-06-14 | 320 | 88d | 0d | 1404/2/21 | 1404/3/24 |
| 322 | 4.1.2.3 | **External Part** | 86d | 2025-05-06 | 2025-08-13 |  | 50d |  | 1404/2/16 | 1404/5/22 |
| 323 | 4.1.2.3.1 | **Nozzles & Manholes** | 86d | 2025-05-06 | 2025-08-13 |  | 43d |  | 1404/2/16 | 1404/5/22 |
| 324 | 4.1.2.3.1.1 | Cutting & Beveling Pipe | 2d | 2025-05-06 | 2025-05-07 | 218 | 121d | 78d | 1404/2/16 | 1404/2/17 |
| 325 | 4.1.2.3.1.2 | Assembling of Pipe To Flange | 2d | 2025-08-07 | 2025-08-09 | 324, 221, 227 | 43d | 0d | 1404/5/16 | 1404/5/18 |
| 326 | 4.1.2.3.1.3 | Welding of Pipe To Flange | 4d | 2025-08-10 | 2025-08-13 | 325 | 43d | 0d | 1404/5/19 | 1404/5/22 |
| 327 | 4.1.2.3.2 | **Lifting & Other External Part** | 7d | 2025-05-06 | 2025-05-13 |  | 129d |  | 1404/2/16 | 1404/2/23 |
| 328 | 4.1.2.3.2.1 | Marking & Cutting & Beveling Lifting & Other External Part | 2d | 2025-05-06 | 2025-05-07 | 218 | 129d | 0d | 1404/2/16 | 1404/2/17 |
| 329 | 4.1.2.3.2.2 | Drilling Lifting & Other External Part | 1d | 2025-05-08 | 2025-05-08 | 328 | 129d | 0d | 1404/2/18 | 1404/2/18 |
| 330 | 4.1.2.3.2.3 | Assembling of external parts together | 2d | 2025-05-10 | 2025-05-11 | 329 | 129d | 0d | 1404/2/20 | 1404/2/21 |
| 331 | 4.1.2.3.2.4 | Welding of external parts together | 2d | 2025-05-12 | 2025-05-13 | 330 | 129d | 86d | 1404/2/22 | 1404/2/23 |

| ID | WBS | Task | Duration | Start | Finish | Predecessors | Total slack | Free slack | شروع | پایان |
| --- | --- | --- | --- | --- | --- | --- | --- | --- | --- | --- |
| 332 | 4.1.2.4 | **Internal Part** | 9d | 2025-05-06 | 2025-05-15 |  | 137d |  | 1404/2/16 | 1404/2/25 |
| 333 | 4.1.2.4.1 | Marking & Cutting & Beveling Internal Part | 2d | 2025-05-06 | 2025-05-07 | 218 | 137d | 0d | 1404/2/16 | 1404/2/17 |
| 334 | 4.1.2.4.2 | Drilling Internal Part | 3d | 2025-05-08 | 2025-05-11 | 333 | 137d | 0d | 1404/2/18 | 1404/2/21 |
| 335 | 4.1.2.4.3 | Assembling of Internal parts together | 2d | 2025-05-12 | 2025-05-13 | 334 | 137d | 0d | 1404/2/22 | 1404/2/23 |
| 336 | 4.1.2.4.4 | Welding of Internal parts together | 2d | 2025-05-14 | 2025-05-15 | 335 | 137d | 94d | 1404/2/24 | 1404/2/25 |
| 337 | 4.1.2.5 | **Final Assembly** | 77d | 2025-06-15 | 2025-09-11 |  | 43d |  | 1404/3/25 | 1404/6/20 |
| 338 | 4.1.2.5.1 | Assembling Shell course & head | 3d | 2025-06-15 | 2025-06-17 | 318, 321, 74, 895 | 88d | 0d | 1404/3/25 | 1404/3/27 |
| 339 | 4.1.2.5.2 | Welding Shell course & head | 2d | 2025-06-18 | 2025-06-19 | 338 | 88d | 0d | 1404/3/28 | 1404/3/29 |
| 340 | 4.1.2.5.3 | Marking & Opening Nozzle | 2d | 2025-06-21 | 2025-06-22 | 339 | 88d | 45d | 1404/3/31 | 1404/4/1 |
| 341 | 4.1.2.5.4 | Assembling nozzel & manhole | 2d | 2025-08-14 | 2025-08-16 | 326, 340 | 43d | 0d | 1404/5/23 | 1404/5/25 |
| 342 | 4.1.2.5.5 | Welding of nozzel & manhole | 5d | 2025-08-17 | 2025-08-21 | 341, 896 | 43d | 0d | 1404/5/26 | 1404/5/30 |
| 343 | 4.1.2.5.6 | Assembling of Lifting & Other External Part | 5d | 2025-08-23 | 2025-08-27 | 331, 342 | 43d | 0d | 1404/6/1 | 1404/6/5 |
| 344 | 4.1.2.5.7 | Welding of Lifting & Other External Part | 5d | 2025-08-28 | 2025-09-02 | 343 | 43d | 0d | 1404/6/6 | 1404/6/11 |
| 345 | 4.1.2.5.8 | Assembling of internal parts | 2d | 2025-09-03 | 2025-09-04 | 336, 344 | 43d | 0d | 1404/6/12 | 1404/6/13 |
| 346 | 4.1.2.5.9 | Welding of Internal parts | 4d | 2025-09-06 | 2025-09-09 | 345 | 43d | 0d | 1404/6/15 | 1404/6/18 |
| 347 | 4.1.2.5.10 | Final dimensional Inspection | 2d | 2025-09-10 | 2025-09-11 | 346, 897 | 43d | 0d | 1404/6/19 | 1404/6/20 |
| 348 | 4.1.2.6 | **Final Activity** | 14d | 2025-09-13 | 2025-09-28 |  | 43d |  | 1404/6/22 | 1404/7/6 |
| 349 | 4.1.2.6.1 | prepare for PWHT | 1d | 2025-09-13 | 2025-09-13 | 347 | 43d | 0d | 1404/6/22 | 1404/6/22 |
| 350 | 4.1.2.6.2 | PWHT | 1d | 2025-09-14 | 2025-09-14 | 349, 24, 20 | 43d | 0d | 1404/6/23 | 1404/6/23 |
| 351 | 4.1.2.6.3 | NDT after PWHT | 2d | 2025-09-15 | 2025-09-16 | 350 | 43d | 0d | 1404/6/24 | 1404/6/25 |
| 352 | 4.1.2.6.4 | Prepare for Hydrotest | 2d | 2025-09-17 | 2025-09-18 | 351 | 43d | 0d | 1404/6/26 | 1404/6/27 |
| 353 | 4.1.2.6.5 | Hydrotest | 2d | 2025-09-20 | 2025-09-21 | 352, 28, 898, 899, 901, 902, 903, 1067 | 43d | 0d | 1404/6/29 | 1404/6/30 |
| 354 | 4.1.2.6.6 | Sanblasting & Painting | 4d | 2025-09-24 | 2025-09-28 | 353, 264, 905, 906, 266 | 43d | 0d | 1404/7/2 | 1404/7/6 |
| 355 | 4.1.3 | **Lean Glycol Filter (F-300)** | 116d | 2025-05-06 | 2025-09-17 |  | 52d |  | 1404/2/16 | 1404/6/26 |
| 356 | 4.1.3.1 | **Shell** | 14d | 2025-05-06 | 2025-05-21 |  | 118d |  | 1404/2/16 | 1404/2/31 |
| 357 | 4.1.3.1.1 | Marking & Cutting & Beveling | 1d | 2025-05-06 | 2025-05-06 | 77, 78, 218 | 118d | 0d | 1404/2/16 | 1404/2/16 |
| 358 | 4.1.3.1.2 | Pre- Assembling & Per-Welding of Plates | 2d | 2025-05-07 | 2025-05-08 | 357, 909 | 118d | 0d | 1404/2/17 | 1404/2/18 |
| 359 | 4.1.3.1.3 | Rolling | 3d | 2025-05-10 | 2025-05-12 | 358 | 118d | 0d | 1404/2/20 | 1404/2/22 |
| 360 | 4.1.3.1.4 | Assemble & Welding of Plates | 4d | 2025-05-13 | 2025-05-17 | 359 | 118d | 0d | 1404/2/23 | 1404/2/27 |
| 361 | 4.1.3.1.5 | Rerolling | 4d | 2025-05-18 | 2025-05-21 | 360 | 118d | 17d | 1404/2/28 | 1404/2/31 |

| ID | WBS | Task | Duration | Start | Finish | Predecessors | Total slack | Free slack | Constraint | شروع | پایان |
| --- | --- | --- | --- | --- | --- | --- | --- | --- | --- | --- | --- |
| 362 | 4.1.3.2 | **Head** | 31d | 2025-05-06 | 2025-06-10 |  | 101d |  |  | 1404/2/16 | 1404/3/20 |
| 363 | 4.1.3.2.1 | Marking & Cutting & Beveling head plate | 1d | 2025-05-06 | 2025-05-06 | 77, 78, 218 | 101d | 0d |  | 1404/2/16 | 1404/2/16 |
| 364 | 4.1.3.2.2 | Forming Head plate (sub contractor) | 30d | 2025-05-07 | 2025-06-10 | 363 | 101d | 0d |  | 1404/2/17 | 1404/3/20 |
| 365 | 4.1.3.3 | **External Part** | 83d | 2025-05-06 | 2025-08-10 |  | 60d |  |  | 1404/2/16 | 1404/5/19 |
| 366 | 4.1.3.3.1 | **Nozzles & Manholes** | 83d | 2025-05-06 | 2025-08-10 |  | 54d |  |  | 1404/2/16 | 1404/5/19 |
| 367 | 4.1.3.3.1.1 | Cutting & Beveling Pipe | 1d | 2025-05-06 | 2025-05-06 | 78, 215 | 133d | 79d | start no earlier than 2024-10-09 | 1404/2/16 | 1404/2/16 |
| 368 | 4.1.3.3.1.2 | Assembling of Pipe To Flange | 1d | 2025-08-07 | 2025-08-07 | 367, 221, 227 | 54d | 0d |  | 1404/5/16 | 1404/5/16 |
| 369 | 4.1.3.3.1.3 | Welding of Pipe To Flange | 2d | 2025-08-09 | 2025-08-10 | 368 | 54d | 0d |  | 1404/5/18 | 1404/5/19 |
| 370 | 4.1.3.3.2 | **Lifting & Other External Part** | 11d | 2025-05-06 | 2025-05-18 |  | 132d |  |  | 1404/2/16 | 1404/2/28 |
| 371 | 4.1.3.3.2.1 | Marking & Cutting & Beveling Lifting & Other External Part | 2d | 2025-05-06 | 2025-05-07 | 78, 218 | 132d | 0d |  | 1404/2/16 | 1404/2/17 |
| 372 | 4.1.3.3.2.2 | Drilling Lifting & Other External Part | 3d | 2025-05-08 | 2025-05-11 | 371 | 132d | 0d |  | 1404/2/18 | 1404/2/21 |
| 373 | 4.1.3.3.2.3 | Assembling of external parts together | 2d | 2025-05-12 | 2025-05-13 | 372 | 132d | 0d |  | 1404/2/22 | 1404/2/23 |
| 374 | 4.1.3.3.2.4 | Welding of external parts together | 4d | 2025-05-14 | 2025-05-18 | 373 | 132d | 78d |  | 1404/2/24 | 1404/2/28 |
| 375 | 4.1.3.4 | **Internal Part** | 6d | 2025-05-06 | 2025-05-12 |  | 142d |  |  | 1404/2/16 | 1404/2/22 |
| 376 | 4.1.3.4.1 | Marking & Cutting & Beveling Internal Part | 1d | 2025-05-06 | 2025-05-06 | 78, 218 | 142d | 0d |  | 1404/2/16 | 1404/2/16 |
| 377 | 4.1.3.4.2 | Drilling Internal Part | 2d | 2025-05-07 | 2025-05-08 | 376 | 142d | 0d |  | 1404/2/17 | 1404/2/18 |
| 378 | 4.1.3.4.3 | Assembling of Internal parts together | 1d | 2025-05-10 | 2025-05-10 | 377 | 142d | 0d |  | 1404/2/20 | 1404/2/20 |
| 379 | 4.1.3.4.4 | Welding of Internal parts together | 2d | 2025-05-11 | 2025-05-12 | 378 | 142d | 88d |  | 1404/2/21 | 1404/2/22 |
| 380 | 4.1.3.5 | **Final Assembly** | 70d | 2025-06-11 | 2025-08-31 |  | 54d |  |  | 1404/3/21 | 1404/6/9 |
| 381 | 4.1.3.5.1 | Assembling Shell course & head | 2d | 2025-06-11 | 2025-06-12 | 361, 364, 910 | 101d | 0d |  | 1404/3/21 | 1404/3/22 |
| 382 | 4.1.3.5.2 | Welding Shell course & head | 2d | 2025-06-14 | 2025-06-15 | 381 | 101d | 0d |  | 1404/3/24 | 1404/3/25 |
| 383 | 4.1.3.5.3 | Marking & Opening Nozzle | 1d | 2025-06-16 | 2025-06-16 | 382 | 101d | 47d |  | 1404/3/26 | 1404/3/26 |
| 384 | 4.1.3.5.4 | Assembling nozzel & manhole | 2d | 2025-08-11 | 2025-08-12 | 369, 383 | 54d | 0d |  | 1404/5/20 | 1404/5/21 |
| 385 | 4.1.3.5.5 | Welding of nozzel & manhole | 4d | 2025-08-13 | 2025-08-17 | 384 | 54d | 0d |  | 1404/5/22 | 1404/5/26 |
| 386 | 4.1.3.5.6 | Assembling of Lifting & Other External Part | 3d | 2025-08-18 | 2025-08-20 | 374, 385 | 54d | 0d |  | 1404/5/27 | 1404/5/29 |
| 387 | 4.1.3.5.7 | Welding of Lifting & Other External Part | 2d | 2025-08-21 | 2025-08-23 | 386 | 54d | 0d |  | 1404/5/30 | 1404/6/1 |
| 388 | 4.1.3.5.8 | Assembling of internal parts | 2d | 2025-08-24 | 2025-08-25 | 379, 387 | 54d | 0d |  | 1404/6/2 | 1404/6/3 |
| 389 | 4.1.3.5.9 | Welding of Internal parts | 3d | 2025-08-26 | 2025-08-28 | 388 | 54d | 0d |  | 1404/6/4 | 1404/6/6 |
| 390 | 4.1.3.5.10 | Final dimensional Inspection | 2d | 2025-08-30 | 2025-08-31 | 389, 911, 912 | 54d | 0d |  | 1404/6/8 | 1404/6/9 |

| ID | WBS | Task | Duration | Start | Finish | Predecessors | Total slack | Free slack | Constraint | شروع | پایان |
| --- | --- | --- | --- | --- | --- | --- | --- | --- | --- | --- | --- |
| 391 | 4.1.3.6 | **Final Activity** | 15d | 2025-09-01 | 2025-09-17 |  | 52d |  |  | 1404/6/10 | 1404/6/26 |
| 392 | 4.1.3.6.1 | prepare for PWHT | 1d | 2025-09-01 | 2025-09-01 | 390 | 54d | 0d |  | 1404/6/10 | 1404/6/10 |
| 393 | 4.1.3.6.2 | PWHT | 1d | 2025-09-02 | 2025-09-02 | 392, 24, 20 | 54d | 0d |  | 1404/6/11 | 1404/6/11 |
| 394 | 4.1.3.6.3 | NDT after PWHT | 2d | 2025-09-03 | 2025-09-04 | 393 | 54d | 0d |  | 1404/6/12 | 1404/6/13 |
| 395 | 4.1.3.6.4 | Prepare for Hydrotest | 1d | 2025-09-06 | 2025-09-06 | 394 | 54d | 0d |  | 1404/6/15 | 1404/6/15 |
| 396 | 4.1.3.6.5 | Hydrotest | 2d | 2025-09-07 | 2025-09-08 | 395, 28, 913, 914, 916, 917, 918 | 54d | 0d |  | 1404/6/16 | 1404/6/17 |
| 397 | 4.1.3.6.6 | Sanblasting & Painting | 4d | 2025-09-14 | 2025-09-17 | 396, 264, 920, 921, 266 | 52d | 0d |  | 1404/6/23 | 1404/6/26 |
| 398 | 4.1.4 | **V-120 Glycol Flash Drum** | 130d | 2025-05-06 | 2025-10-04 |  | 38d |  |  | 1404/2/16 | 1404/7/12 |
| 399 | 4.1.4.1 | **Shell** | 13d | 2025-05-06 | 2025-05-20 |  | 103d |  |  | 1404/2/16 | 1404/2/30 |
| 400 | 4.1.4.1.1 | Marking & Cutting & Beveling | 2d | 2025-05-06 | 2025-05-07 | 83, 84, 218 | 103d | 0d |  | 1404/2/16 | 1404/2/17 |
| 401 | 4.1.4.1.2 | Pre- Assembling & Per-Welding of Plates | 2d | 2025-05-08 | 2025-05-10 | 400, 924 | 103d | 0d |  | 1404/2/18 | 1404/2/20 |
| 402 | 4.1.4.1.3 | Rolling | 2d | 2025-05-11 | 2025-05-12 | 401 | 103d | 0d |  | 1404/2/21 | 1404/2/22 |
| 403 | 4.1.4.1.4 | Assemble & Welding of Plates | 5d | 2025-05-13 | 2025-05-18 | 402 | 103d | 0d |  | 1404/2/23 | 1404/2/28 |
| 404 | 4.1.4.1.5 | Rerolling | 2d | 2025-05-19 | 2025-05-20 | 403 | 103d | 20d |  | 1404/2/29 | 1404/2/30 |
| 405 | 4.1.4.2 | **Head** | 33d | 2025-05-06 | 2025-06-12 |  | 83d |  |  | 1404/2/16 | 1404/3/22 |
| 406 | 4.1.4.2.1 | Marking & Cutting & Beveling head plate | 3d | 2025-05-06 | 2025-05-08 | 83, 84, 218 | 83d | 0d |  | 1404/2/16 | 1404/2/18 |
| 407 | 4.1.4.2.2 | Forming Head plate (sub contractor) | 30d | 2025-05-10 | 2025-06-12 | 406 | 83d | 0d |  | 1404/2/20 | 1404/3/22 |
| 408 | 4.1.4.3 | **External Part** | 89d | 2025-05-06 | 2025-08-17 |  | 44d |  |  | 1404/2/16 | 1404/5/26 |
| 409 | 4.1.4.3.1 | **Nozzles & Manholes** | 89d | 2025-05-06 | 2025-08-17 |  | 38d |  |  | 1404/2/16 | 1404/5/26 |
| 410 | 4.1.4.3.1.1 | Cutting & Beveling Pipe | 2d | 2025-05-06 | 2025-05-07 | 215 | 116d | 78d | start no earlier than 2024-10-09 | 1404/2/16 | 1404/2/17 |
| 411 | 4.1.4.3.1.2 | Assembling of Pipe To Flange | 4d | 2025-08-07 | 2025-08-11 | 410, 221, 227 | 38d | 0d |  | 1404/5/16 | 1404/5/20 |
| 412 | 4.1.4.3.1.3 | Welding of Pipe To Flange | 5d | 2025-08-12 | 2025-08-17 | 411 | 38d | 0d |  | 1404/5/21 | 1404/5/26 |
| 413 | 4.1.4.3.2 | **Lifting & Other External Part** | 9d | 2025-05-06 | 2025-05-15 |  | 124d |  |  | 1404/2/16 | 1404/2/25 |
| 414 | 4.1.4.3.2.1 | Marking & Cutting & Beveling Lifting & Other External Part | 1d | 2025-05-06 | 2025-05-06 | 218 | 124d | 0d |  | 1404/2/16 | 1404/2/16 |
| 415 | 4.1.4.3.2.2 | Drilling Lifting & Other External Part | 2d | 2025-05-07 | 2025-05-08 | 414 | 124d | 0d |  | 1404/2/17 | 1404/2/18 |
| 416 | 4.1.4.3.2.3 | Assembling of external parts together | 2d | 2025-05-10 | 2025-05-11 | 415 | 124d | 0d |  | 1404/2/20 | 1404/2/21 |
| 417 | 4.1.4.3.2.4 | Welding of external parts together | 4d | 2025-05-12 | 2025-05-15 | 416 | 124d | 86d |  | 1404/2/22 | 1404/2/25 |

| ID | WBS | Task | Duration | Start | Finish | Predecessors | Total slack | Free slack | شروع | پایان |
| --- | --- | --- | --- | --- | --- | --- | --- | --- | --- | --- |
| 418 | 4.1.4.4 | **Internal Part** | 6d | 2025-05-06 | 2025-05-12 |  | 138d |  | 1404/2/16 | 1404/2/22 |
| 419 | 4.1.4.4.1 | Marking & Cutting & Beveling Internal Part | 1d | 2025-05-06 | 2025-05-06 | 218 | 138d | 0d | 1404/2/16 | 1404/2/16 |
| 420 | 4.1.4.4.2 | Drilling Internal Part | 2d | 2025-05-07 | 2025-05-08 | 419 | 138d | 0d | 1404/2/17 | 1404/2/18 |
| 421 | 4.1.4.4.3 | Assembling of Internal parts together | 2d | 2025-05-10 | 2025-05-11 | 420 | 138d | 0d | 1404/2/20 | 1404/2/21 |
| 422 | 4.1.4.4.4 | Welding of Internal parts together | 1d | 2025-05-12 | 2025-05-12 | 421 | 138d | 100d | 1404/2/22 | 1404/2/22 |
| 423 | 4.1.4.5 | **Final Assembly** | 83d | 2025-06-14 | 2025-09-17 |  | 38d |  | 1404/3/24 | 1404/6/26 |
| 424 | 4.1.4.5.1 | Assembling Shell course & head | 4d | 2025-06-14 | 2025-06-17 | 404, 407, 925 | 83d | 0d | 1404/3/24 | 1404/3/27 |
| 425 | 4.1.4.5.2 | Welding Shell course & head | 5d | 2025-06-18 | 2025-06-23 | 424 | 83d | 0d | 1404/3/28 | 1404/4/2 |
| 426 | 4.1.4.5.3 | Marking & Opening Nozzle | 2d | 2025-06-24 | 2025-06-25 | 425 | 83d | 45d | 1404/4/3 | 1404/4/4 |
| 427 | 4.1.4.5.4 | Assembling nozzel & manhole | 2d | 2025-08-18 | 2025-08-19 | 412, 426 | 38d | 0d | 1404/5/27 | 1404/5/28 |
| 428 | 4.1.4.5.5 | Welding of nozzel & manhole | 4d | 2025-08-20 | 2025-08-24 | 427 | 38d | 0d | 1404/5/29 | 1404/6/2 |
| 429 | 4.1.4.5.6 | Assembling of Lifting & Other External Part | 5d | 2025-08-25 | 2025-08-30 | 417, 428 | 38d | 0d | 1404/6/3 | 1404/6/8 |
| 430 | 4.1.4.5.7 | Welding of Lifting & Other External Part | 6d | 2025-08-31 | 2025-09-06 | 429 | 38d | 0d | 1404/6/9 | 1404/6/15 |
| 431 | 4.1.4.5.8 | Assembling of internal parts | 3d | 2025-09-07 | 2025-09-09 | 422, 430 | 38d | 0d | 1404/6/16 | 1404/6/18 |
| 432 | 4.1.4.5.9 | Welding of Internal parts | 5d | 2025-09-10 | 2025-09-15 | 431 | 38d | 0d | 1404/6/19 | 1404/6/24 |
| 433 | 4.1.4.5.10 | Final dimensional Inspection | 2d | 2025-09-16 | 2025-09-17 | 432, 926, 927 | 38d | 0d | 1404/6/25 | 1404/6/26 |
| 434 | 4.1.4.6 | **Final Activity** | 14d | 2025-09-18 | 2025-10-04 |  | 38d |  | 1404/6/27 | 1404/7/12 |
| 435 | 4.1.4.6.1 | prepare for PWHT | 2d | 2025-09-18 | 2025-09-20 | 433 | 38d | 0d | 1404/6/27 | 1404/6/29 |
| 436 | 4.1.4.6.2 | PWHT | 1d | 2025-09-21 | 2025-09-21 | 435, 24, 20 | 38d | 0d | 1404/6/30 | 1404/6/30 |
| 437 | 4.1.4.6.3 | NDT after PWHT | 2d | 2025-09-22 | 2025-09-23 | 436 | 38d | 0d | 1404/6/31 | 1404/7/1 |
| 438 | 4.1.4.6.4 | Prepare for Hydrotest | 1d | 2025-09-24 | 2025-09-24 | 437 | 38d | 0d | 1404/7/2 | 1404/7/2 |
| 439 | 4.1.4.6.5 | Hydrotest | 2d | 2025-09-25 | 2025-09-27 | 438, 28, 928, 929, 931, 932, 933 | 38d | 0d | 1404/7/3 | 1404/7/5 |
| 440 | 4.1.4.6.6 | Sanblasting & Painting | 4d | 2025-09-30 | 2025-10-04 | 439, 264, 935, 936, 266 | 38d | 0d | 1404/7/8 | 1404/7/12 |
| 441 | 4.1.5 | **F-100A Particle Glycol Filter** | 124d | 2025-05-06 | 2025-09-27 |  | 44d |  | 1404/2/16 | 1404/7/5 |
| 442 | 4.1.5.1 | **Shell** | 6d | 2025-05-10 | 2025-05-15 |  | 112d |  | 1404/2/20 | 1404/2/25 |
| 443 | 4.1.5.1.1 | Marking & Cutting & Beveling | 1d | 2025-05-10 | 2025-05-10 | 89, 90, 218FS+3d | 112d | 0d | 1404/2/20 | 1404/2/20 |
| 444 | 4.1.5.1.2 | Pre- Assembling & Per-Welding of Plates | 1d | 2025-05-11 | 2025-05-11 | 443, 939 | 112d | 0d | 1404/2/21 | 1404/2/21 |
| 445 | 4.1.5.1.3 | Rolling | 1d | 2025-05-12 | 2025-05-12 | 444 | 112d | 0d | 1404/2/22 | 1404/2/22 |
| 446 | 4.1.5.1.4 | Assemble & Welding of Plates | 2d | 2025-05-13 | 2025-05-14 | 445 | 112d | 0d | 1404/2/23 | 1404/2/24 |
| 447 | 4.1.5.1.5 | Rerolling | 1d | 2025-05-15 | 2025-05-15 | 446 | 112d | 25d | 1404/2/25 | 1404/2/25 |

| ID | WBS | Task | Duration | Start | Finish | Predecessors | Total slack | Free slack | Constraint | شروع | پایان |
| --- | --- | --- | --- | --- | --- | --- | --- | --- | --- | --- | --- |
| 448 | 4.1.5.2 | **Head** | 31d | 2025-05-10 | 2025-06-14 |  | 87d |  |  | 1404/2/20 | 1404/3/24 |
| 449 | 4.1.5.2.1 | Marking & Cutting & Beveling head plate | 1d | 2025-05-10 | 2025-05-10 | 89, 218FS+3d | 87d | 0d |  | 1404/2/20 | 1404/2/20 |
| 450 | 4.1.5.2.2 | Forming Head plate (sub contractor) | 30d | 2025-05-11 | 2025-06-14 | 449 | 87d | 0d |  | 1404/2/21 | 1404/3/24 |
| 451 | 4.1.5.3 | **External Part** | 85d | 2025-05-06 | 2025-08-12 |  | 50d |  |  | 1404/2/16 | 1404/5/21 |
| 452 | 4.1.5.3.1 | **Nozzles & Manholes** | 85d | 2025-05-06 | 2025-08-12 |  | 44d |  |  | 1404/2/16 | 1404/5/21 |
| 453 | 4.1.5.3.1.1 | Cutting & Beveling Pipe | 1d | 2025-05-06 | 2025-05-06 | 90, 215 | 123d | 79d | start no earlier than 2024-10-09 | 1404/2/16 | 1404/2/16 |
| 454 | 4.1.5.3.1.2 | Assembling of Pipe To Flange | 2d | 2025-08-07 | 2025-08-09 | 453, 221, 227 | 44d | 0d |  | 1404/5/16 | 1404/5/18 |
| 455 | 4.1.5.3.1.3 | Welding of Pipe To Flange | 3d | 2025-08-10 | 2025-08-12 | 454 | 44d | 0d |  | 1404/5/19 | 1404/5/21 |
| 456 | 4.1.5.3.2 | **Lifting & Other External Part** | 10d | 2025-05-17 | 2025-05-27 |  | 116d |  |  | 1404/2/27 | 1404/3/6 |
| 457 | 4.1.5.3.2.1 | Marking & Cutting & Beveling Lifting & Other External Part | 2d | 2025-05-17 | 2025-05-18 | 90, 218FS+9d | 116d | 0d |  | 1404/2/27 | 1404/2/28 |
| 458 | 4.1.5.3.2.2 | Drilling Lifting & Other External Part | 3d | 2025-05-19 | 2025-05-21 | 457 | 116d | 0d |  | 1404/2/29 | 1404/2/31 |
| 459 | 4.1.5.3.2.3 | Assembling of external parts together | 2d | 2025-05-22 | 2025-05-24 | 458 | 116d | 0d |  | 1404/3/1 | 1404/3/3 |
| 460 | 4.1.5.3.2.4 | Welding of external parts together | 3d | 2025-05-25 | 2025-05-27 | 459 | 116d | 72d |  | 1404/3/4 | 1404/3/6 |
| 461 | 4.1.5.4 | **Internal Part** | 6d | 2025-05-24 | 2025-05-29 |  | 120d |  |  | 1404/3/3 | 1404/3/8 |
| 462 | 4.1.5.4.1 | Marking & Cutting & Beveling Internal Part | 1d | 2025-05-24 | 2025-05-24 | 90, 218FS+15d | 120d | 0d |  | 1404/3/3 | 1404/3/3 |
| 463 | 4.1.5.4.2 | Drilling Internal Part | 2d | 2025-05-25 | 2025-05-26 | 462 | 120d | 0d |  | 1404/3/4 | 1404/3/5 |
| 464 | 4.1.5.4.3 | Assembling of Internal parts together | 1d | 2025-05-27 | 2025-05-27 | 463 | 120d | 0d |  | 1404/3/6 | 1404/3/6 |
| 465 | 4.1.5.4.4 | Welding of Internal parts together | 2d | 2025-05-28 | 2025-05-29 | 464 | 120d | 76d |  | 1404/3/7 | 1404/3/8 |
| 466 | 4.1.5.5 | **Final Assembly** | 72d | 2025-06-15 | 2025-09-06 |  | 44d |  |  | 1404/3/25 | 1404/6/15 |
| 467 | 4.1.5.5.1 | Assembling Shell course & head | 2d | 2025-06-15 | 2025-06-16 | 447, 450, 940 | 87d | 0d |  | 1404/3/25 | 1404/3/26 |
| 468 | 4.1.5.5.2 | Welding Shell course & head | 4d | 2025-06-17 | 2025-06-21 | 467 | 87d | 0d |  | 1404/3/27 | 1404/3/31 |
| 469 | 4.1.5.5.3 | Marking & Opening Nozzle | 2d | 2025-06-22 | 2025-06-23 | 468 | 87d | 43d |  | 1404/4/1 | 1404/4/2 |
| 470 | 4.1.5.5.4 | Assembling nozzel & manhole | 4d | 2025-08-13 | 2025-08-17 | 455, 469 | 44d | 0d |  | 1404/5/22 | 1404/5/26 |
| 471 | 4.1.5.5.5 | Welding of nozzel & manhole | 2d | 2025-08-18 | 2025-08-19 | 470 | 44d | 0d |  | 1404/5/27 | 1404/5/28 |
| 472 | 4.1.5.5.6 | Assembling of Lifting & Other External Part | 2d | 2025-08-20 | 2025-08-21 | 460, 471 | 44d | 0d |  | 1404/5/29 | 1404/5/30 |
| 473 | 4.1.5.5.7 | Welding of Lifting & Other External Part | 4d | 2025-08-23 | 2025-08-26 | 472 | 44d | 0d |  | 1404/6/1 | 1404/6/4 |
| 474 | 4.1.5.5.8 | Assembling of internal parts | 2d | 2025-08-27 | 2025-08-28 | 465, 473 | 44d | 0d |  | 1404/6/5 | 1404/6/6 |
| 475 | 4.1.5.5.9 | Welding of Internal parts | 3d | 2025-08-30 | 2025-09-01 | 474 | 44d | 0d |  | 1404/6/8 | 1404/6/10 |
| 476 | 4.1.5.5.10 | Final dimensional Inspection | 4d | 2025-09-02 | 2025-09-06 | 475, 941, 942 | 44d | 0d |  | 1404/6/11 | 1404/6/15 |

| ID | WBS | Task | Duration | Start | Finish | Predecessors | Total slack | Free slack | Constraint | شروع | پایان |
| --- | --- | --- | --- | --- | --- | --- | --- | --- | --- | --- | --- |
| 477 | 4.1.5.6 | **Final Activity** | 18d | 2025-09-07 | 2025-09-27 |  | 44d |  |  | 1404/6/16 | 1404/7/5 |
| 478 | 4.1.5.6.1 | prepare for PWHT | 1d | 2025-09-07 | 2025-09-07 | 476 | 44d | 0d |  | 1404/6/16 | 1404/6/16 |
| 479 | 4.1.5.6.2 | PWHT | 3d | 2025-09-08 | 2025-09-10 | 478, 24, 20 | 44d | 0d |  | 1404/6/17 | 1404/6/19 |
| 480 | 4.1.5.6.3 | NDT after PWHT | 2d | 2025-09-11 | 2025-09-13 | 479 | 44d | 0d |  | 1404/6/20 | 1404/6/22 |
| 481 | 4.1.5.6.4 | Prepare for Hydrotest | 1d | 2025-09-14 | 2025-09-14 | 480 | 44d | 0d |  | 1404/6/23 | 1404/6/23 |
| 482 | 4.1.5.6.5 | Hydrotest | 4d | 2025-09-15 | 2025-09-18 | 481, 28, 943, 944, 946, 947, 948 | 44d | 0d |  | 1404/6/24 | 1404/6/27 |
| 483 | 4.1.5.6.6 | Sanblasting & Painting | 5d | 2025-09-22 | 2025-09-27 | 482, 264, 950, 951, 266 | 44d | 0d |  | 1404/6/31 | 1404/7/5 |
| 484 | 4.1.6 | **F-100B Particle Glycol Filter** | 114d | 2025-05-06 | 2025-09-15 |  | 54d |  |  | 1404/2/16 | 1404/6/24 |
| 485 | 4.1.6.1 | **Shell** | 6d | 2025-05-06 | 2025-05-12 |  | 139d |  |  | 1404/2/16 | 1404/2/22 |
| 486 | 4.1.6.1.1 | Marking & Cutting & Beveling | 1d | 2025-05-06 | 2025-05-06 | 89, 90, 218 | 139d | 0d |  | 1404/2/16 | 1404/2/16 |
| 487 | 4.1.6.1.2 | Pre- Assembling & Per-Welding of Plates | 1d | 2025-05-07 | 2025-05-07 | 486, 954 | 139d | 0d |  | 1404/2/17 | 1404/2/17 |
| 488 | 4.1.6.1.3 | Rolling | 1d | 2025-05-08 | 2025-05-08 | 487 | 139d | 0d |  | 1404/2/18 | 1404/2/18 |
| 489 | 4.1.6.1.4 | Assemble & Welding of Plates | 2d | 2025-05-10 | 2025-05-11 | 488 | 139d | 0d |  | 1404/2/20 | 1404/2/21 |
| 490 | 4.1.6.1.5 | Rerolling | 1d | 2025-05-12 | 2025-05-12 | 489 | 139d | 25d |  | 1404/2/22 | 1404/2/22 |
| 491 | 4.1.6.2 | **Head** | 31d | 2025-05-06 | 2025-06-10 |  | 114d |  |  | 1404/2/16 | 1404/3/20 |
| 492 | 4.1.6.2.1 | Marking & Cutting & Beveling head plate | 1d | 2025-05-06 | 2025-05-06 | 90, 218 | 114d | 0d |  | 1404/2/16 | 1404/2/16 |
| 493 | 4.1.6.2.2 | Forming Head plate (sub contractor) | 30d | 2025-05-07 | 2025-06-10 | 492 | 114d | 0d |  | 1404/2/17 | 1404/3/20 |
| 494 | 4.1.6.3 | **External Part** | 85d | 2025-05-06 | 2025-08-12 |  | 66d |  |  | 1404/2/16 | 1404/5/21 |
| 495 | 4.1.6.3.1 | **Nozzles & Manholes** | 85d | 2025-05-06 | 2025-08-12 |  | 63d |  |  | 1404/2/16 | 1404/5/21 |
| 496 | 4.1.6.3.1.1 | Cutting & Beveling Pipe | 1d | 2025-05-06 | 2025-05-06 | 90, 215 | 142d | 79d | start no earlier than 2024-10-09 | 1404/2/16 | 1404/2/16 |
| 497 | 4.1.6.3.1.2 | Assembling of Pipe To Flange | 2d | 2025-08-07 | 2025-08-09 | 496, 221, 227 | 63d | 0d |  | 1404/5/16 | 1404/5/18 |
| 498 | 4.1.6.3.1.3 | Welding of Pipe To Flange | 3d | 2025-08-10 | 2025-08-12 | 497 | 63d | 0d |  | 1404/5/19 | 1404/5/21 |
| 499 | 4.1.6.3.2 | **Lifting & Other External Part** | 10d | 2025-05-06 | 2025-05-17 |  | 141d |  |  | 1404/2/16 | 1404/2/27 |
| 500 | 4.1.6.3.2.1 | Marking & Cutting & Beveling Lifting & Other External Part | 2d | 2025-05-06 | 2025-05-07 | 90, 218 | 141d | 0d |  | 1404/2/16 | 1404/2/17 |
| 501 | 4.1.6.3.2.2 | Drilling Lifting & Other External Part | 3d | 2025-05-08 | 2025-05-11 | 500 | 141d | 0d |  | 1404/2/18 | 1404/2/21 |
| 502 | 4.1.6.3.2.3 | Assembling of external parts together | 2d | 2025-05-12 | 2025-05-13 | 501 | 141d | 0d |  | 1404/2/22 | 1404/2/23 |
| 503 | 4.1.6.3.2.4 | Welding of external parts together | 3d | 2025-05-14 | 2025-05-17 | 502 | 141d | 78d |  | 1404/2/24 | 1404/2/27 |

| ID | WBS | Task | Duration | Start | Finish | Predecessors | Total slack | Free slack | شروع | پایان |
| --- | --- | --- | --- | --- | --- | --- | --- | --- | --- | --- |
| 504 | 4.1.6.4 | **Internal Part** | 6d | 2025-05-06 | 2025-05-12 |  | 148d |  | 1404/2/16 | 1404/2/22 |
| 505 | 4.1.6.4.1 | Marking & Cutting & Beveling Internal Part | 1d | 2025-05-06 | 2025-05-06 | 90, 218 | 148d | 0d | 1404/2/16 | 1404/2/16 |
| 506 | 4.1.6.4.2 | Drilling Internal Part | 2d | 2025-05-07 | 2025-05-08 | 505 | 148d | 0d | 1404/2/17 | 1404/2/18 |
| 507 | 4.1.6.4.3 | Assembling of Internal parts together | 1d | 2025-05-10 | 2025-05-10 | 506 | 148d | 0d | 1404/2/20 | 1404/2/20 |
| 508 | 4.1.6.4.4 | Welding of Internal parts together | 2d | 2025-05-11 | 2025-05-12 | 507 | 148d | 85d | 1404/2/21 | 1404/2/22 |
| 509 | 4.1.6.5 | **Final Assembly** | 64d | 2025-06-11 | 2025-08-24 |  | 63d |  | 1404/3/21 | 1404/6/2 |
| 510 | 4.1.6.5.1 | Assembling Shell course & head | 1d | 2025-06-11 | 2025-06-11 | 490, 493, 955 | 114d | 0d | 1404/3/21 | 1404/3/21 |
| 511 | 4.1.6.5.2 | Welding Shell course & head | 1d | 2025-06-12 | 2025-06-12 | 510 | 114d | 0d | 1404/3/22 | 1404/3/22 |
| 512 | 4.1.6.5.3 | Marking & Opening Nozzle | 1d | 2025-06-14 | 2025-06-14 | 511 | 114d | 51d | 1404/3/24 | 1404/3/24 |
| 513 | 4.1.6.5.4 | Assembling nozzel & manhole | 1d | 2025-08-13 | 2025-08-13 | 498, 512 | 63d | 0d | 1404/5/22 | 1404/5/22 |
| 514 | 4.1.6.5.5 | Welding of nozzel & manhole | 2d | 2025-08-14 | 2025-08-16 | 513 | 63d | 0d | 1404/5/23 | 1404/5/25 |
| 515 | 4.1.6.5.6 | Assembling of Lifting & Other External Part | 1d | 2025-08-17 | 2025-08-17 | 503, 514 | 63d | 0d | 1404/5/26 | 1404/5/26 |
| 516 | 4.1.6.5.7 | Welding of Lifting & Other External Part | 2d | 2025-08-18 | 2025-08-19 | 515 | 63d | 0d | 1404/5/27 | 1404/5/28 |
| 517 | 4.1.6.5.8 | Assembling of internal parts | 1d | 2025-08-20 | 2025-08-20 | 508, 516 | 63d | 0d | 1404/5/29 | 1404/5/29 |
| 518 | 4.1.6.5.9 | Welding of Internal parts | 1d | 2025-08-21 | 2025-08-21 | 517 | 63d | 0d | 1404/5/30 | 1404/5/30 |
| 519 | 4.1.6.5.10 | Final dimensional Inspection | 2d | 2025-08-23 | 2025-08-24 | 518, 956, 957 | 63d | 0d | 1404/6/1 | 1404/6/2 |
| 520 | 4.1.6.6 | **Final Activity** | 19d | 2025-08-25 | 2025-09-15 |  | 54d |  | 1404/6/3 | 1404/6/24 |
| 521 | 4.1.6.6.1 | prepare for PWHT | 1d | 2025-08-25 | 2025-08-25 | 519 | 63d | 0d | 1404/6/3 | 1404/6/3 |
| 522 | 4.1.6.6.2 | PWHT | 1d | 2025-08-26 | 2025-08-26 | 521, 24, 20 | 63d | 0d | 1404/6/4 | 1404/6/4 |
| 523 | 4.1.6.6.3 | NDT after PWHT | 1d | 2025-08-27 | 2025-08-27 | 522 | 63d | 0d | 1404/6/5 | 1404/6/5 |
| 524 | 4.1.6.6.4 | Prepare for Hydrotest | 1d | 2025-08-28 | 2025-08-28 | 523 | 63d | 0d | 1404/6/6 | 1404/6/6 |
| 525 | 4.1.6.6.5 | Hydrotest | 2d | 2025-08-30 | 2025-08-31 | 524, 28, 958, 959, 961, 962, 963 | 63d | 0d | 1404/6/8 | 1404/6/9 |
| 526 | 4.1.6.6.6 | Sanblasting & Painting | 2d | 2025-09-14 | 2025-09-15 | 525, 264, 965, 966, 266 | 54d | 0d | 1404/6/23 | 1404/6/24 |
| 527 | 4.1.7 | **F-200 Carbon Glycol Filter** | 116d | 2025-05-06 | 2025-09-17 |  | 52d |  | 1404/2/16 | 1404/6/26 |
| 528 | 4.1.7.1 | **Shell** | 6d | 2025-05-10 | 2025-05-15 |  | 131d |  | 1404/2/20 | 1404/2/25 |
| 529 | 4.1.7.1.1 | Marking & Cutting & Beveling | 1d | 2025-05-10 | 2025-05-10 | 95, 96, 218FS+3d | 131d | 0d | 1404/2/20 | 1404/2/20 |
| 530 | 4.1.7.1.2 | Pre- Assembling & Per-Welding of Plates | 1d | 2025-05-11 | 2025-05-11 | 529, 969 | 131d | 0d | 1404/2/21 | 1404/2/21 |
| 531 | 4.1.7.1.3 | Rolling | 2d | 2025-05-12 | 2025-05-13 | 530 | 131d | 0d | 1404/2/22 | 1404/2/23 |
| 532 | 4.1.7.1.4 | Assemble & Welding of Plates | 1d | 2025-05-14 | 2025-05-14 | 531 | 131d | 0d | 1404/2/24 | 1404/2/24 |
| 533 | 4.1.7.1.5 | Rerolling | 1d | 2025-05-15 | 2025-05-15 | 532 | 131d | 25d | 1404/2/25 | 1404/2/25 |

| ID | WBS | Task | Duration | Start | Finish | Predecessors | Total slack | Free slack | Constraint | شروع | پایان |
| --- | --- | --- | --- | --- | --- | --- | --- | --- | --- | --- | --- |
| 534 | 4.1.7.2 | **Head** | 31d | 2025-05-10 | 2025-06-14 |  | 106d |  |  | 1404/2/20 | 1404/3/24 |
| 535 | 4.1.7.2.1 | Marking & Cutting & Beveling head plate | 1d | 2025-05-10 | 2025-05-10 | 96, 95, 218FS+3d | 106d | 0d |  | 1404/2/20 | 1404/2/20 |
| 536 | 4.1.7.2.2 | Forming Head plate (sub contractor) | 30d | 2025-05-11 | 2025-06-14 | 535 | 106d | 0d |  | 1404/2/21 | 1404/3/24 |
| 537 | 4.1.7.3 | **External Part** | 88d | 2025-05-06 | 2025-08-16 |  | 58d |  |  | 1404/2/16 | 1404/5/25 |
| 538 | 4.1.7.3.1 | **Nozzles & Manholes** | 88d | 2025-05-06 | 2025-08-16 |  | 55d |  |  | 1404/2/16 | 1404/5/25 |
| 539 | 4.1.7.3.1.1 | Cutting & Beveling Pipe | 2d | 2025-05-06 | 2025-05-07 | 96, 215 | 133d | 78d | start no earlier than 2024-10-09 | 1404/2/16 | 1404/2/17 |
| 540 | 4.1.7.3.1.2 | Assembling of Pipe To Flange | 3d | 2025-08-07 | 2025-08-10 | 539, 221, 227 | 55d | 0d |  | 1404/5/16 | 1404/5/19 |
| 541 | 4.1.7.3.1.3 | Welding of Pipe To Flange | 5d | 2025-08-11 | 2025-08-16 | 540 | 55d | 0d |  | 1404/5/20 | 1404/5/25 |
| 542 | 4.1.7.3.2 | **Lifting & Other External Part** | 5d | 2025-05-13 | 2025-05-18 |  | 135d |  |  | 1404/2/23 | 1404/2/28 |
| 543 | 4.1.7.3.2.1 | Marking & Cutting & Beveling Lifting & Other External Part | 1d | 2025-05-13 | 2025-05-13 | 96, 218FS+6d | 135d | 0d |  | 1404/2/23 | 1404/2/23 |
| 544 | 4.1.7.3.2.2 | Drilling Lifting & Other External Part | 1d | 2025-05-14 | 2025-05-14 | 543 | 135d | 0d |  | 1404/2/24 | 1404/2/24 |
| 545 | 4.1.7.3.2.3 | Assembling of external parts together | 1d | 2025-05-15 | 2025-05-15 | 544 | 135d | 0d |  | 1404/2/25 | 1404/2/25 |
| 546 | 4.1.7.3.2.4 | Welding of external parts together | 2d | 2025-05-17 | 2025-05-18 | 545 | 135d | 80d |  | 1404/2/27 | 1404/2/28 |
| 547 | 4.1.7.4 | **Internal Part** | 7d | 2025-05-06 | 2025-05-13 |  | 142d |  |  | 1404/2/16 | 1404/2/23 |
| 548 | 4.1.7.4.1 | Marking & Cutting & Beveling Internal Part | 1d | 2025-05-06 | 2025-05-06 | 96, 218 | 142d | 0d |  | 1404/2/16 | 1404/2/16 |
| 549 | 4.1.7.4.2 | Drilling Internal Part | 1d | 2025-05-07 | 2025-05-07 | 548 | 142d | 0d |  | 1404/2/17 | 1404/2/17 |
| 550 | 4.1.7.4.3 | Assembling of Internal parts together | 2d | 2025-05-08 | 2025-05-10 | 549 | 142d | 0d |  | 1404/2/18 | 1404/2/20 |
| 551 | 4.1.7.4.4 | Welding of Internal parts together | 3d | 2025-05-11 | 2025-05-13 | 550 | 142d | 87d |  | 1404/2/21 | 1404/2/23 |
| 552 | 4.1.7.5 | **Final Assembly** | 64d | 2025-06-15 | 2025-08-27 |  | 55d |  |  | 1404/3/25 | 1404/6/5 |
| 553 | 4.1.7.5.1 | Assembling Shell course & head | 1d | 2025-06-15 | 2025-06-15 | 533, 536, 970 | 106d | 0d |  | 1404/3/25 | 1404/3/25 |
| 554 | 4.1.7.5.2 | Welding Shell course & head | 1d | 2025-06-16 | 2025-06-16 | 553 | 106d | 0d |  | 1404/3/26 | 1404/3/26 |
| 555 | 4.1.7.5.3 | Marking & Opening Nozzle | 1d | 2025-06-17 | 2025-06-17 | 554 | 106d | 51d |  | 1404/3/27 | 1404/3/27 |
| 556 | 4.1.7.5.4 | Assembling nozzel & manhole | 1d | 2025-08-17 | 2025-08-17 | 541, 555 | 55d | 0d |  | 1404/5/26 | 1404/5/26 |
| 557 | 4.1.7.5.5 | Welding of nozzel & manhole | 2d | 2025-08-18 | 2025-08-19 | 556 | 55d | 0d |  | 1404/5/27 | 1404/5/28 |
| 558 | 4.1.7.5.6 | Assembling of Lifting & Other External Part | 1d | 2025-08-20 | 2025-08-20 | 546, 557 | 55d | 0d |  | 1404/5/29 | 1404/5/29 |
| 559 | 4.1.7.5.7 | Welding of Lifting & Other External Part | 2d | 2025-08-21 | 2025-08-23 | 558 | 55d | 0d |  | 1404/5/30 | 1404/6/1 |
| 560 | 4.1.7.5.8 | Assembling of internal parts | 1d | 2025-08-24 | 2025-08-24 | 551, 559 | 55d | 0d |  | 1404/6/2 | 1404/6/2 |
| 561 | 4.1.7.5.9 | Welding of Internal parts | 1d | 2025-08-25 | 2025-08-25 | 560 | 55d | 0d |  | 1404/6/3 | 1404/6/3 |
| 562 | 4.1.7.5.10 | Final dimensional Inspection | 2d | 2025-08-26 | 2025-08-27 | 561, 971, 972 | 55d | 0d |  | 1404/6/4 | 1404/6/5 |

| ID | WBS | Task | Duration | Start | Finish | Predecessors | Total slack | Free slack | Constraint | شروع | پایان |
| --- | --- | --- | --- | --- | --- | --- | --- | --- | --- | --- | --- |
| 563 | 4.1.7.6 | **Final Activity** | 18d | 2025-08-28 | 2025-09-17 |  | 52d |  |  | 1404/6/6 | 1404/6/26 |
| 564 | 4.1.7.6.1 | prepare for PWHT | 2d | 2025-08-28 | 2025-08-30 | 562 | 55d | 0d |  | 1404/6/6 | 1404/6/8 |
| 565 | 4.1.7.6.2 | PWHT | 1d | 2025-08-31 | 2025-08-31 | 564, 24, 20 | 55d | 0d |  | 1404/6/9 | 1404/6/9 |
| 566 | 4.1.7.6.3 | NDT after PWHT | 1d | 2025-09-01 | 2025-09-01 | 565 | 55d | 0d |  | 1404/6/10 | 1404/6/10 |
| 567 | 4.1.7.6.4 | Prepare for Hydrotest | 2d | 2025-09-02 | 2025-09-03 | 566 | 55d | 0d |  | 1404/6/11 | 1404/6/12 |
| 568 | 4.1.7.6.5 | Hydrotest | 3d | 2025-09-04 | 2025-09-07 | 567, 28, 973, 974, 976, 977, 978 | 55d | 0d |  | 1404/6/13 | 1404/6/16 |
| 569 | 4.1.7.6.6 | Sanblasting & Painting | 4d | 2025-09-14 | 2025-09-17 | 568, 264, 980, 981, 266 | 52d | 0d |  | 1404/6/23 | 1404/6/26 |
| 570 | 4.1.8 | **E-100 Glycol reflux condenser COIL TYPE** | 129d | 2025-05-06 | 2025-10-02 |  | 39d |  |  | 1404/2/16 | 1404/7/10 |
| 571 | 4.1.8.1 | **Shell** | 5d | 2025-05-18 | 2025-05-22 |  | 101d |  |  | 1404/2/28 | 1404/3/1 |
| 572 | 4.1.8.1.1 | Marking & Cutting & Beveling | 1d | 2025-05-18 | 2025-05-18 | 101, 102, 218FS+10d | 101d | 0d |  | 1404/2/28 | 1404/2/28 |
| 573 | 4.1.8.1.2 | Pre- Assembling & Per-Welding of Plates | 1d | 2025-05-19 | 2025-05-19 | 572, 984 | 101d | 0d |  | 1404/2/29 | 1404/2/29 |
| 574 | 4.1.8.1.3 | Rolling | 1d | 2025-05-20 | 2025-05-20 | 573 | 101d | 0d |  | 1404/2/30 | 1404/2/30 |
| 575 | 4.1.8.1.4 | Assemble & Welding of Plates | 1d | 2025-05-21 | 2025-05-21 | 574 | 101d | 0d |  | 1404/2/31 | 1404/2/31 |
| 576 | 4.1.8.1.5 | Rerolling | 1d | 2025-05-22 | 2025-05-22 | 575 | 101d | 0d |  | 1404/3/1 | 1404/3/1 |
| 577 | 4.1.8.2 | **External Part** | 83d | 2025-05-06 | 2025-08-10 |  | 45d |  |  | 1404/2/16 | 1404/5/19 |
| 578 | 4.1.8.2.1 | **Nozzles & Manholes** | 83d | 2025-05-06 | 2025-08-10 |  | 39d |  |  | 1404/2/16 | 1404/5/19 |
| 579 | 4.1.8.2.1.1 | Cutting & Beveling Pipe | 1d | 2025-05-06 | 2025-05-06 | 102, 215 | 118d | 79d | start no earlier than 2024-10-09 | 1404/2/16 | 1404/2/16 |
| 580 | 4.1.8.2.1.2 | Assembling of Pipe To Flange | 1d | 2025-08-07 | 2025-08-07 | 579, 221, 227 | 39d | 0d |  | 1404/5/16 | 1404/5/16 |
| 581 | 4.1.8.2.1.3 | Welding of Pipe To Flange | 2d | 2025-08-09 | 2025-08-10 | 580 | 39d | 0d |  | 1404/5/18 | 1404/5/19 |
| 582 | 4.1.8.2.2 | **Lifting & Other External Part** | 6d | 2025-05-18 | 2025-05-24 |  | 112d |  |  | 1404/2/28 | 1404/3/3 |
| 583 | 4.1.8.2.2.1 | Marking & Cutting & Beveling Lifting & Other External Part | 1d | 2025-05-18 | 2025-05-18 | 102, 218FS+10d | 112d | 0d |  | 1404/2/28 | 1404/2/28 |
| 584 | 4.1.8.2.2.2 | Drilling Lifting & Other External Part | 2d | 2025-05-19 | 2025-05-20 | 583 | 112d | 0d |  | 1404/2/29 | 1404/2/30 |
| 585 | 4.1.8.2.2.3 | Assembling of external parts together | 1d | 2025-05-21 | 2025-05-21 | 584 | 112d | 0d |  | 1404/2/31 | 1404/2/31 |
| 586 | 4.1.8.2.2.4 | Welding of external parts together | 2d | 2025-05-22 | 2025-05-24 | 585 | 112d | 73d |  | 1404/3/1 | 1404/3/3 |

| ID | WBS | Task | Duration | Start | Finish | Predecessors | Total slack | Free slack | Constraint | شروع | پایان |
| --- | --- | --- | --- | --- | --- | --- | --- | --- | --- | --- | --- |
| 587 | 4.1.8.3 | **Coil** | 10d | 2025-05-06 | 2025-05-17 |  | 121d |  |  | 1404/2/16 | 1404/2/27 |
| 588 | 4.1.8.3.1 | Cutting & Beveling Coil | 2d | 2025-05-06 | 2025-05-07 | 102, 215 | 121d | 0d | start no earlier than 2024-10-09 | 1404/2/16 | 1404/2/17 |
| 589 | 4.1.8.3.2 | Assembling of coil together | 3d | 2025-05-08 | 2025-05-11 | 588 | 121d | 0d | start no earlier than 2024-10-09 | 1404/2/18 | 1404/2/21 |
| 590 | 4.1.8.3.3 | Welding of Coil together | 5d | 2025-05-12 | 2025-05-17 | 589 | 121d | 9d | start no earlier than 2024-10-09 | 1404/2/22 | 1404/2/27 |
| 591 | 4.1.8.4 | **Final Assembly** | 98d | 2025-05-24 | 2025-09-14 |  | 39d |  |  | 1404/3/3 | 1404/6/23 |
| 592 | 4.1.8.4.1 | Assembling Shell course & Body flanges | 1d | 2025-05-24 | 2025-05-24 | 576, 985 | 101d | 0d |  | 1404/3/3 | 1404/3/3 |
| 593 | 4.1.8.4.2 | Welding Shell course & Body flanges | 3d | 2025-05-25 | 2025-05-27 | 592 | 101d | 0d |  | 1404/3/4 | 1404/3/6 |
| 594 | 4.1.8.4.3 | Marking & Opening Nozzle | 2d | 2025-05-28 | 2025-05-29 | 593 | 101d | 62d |  | 1404/3/7 | 1404/3/8 |
| 595 | 4.1.8.4.4 | Assembling nozzel & manhole | 4d | 2025-08-11 | 2025-08-14 | 581, 594 | 39d | 0d |  | 1404/5/20 | 1404/5/23 |
| 596 | 4.1.8.4.5 | Welding of nozzel & manhole | 2d | 2025-08-16 | 2025-08-17 | 595, 986 | 39d | 0d |  | 1404/5/25 | 1404/5/26 |
| 597 | 4.1.8.4.6 | Assembling of Lifting & Other External Part | 1d | 2025-08-18 | 2025-08-18 | 586, 596 | 39d | 0d |  | 1404/5/27 | 1404/5/27 |
| 598 | 4.1.8.4.7 | Welding of Lifting & Other External Part | 2d | 2025-08-19 | 2025-08-20 | 597 | 39d | 0d |  | 1404/5/28 | 1404/5/29 |
| 599 | 4.1.8.4.8 | Assembling of Coil to Shell | 8d | 2025-08-21 | 2025-08-30 | 590, 598 | 39d | 0d |  | 1404/5/30 | 1404/6/8 |
| 600 | 4.1.8.4.9 | Welding of Coil to Shell | 11d | 2025-08-31 | 2025-09-11 | 599 | 39d | 0d |  | 1404/6/9 | 1404/6/20 |
| 601 | 4.1.8.4.10 | Final dimensional Inspection | 2d | 2025-09-13 | 2025-09-14 | 600, 987 | 39d | 0d |  | 1404/6/22 | 1404/6/23 |
| 602 | 4.1.8.5 | **Final Activity** | 16d | 2025-09-15 | 2025-10-02 |  | 39d |  |  | 1404/6/24 | 1404/7/10 |
| 603 | 4.1.8.5.1 | prepare for PWHT | 2d | 2025-09-15 | 2025-09-16 | 601 | 39d | 0d |  | 1404/6/24 | 1404/6/25 |
| 604 | 4.1.8.5.2 | PWHT | 1d | 2025-09-17 | 2025-09-17 | 603, 24, 20 | 39d | 0d |  | 1404/6/26 | 1404/6/26 |
| 605 | 4.1.8.5.3 | NDT after PWHT | 1d | 2025-09-18 | 2025-09-18 | 604 | 39d | 0d |  | 1404/6/27 | 1404/6/27 |
| 606 | 4.1.8.5.4 | Prepare for Hydrotest | 2d | 2025-09-20 | 2025-09-21 | 605 | 39d | 0d |  | 1404/6/29 | 1404/6/30 |
| 607 | 4.1.8.5.5 | Hydrotest of shell side | 2d | 2025-09-22 | 2025-09-23 | 606, 29, 988, 989, 991, 992, 993 | 39d | 0d |  | 1404/6/31 | 1404/7/1 |
| 608 | 4.1.8.5.6 | Hydrotest of Coil side | 2d | 2025-09-24 | 2025-09-25 | 607, 29 | 39d | 0d |  | 1404/7/2 | 1404/7/3 |
| 609 | 4.1.8.5.7 | Sanblasting & Painting | 4d | 2025-09-29 | 2025-10-02 | 608, 264, 995, 996, 266 | 39d | 0d |  | 1404/7/7 | 1404/7/10 |
| 610 | 4.1.9 | **V-130 Surge Tank** | 136d | 2025-05-06 | 2025-10-11 |  | 32d |  |  | 1404/2/16 | 1404/7/19 |
| 611 | 4.1.9.1 | **Shell** | 16d | 2025-05-06 | 2025-05-24 |  | 100d |  |  | 1404/2/16 | 1404/3/3 |
| 612 | 4.1.9.1.1 | Marking & Cutting & Beveling | 2d | 2025-05-06 | 2025-05-07 | 125, 126, 218 | 100d | 0d |  | 1404/2/16 | 1404/2/17 |
| 613 | 4.1.9.1.2 | Pre- Assembling & Per-Welding of Plates | 2d | 2025-05-08 | 2025-05-10 | 612, 999 | 100d | 0d |  | 1404/2/18 | 1404/2/20 |
| 614 | 4.1.9.1.3 | Rolling | 4d | 2025-05-11 | 2025-05-14 | 613 | 100d | 0d |  | 1404/2/21 | 1404/2/24 |
| 615 | 4.1.9.1.4 | Assemble & Welding of Plates | 5d | 2025-05-15 | 2025-05-20 | 614 | 100d | 0d |  | 1404/2/25 | 1404/2/30 |
| 616 | 4.1.9.1.5 | Rerolling | 3d | 2025-05-21 | 2025-05-24 | 615 | 100d | 20d |  | 1404/2/31 | 1404/3/3 |

| ID | WBS | Task | Duration | Start | Finish | Predecessors | Total slack | Free slack | Constraint | شروع | پایان |
| --- | --- | --- | --- | --- | --- | --- | --- | --- | --- | --- | --- |
| 617 | 4.1.9.2 | **Head** | 36d | 2025-05-06 | 2025-06-16 |  | 80d |  |  | 1404/2/16 | 1404/3/26 |
| 618 | 4.1.9.2.1 | Marking & Cutting & Beveling head plate | 6d | 2025-05-06 | 2025-05-12 | 125, 126, 218 | 80d | 0d |  | 1404/2/16 | 1404/2/22 |
| 619 | 4.1.9.2.2 | Forming Head plate (sub contractor) | 30d | 2025-05-13 | 2025-06-16 | 618 | 80d | 0d |  | 1404/2/23 | 1404/3/26 |
| 620 | 4.1.9.3 | **External Part** | 90d | 2025-05-06 | 2025-08-18 |  | 39d |  |  | 1404/2/16 | 1404/5/27 |
| 621 | 4.1.9.3.1 | **Nozzles & Manholes** | 90d | 2025-05-06 | 2025-08-18 |  | 32d |  |  | 1404/2/16 | 1404/5/27 |
| 622 | 4.1.9.3.1.1 | Cutting & Beveling Pipe | 3d | 2025-05-06 | 2025-05-08 | 215 | 109d | 77d | start no earlier than 2024-10-09 | 1404/2/16 | 1404/2/18 |
| 623 | 4.1.9.3.1.2 | Assembling of Pipe To Flange | 4d | 2025-08-07 | 2025-08-11 | 622, 221, 227 | 32d | 0d |  | 1404/5/16 | 1404/5/20 |
| 624 | 4.1.9.3.1.3 | Welding of Pipe To Flange | 6d | 2025-08-12 | 2025-08-18 | 623 | 32d | 0d |  | 1404/5/21 | 1404/5/27 |
| 625 | 4.1.9.3.2 | **Lifting & Other External Part** | 18d | 2025-05-06 | 2025-05-26 |  | 111d |  |  | 1404/2/16 | 1404/3/5 |
| 626 | 4.1.9.3.2.1 | Marking & Cutting & Beveling Lifting & Other External Part | 2d | 2025-05-06 | 2025-05-07 | 218 | 111d | 0d |  | 1404/2/16 | 1404/2/17 |
| 627 | 4.1.9.3.2.2 | Drilling Lifting & Other External Part | 4d | 2025-05-08 | 2025-05-12 | 626 | 111d | 0d |  | 1404/2/18 | 1404/2/22 |
| 628 | 4.1.9.3.2.3 | Assembling of external parts together | 4d | 2025-05-13 | 2025-05-17 | 627 | 111d | 0d |  | 1404/2/23 | 1404/2/27 |
| 629 | 4.1.9.3.2.4 | Welding of external parts together | 8d | 2025-05-18 | 2025-05-26 | 628 | 111d | 79d |  | 1404/2/28 | 1404/3/5 |
| 630 | 4.1.9.4 | **Internal Part** | 10d | 2025-05-06 | 2025-05-17 |  | 136d |  |  | 1404/2/16 | 1404/2/27 |
| 631 | 4.1.9.4.1 | Marking & Cutting & Beveling Internal Part | 2d | 2025-05-06 | 2025-05-07 | 218 | 136d | 0d |  | 1404/2/16 | 1404/2/17 |
| 632 | 4.1.9.4.2 | Drilling Internal Part | 2d | 2025-05-08 | 2025-05-10 | 631 | 136d | 0d |  | 1404/2/18 | 1404/2/20 |
| 633 | 4.1.9.4.3 | Assembling of Internal parts together | 2d | 2025-05-11 | 2025-05-12 | 632 | 136d | 0d |  | 1404/2/21 | 1404/2/22 |
| 634 | 4.1.9.4.4 | Welding of Internal parts together | 4d | 2025-05-13 | 2025-05-17 | 633 | 136d | 104d |  | 1404/2/23 | 1404/2/27 |
| 635 | 4.1.9.5 | **Final Assembly** | 85d | 2025-06-17 | 2025-09-23 |  | 32d |  |  | 1404/3/27 | 1404/7/1 |
| 636 | 4.1.9.5.1 | Assembling Shell course & head | 2d | 2025-06-17 | 2025-06-18 | 616, 619, 1000 | 80d | 0d |  | 1404/3/27 | 1404/3/28 |
| 637 | 4.1.9.5.2 | Welding Shell course & head | 2d | 2025-06-19 | 2025-06-21 | 636 | 80d | 0d |  | 1404/3/29 | 1404/3/31 |
| 638 | 4.1.9.5.3 | Marking & Opening Nozzle | 2d | 2025-06-22 | 2025-06-23 | 637 | 80d | 48d |  | 1404/4/1 | 1404/4/2 |
| 639 | 4.1.9.5.4 | Assembling nozzel & manhole | 2d | 2025-08-19 | 2025-08-20 | 624, 638 | 32d | 0d |  | 1404/5/28 | 1404/5/29 |
| 640 | 4.1.9.5.5 | Welding of nozzel & manhole | 5d | 2025-08-21 | 2025-08-26 | 639, 1001 | 32d | 0d |  | 1404/5/30 | 1404/6/4 |
| 641 | 4.1.9.5.6 | Assembling of Lifting & Other External Part | 8d | 2025-08-27 | 2025-09-04 | 629, 640 | 32d | 0d |  | 1404/6/5 | 1404/6/13 |
| 642 | 4.1.9.5.7 | Welding of Lifting & Other External Part | 9d | 2025-09-06 | 2025-09-15 | 641 | 32d | 0d |  | 1404/6/15 | 1404/6/24 |
| 643 | 4.1.9.5.8 | Assembling of internal parts | 3d | 2025-09-16 | 2025-09-18 | 634, 642 | 32d | 0d |  | 1404/6/25 | 1404/6/27 |
| 644 | 4.1.9.5.9 | Welding of Internal parts | 2d | 2025-09-20 | 2025-09-21 | 643 | 32d | 0d |  | 1404/6/29 | 1404/6/30 |
| 645 | 4.1.9.5.10 | Final dimensional Inspection | 2d | 2025-09-22 | 2025-09-23 | 644, 1002 | 32d | 0d |  | 1404/6/31 | 1404/7/1 |

| ID | WBS | Task | Duration | Start | Finish | Predecessors | Total slack | Free slack | Constraint | شروع | پایان |
| --- | --- | --- | --- | --- | --- | --- | --- | --- | --- | --- | --- |
| 646 | 4.1.9.6 | **Final Activity** | 15d | 2025-09-24 | 2025-10-11 |  | 32d |  |  | 1404/7/2 | 1404/7/19 |
| 647 | 4.1.9.6.1 | prepare for PWHT | 2d | 2025-09-24 | 2025-09-25 | 645 | 32d | 0d |  | 1404/7/2 | 1404/7/3 |
| 648 | 4.1.9.6.2 | PWHT | 1d | 2025-09-27 | 2025-09-27 | 647, 24, 20 | 32d | 0d |  | 1404/7/5 | 1404/7/5 |
| 649 | 4.1.9.6.3 | NDT after PWHT | 2d | 2025-09-28 | 2025-09-29 | 648 | 32d | 0d |  | 1404/7/6 | 1404/7/7 |
| 650 | 4.1.9.6.4 | Prepare for Hydrotest | 1d | 2025-09-30 | 2025-09-30 | 649 | 32d | 0d |  | 1404/7/8 | 1404/7/8 |
| 651 | 4.1.9.6.5 | Hydrotest | 2d | 2025-10-01 | 2025-10-02 | 650, 28, 1003, 1004, 1006, 1007, 1008 | 32d | 0d |  | 1404/7/9 | 1404/7/10 |
| 652 | 4.1.9.6.6 | Sanblasting & Painting | 5d | 2025-10-06 | 2025-10-11 | 651, 264, 1010, 1011, 266 | 32d | 0d |  | 1404/7/14 | 1404/7/19 |
| 653 | 4.2 | **Heat exchanger** | 138d | 2025-05-06 | 2025-10-13 |  | 34d |  |  | 1404/2/16 | 1404/7/21 |
| 654 | 4.2.1 | **E -200 Rich-Lean HE** | 135d | 2025-05-06 | 2025-10-09 |  | 37d |  |  | 1404/2/16 | 1404/7/17 |
| 655 | 4.2.1.1 | **Shell** | 5d | 2025-05-15 | 2025-05-20 |  | 100d |  |  | 1404/2/25 | 1404/2/30 |
| 656 | 4.2.1.1.1 | Marking & Cutting & Beveling | 1d | 2025-05-15 | 2025-05-15 | 107, 108, 218FS+8d | 100d | 0d |  | 1404/2/25 | 1404/2/25 |
| 657 | 4.2.1.1.2 | Pre- Assembling & Per-Welding of Plates | 1d | 2025-05-17 | 2025-05-17 | 656, 1015 | 100d | 0d |  | 1404/2/27 | 1404/2/27 |
| 658 | 4.2.1.1.3 | Rolling | 1d | 2025-05-18 | 2025-05-18 | 657 | 100d | 0d |  | 1404/2/28 | 1404/2/28 |
| 659 | 4.2.1.1.4 | Assemble & Welding of Plates | 1d | 2025-05-19 | 2025-05-19 | 658 | 100d | 0d |  | 1404/2/29 | 1404/2/29 |
| 660 | 4.2.1.1.5 | Rerolling | 1d | 2025-05-20 | 2025-05-20 | 659 | 100d | 0d |  | 1404/2/30 | 1404/2/30 |
| 661 | 4.2.1.2 | **External Part** | 83d | 2025-05-06 | 2025-08-10 |  | 36d |  |  | 1404/2/16 | 1404/5/19 |
| 662 | 4.2.1.2.1 | **Nozzles & Manholes** | 83d | 2025-05-06 | 2025-08-10 |  | 33d |  |  | 1404/2/16 | 1404/5/19 |
| 663 | 4.2.1.2.1.1 | Cutting& Beveling Pipe | 1d | 2025-05-06 | 2025-05-06 | 108, 215 | 112d | 79d | start no earlier than 2024-10-09 | 1404/2/16 | 1404/2/16 |
| 664 | 4.2.1.2.1.2 | Assembling of Pipe To Flange | 1d | 2025-08-07 | 2025-08-07 | 663, 221, 227 | 33d | 0d |  | 1404/5/16 | 1404/5/16 |
| 665 | 4.2.1.2.1.3 | Welding of Pipe To Flange | 2d | 2025-08-09 | 2025-08-10 | 664 | 33d | 0d |  | 1404/5/18 | 1404/5/19 |
| 666 | 4.2.1.2.2 | **Lifting & Other External Part** | 6d | 2025-05-18 | 2025-05-24 |  | 103d |  |  | 1404/2/28 | 1404/3/3 |
| 667 | 4.2.1.2.2.1 | Marking& Cutting & Beveling Lifting & Other External Part | 1d | 2025-05-18 | 2025-05-18 | 108, 218FS+10d | 103d | 0d |  | 1404/2/28 | 1404/2/28 |
| 668 | 4.2.1.2.2.2 | Drilling Lifting& Other External Part | 2d | 2025-05-19 | 2025-05-20 | 667 | 103d | 0d |  | 1404/2/29 | 1404/2/30 |
| 669 | 4.2.1.2.2.3 | Assembling of external parts together | 1d | 2025-05-21 | 2025-05-21 | 668 | 103d | 0d |  | 1404/2/31 | 1404/2/31 |
| 670 | 4.2.1.2.2.4 | Welding of external parts together | 2d | 2025-05-22 | 2025-05-24 | 669 | 103d | 70d |  | 1404/3/1 | 1404/3/3 |

| ID | WBS | Task | Duration | Start | Finish | Predecessors | Total slack | Free slack | شروع | پایان |
| --- | --- | --- | --- | --- | --- | --- | --- | --- | --- | --- |
| 671 | 4.2.1.3 | **Internal Plate** | 5d | 2025-05-06 | 2025-05-11 |  | 167d |  | 1404/2/16 | 1404/2/21 |
| 672 | 4.2.1.3.1 | Marking & Cutting & Beveling Internal plate | 2d | 2025-05-06 | 2025-05-07 | 108, 218 | 167d | 0d | 1404/2/16 | 1404/2/17 |
| 673 | 4.2.1.3.2 | Assembling of Internal plate together | 3d | 2025-05-08 | 2025-05-11 | 672 | 167d |  | 1404/2/18 | 1404/2/21 |
| 674 | 4.2.1.4 | **Final Assembly** | 106d | 2025-05-21 | 2025-09-21 |  | 33d |  | 1404/2/31 | 1404/6/30 |
| 675 | 4.2.1.4.1 | Assembling Shell course & Body flanges | 1d | 2025-05-21 | 2025-05-21 | 660, 1016 | 100d | 0d | 1404/2/31 | 1404/2/31 |
| 676 | 4.2.1.4.2 | Welding Shell course & Body flanges | 1d | 2025-05-22 | 2025-05-22 | 675 | 100d | 0d | 1404/3/1 | 1404/3/1 |
| 677 | 4.2.1.4.3 | Marking & Opening Nozzle | 1d | 2025-05-24 | 2025-05-24 | 676 | 100d | 67d | 1404/3/3 | 1404/3/3 |
| 678 | 4.2.1.4.4 | Assembling nozzel & manhole | 1d | 2025-08-11 | 2025-08-11 | 665, 677 | 33d | 0d | 1404/5/20 | 1404/5/20 |
| 679 | 4.2.1.4.5 | Welding of nozzel & manhole | 2d | 2025-08-12 | 2025-08-13 | 678, 1018 | 33d | 0d | 1404/5/21 | 1404/5/22 |
| 680 | 4.2.1.4.6 | Assembling of Lifting & Other External Part | 1d | 2025-08-14 | 2025-08-14 | 670, 679 | 33d | 0d | 1404/5/23 | 1404/5/23 |
| 681 | 4.2.1.4.7 | Welding of Lifting & Other External Part | 2d | 2025-08-16 | 2025-08-17 | 680 | 33d | 0d | 1404/5/25 | 1404/5/26 |
| 682 | 4.2.1.4.8 | Assembling of Internal plate to Shell | 14d | 2025-08-18 | 2025-09-02 | 681 | 33d | 0d | 1404/5/27 | 1404/6/11 |
| 683 | 4.2.1.4.9 | Welding of Internal plate to Shell | 14d | 2025-09-03 | 2025-09-18 | 682 | 33d | 0d | 1404/6/12 | 1404/6/27 |
| 684 | 4.2.1.4.10 | Final dimensional Inspection | 2d | 2025-09-20 | 2025-09-21 | 683, 1017, 1019 | 33d | 0d | 1404/6/29 | 1404/6/30 |
| 685 | 4.2.1.5 | **Final Activity** | 16d | 2025-09-22 | 2025-10-09 |  | 33d |  | 1404/6/31 | 1404/7/17 |
| 686 | 4.2.1.5.1 | prepare for PWHT | 2d | 2025-09-22 | 2025-09-23 | 684 | 33d | 0d | 1404/6/31 | 1404/7/1 |
| 687 | 4.2.1.5.2 | PWHT | 1d | 2025-09-24 | 2025-09-24 | 686, 24, 20 | 33d | 0d | 1404/7/2 | 1404/7/2 |
| 688 | 4.2.1.5.3 | NDT after PWHT | 1d | 2025-09-25 | 2025-09-25 | 687 | 33d | 0d | 1404/7/3 | 1404/7/3 |
| 689 | 4.2.1.5.4 | Prepare for Hydrotest | 2d | 2025-09-27 | 2025-09-28 | 688 | 33d | 0d | 1404/7/5 | 1404/7/6 |
| 690 | 4.2.1.5.5 | Hydrotest of shell side | 2d | 2025-09-29 | 2025-09-30 | 689, 29, 1020, 1021, 1023, 1024, 1025 | 33d | 0d | 1404/7/7 | 1404/7/8 |
| 691 | 4.2.1.5.6 | Hydrotest of internal side side | 2d | 2025-10-01 | 2025-10-02 | 690, 29 | 33d | 0d | 1404/7/9 | 1404/7/10 |
| 692 | 4.2.1.5.7 | Sanblasting & Painting | 4d | 2025-10-06 | 2025-10-09 | 691, 264, 1027, 1028, 266 | 33d | 0d | 1404/7/14 | 1404/7/17 |
| 693 | 4.2.2 | **E -300 LEAN TEG - DRY GAS EXCH** | 138d | 2025-05-06 | 2025-10-13 |  | 30d |  | 1404/2/16 | 1404/7/21 |
| 694 | 4.2.2.1 | **Shell** | 5d | 2025-05-06 | 2025-05-11 |  | 105d |  | 1404/2/16 | 1404/2/21 |
| 695 | 4.2.2.1.1 | Marking & Cutting & Beveling | 1d | 2025-05-06 | 2025-05-06 | 113, 114, 218 | 105d | 0d | 1404/2/16 | 1404/2/16 |
| 696 | 4.2.2.1.2 | Pre- Assembling & Per-Welding of Plates | 1d | 2025-05-07 | 2025-05-07 | 695, 1031 | 105d | 0d | 1404/2/17 | 1404/2/17 |
| 697 | 4.2.2.1.3 | Rolling | 1d | 2025-05-08 | 2025-05-08 | 696 | 105d | 0d | 1404/2/18 | 1404/2/18 |
| 698 | 4.2.2.1.4 | Assemble & Welding of Plates | 1d | 2025-05-10 | 2025-05-10 | 697 | 105d | 0d | 1404/2/20 | 1404/2/20 |
| 699 | 4.2.2.1.5 | Rerolling | 1d | 2025-05-11 | 2025-05-11 | 698 | 105d | 0d | 1404/2/21 | 1404/2/21 |

| ID | WBS | Task | Duration | Start | Finish | Predecessors | Total slack | Free slack | Constraint | شروع | پایان |
| --- | --- | --- | --- | --- | --- | --- | --- | --- | --- | --- | --- |
| 700 | 4.2.2.2 | **External Part** | 83d | 2025-05-06 | 2025-08-10 |  | 33d |  |  | 1404/2/16 | 1404/5/19 |
| 701 | 4.2.2.2.1 | **Nozzles & Manholes** | 83d | 2025-05-06 | 2025-08-10 |  | 30d |  |  | 1404/2/16 | 1404/5/19 |
| 702 | 4.2.2.2.1.1 | Cutting & Beveling Pipe | 1d | 2025-05-06 | 2025-05-06 | 114, 215 | 109d | 79d | start no earlier than 2024-10-09 | 1404/2/16 | 1404/2/16 |
| 703 | 4.2.2.2.1.2 | Assembling of Pipe To Flange | 1d | 2025-08-07 | 2025-08-07 | 702, 221, 227 | 30d | 0d |  | 1404/5/16 | 1404/5/16 |
| 704 | 4.2.2.2.1.3 | Welding of Pipe To Flange | 2d | 2025-08-09 | 2025-08-10 | 703 | 30d | 0d |  | 1404/5/18 | 1404/5/19 |
| 705 | 4.2.2.2.2 | **Lifting & Other External Part** | 6d | 2025-05-06 | 2025-05-12 |  | 110d |  |  | 1404/2/16 | 1404/2/22 |
| 706 | 4.2.2.2.2.1 | Marking & Cutting & Beveling Lifting & Other External Part | 1d | 2025-05-06 | 2025-05-06 | 114, 218 | 110d | 0d |  | 1404/2/16 | 1404/2/16 |
| 707 | 4.2.2.2.2.2 | Drilling Lifting & Other External Part | 2d | 2025-05-07 | 2025-05-08 | 706 | 110d | 0d |  | 1404/2/17 | 1404/2/18 |
| 708 | 4.2.2.2.2.3 | Assembling of external parts together | 1d | 2025-05-10 | 2025-05-10 | 707 | 110d | 0d |  | 1404/2/20 | 1404/2/20 |
| 709 | 4.2.2.2.2.4 | Welding of external parts together | 2d | 2025-05-11 | 2025-05-12 | 708 | 110d | 80d |  | 1404/2/21 | 1404/2/22 |
| 710 | 4.2.2.3 | **Tube Bundle** | 33d | 2025-05-06 | 2025-06-12 |  | 86d |  |  | 1404/2/16 | 1404/3/22 |
| 711 | 4.2.2.3.1 | Cutting & Beveling of Baffles & Tie rod & Spacer &Stripper | 4d | 2025-05-06 | 2025-05-10 | 114, 215, 218 | 86d | 0d |  | 1404/2/16 | 1404/2/20 |
| 712 | 4.2.2.3.2 | Drilling of Baffles | 5d | 2025-05-11 | 2025-05-15 | 711 | 86d | 0d |  | 1404/2/21 | 1404/2/25 |
| 713 | 4.2.2.3.3 | Assembling of Tube & Tie rod & Spacer &Stripper in to Baffles | 11d | 2025-05-17 | 2025-05-28 | 712 | 86d | 0d |  | 1404/2/27 | 1404/3/7 |
| 714 | 4.2.2.3.4 | Welding of Tube & Tie rod & Spacer &Stripper in to Baffles | 13d | 2025-05-29 | 2025-06-12 | 713 | 86d | 56d |  | 1404/3/8 | 1404/3/22 |
| 715 | 4.2.2.4 | **Final Assembly** | 117d | 2025-05-12 | 2025-09-24 |  | 30d |  |  | 1404/2/22 | 1404/7/2 |
| 716 | 4.2.2.4.1 | Assembling Shell course & Body flanges | 1d | 2025-05-12 | 2025-05-12 | 699, 1032 | 105d | 0d |  | 1404/2/22 | 1404/2/22 |
| 717 | 4.2.2.4.2 | Welding Shell course & Body flanges | 1d | 2025-05-13 | 2025-05-13 | 716 | 105d | 0d |  | 1404/2/23 | 1404/2/23 |
| 718 | 4.2.2.4.3 | Marking & Opening Nozzle | 1d | 2025-05-14 | 2025-05-14 | 717 | 105d | 75d |  | 1404/2/24 | 1404/2/24 |
| 719 | 4.2.2.4.4 | Assembling nozzel & manhole | 1d | 2025-08-11 | 2025-08-11 | 704, 718 | 30d | 0d |  | 1404/5/20 | 1404/5/20 |
| 720 | 4.2.2.4.5 | Welding of nozzel & manhole | 2d | 2025-08-12 | 2025-08-13 | 719, 1034 | 30d | 0d |  | 1404/5/21 | 1404/5/22 |
| 721 | 4.2.2.4.6 | Assembling of Lifting & Other External Part | 1d | 2025-08-14 | 2025-08-14 | 709, 720 | 30d | 0d |  | 1404/5/23 | 1404/5/23 |
| 722 | 4.2.2.4.7 | Welding of Lifting & Other External Part | 2d | 2025-08-16 | 2025-08-17 | 721 | 30d | 0d |  | 1404/5/25 | 1404/5/26 |
| 723 | 4.2.2.4.8 | Assembling of Tube bandle& Tube Sheet to Shell | 8d | 2025-08-18 | 2025-08-26 | 714, 722 | 30d | 0d |  | 1404/5/27 | 1404/6/4 |
| 724 | 4.2.2.4.9 | Welding of Tube bandle& tube SheetT to Shell | 11d | 2025-08-27 | 2025-09-08 | 723 | 30d | 0d |  | 1404/6/5 | 1404/6/17 |
| 725 | 4.2.2.4.10 | Welding of tube to tubesheet | 7d | 2025-09-09 | 2025-09-16 | 724 | 30d | 0d |  | 1404/6/18 | 1404/6/25 |
| 726 | 4.2.2.4.11 | Expanding of Tube sheet | 5d | 2025-09-17 | 2025-09-22 | 725 | 30d | 0d |  | 1404/6/26 | 1404/6/31 |
| 727 | 4.2.2.4.12 | Final dimensional Inspection | 2d | 2025-09-23 | 2025-09-24 | 726, 1033, 1035 | 30d | 0d |  | 1404/7/1 | 1404/7/2 |

| ID | WBS | Task | Duration | Start | Finish | Predecessors | Total slack | Free slack | Constraint | شروع | پایان |
| --- | --- | --- | --- | --- | --- | --- | --- | --- | --- | --- | --- |
| 728 | 4.2.2.5 | **Final Activity** | 16d | 2025-09-25 | 2025-10-13 |  | 30d |  |  | 1404/7/3 | 1404/7/21 |
| 729 | 4.2.2.5.1 | prepare for PWHT | 2d | 2025-09-25 | 2025-09-27 | 727 | 30d | 0d |  | 1404/7/3 | 1404/7/5 |
| 730 | 4.2.2.5.2 | PWHT | 1d | 2025-09-28 | 2025-09-28 | 729, 24, 20 | 30d | 0d |  | 1404/7/6 | 1404/7/6 |
| 731 | 4.2.2.5.3 | NDT after PWHT | 1d | 2025-09-29 | 2025-09-29 | 730 | 30d | 0d |  | 1404/7/7 | 1404/7/7 |
| 732 | 4.2.2.5.4 | Prepare for Hydrotest | 2d | 2025-09-30 | 2025-10-01 | 731 | 30d | 0d |  | 1404/7/8 | 1404/7/9 |
| 733 | 4.2.2.5.5 | Hydrotest of shell side | 2d | 2025-10-02 | 2025-10-04 | 732, 29, 1036, 1037, 1039, 1040, 1041 | 30d | 0d |  | 1404/7/10 | 1404/7/12 |
| 734 | 4.2.2.5.6 | Hydrotest of tube side | 2d | 2025-10-05 | 2025-10-06 | 733, 29 | 30d | 0d |  | 1404/7/13 | 1404/7/14 |
| 735 | 4.2.2.5.7 | Sanblasting & Painting | 4d | 2025-10-09 | 2025-10-13 | 734, 264, 1043, 1044, 266 | 30d | 0d |  | 1404/7/17 | 1404/7/21 |
| 736 | 4.3 | **R-100 Reboiler** | 128d | 2025-05-06 | 2025-10-01 |  | 40d |  |  | 1404/2/16 | 1404/7/9 |
| 737 | 4.3.1 | **Shell** | 7d | 2025-05-06 | 2025-05-13 |  | 113d |  |  | 1404/2/16 | 1404/2/23 |
| 738 | 4.3.1.1 | Marking & Cutting & Beveling | 1d | 2025-05-06 | 2025-05-06 | 119, 120, 218 | 113d | 0d |  | 1404/2/16 | 1404/2/16 |
| 739 | 4.3.1.2 | Pre- Assembling & Per-Welding of Plates | 1d | 2025-05-07 | 2025-05-07 | 738, 1047 | 113d | 0d |  | 1404/2/17 | 1404/2/17 |
| 740 | 4.3.1.3 | Rolling | 2d | 2025-05-08 | 2025-05-10 | 739 | 113d | 0d |  | 1404/2/18 | 1404/2/20 |
| 741 | 4.3.1.4 | Assemble & Welding of Plates | 2d | 2025-05-11 | 2025-05-12 | 740 | 113d | 0d |  | 1404/2/21 | 1404/2/22 |
| 742 | 4.3.1.5 | Rerolling | 1d | 2025-05-13 | 2025-05-13 | 741 | 113d | 25d |  | 1404/2/23 | 1404/2/23 |
| 743 | 4.3.2 | **Head** | 32d | 2025-05-06 | 2025-06-11 |  | 88d |  |  | 1404/2/16 | 1404/3/21 |
| 744 | 4.3.2.1 | Marking & Cutting & Beveling head plate | 2d | 2025-05-06 | 2025-05-07 | 119, 120, 218 | 88d | 0d |  | 1404/2/16 | 1404/2/17 |
| 745 | 4.3.2.2 | Forming Head plate (sub contractor) | 30d | 2025-05-08 | 2025-06-11 | 744 | 88d | 0d |  | 1404/2/18 | 1404/3/21 |
| 746 | 4.3.3 | **External Part** | 93d | 2025-05-06 | 2025-08-21 |  | 47d |  |  | 1404/2/16 | 1404/5/30 |
| 747 | 4.3.3.1 | **Nozzles & Manholes** | 93d | 2025-05-06 | 2025-08-21 |  | 40d |  |  | 1404/2/16 | 1404/5/30 |
| 748 | 4.3.3.1.1 | Cutting & Beveling Pipe | 5d | 2025-05-06 | 2025-05-11 | 215 | 115d | 75d | start no earlier than 2024-10-09 | 1404/2/16 | 1404/2/21 |
| 749 | 4.3.3.1.2 | Assembling of Pipe To Flange | 4d | 2025-08-07 | 2025-08-11 | 748, 221, 227 | 40d | 0d |  | 1404/5/16 | 1404/5/20 |
| 750 | 4.3.3.1.3 | Welding of Pipe To Flange | 9d | 2025-08-12 | 2025-08-21 | 749 | 40d | 0d |  | 1404/5/21 | 1404/5/30 |
| 751 | 4.3.3.2 | **Lifting & Other External Part** | 16d | 2025-05-06 | 2025-05-24 |  | 124d |  |  | 1404/2/16 | 1404/3/3 |
| 752 | 4.3.3.2.1 | Marking & Cutting & Beveling Lifting & Other External Part | 2d | 2025-05-06 | 2025-05-07 | 218 | 124d | 0d |  | 1404/2/16 | 1404/2/17 |
| 753 | 4.3.3.2.2 | Drilling Lifting & Other External Part | 4d | 2025-05-08 | 2025-05-12 | 752 | 124d | 0d |  | 1404/2/18 | 1404/2/22 |
| 754 | 4.3.3.2.3 | Assembling of external parts together | 4d | 2025-05-13 | 2025-05-17 | 753 | 124d | 0d |  | 1404/2/23 | 1404/2/27 |
| 755 | 4.3.3.2.4 | Welding of external parts together | 6d | 2025-05-18 | 2025-05-24 | 754 | 124d | 84d |  | 1404/2/28 | 1404/3/3 |

| ID | WBS | Task | Duration | Start | Finish | Predecessors | Total slack | Free slack | شروع | پایان |
| --- | --- | --- | --- | --- | --- | --- | --- | --- | --- | --- |
| 756 | 4.3.4 | **Internal Part** | 9d | 2025-05-06 | 2025-05-15 |  | 138d |  | 1404/2/16 | 1404/2/25 |
| 757 | 4.3.4.1 | Marking & Cutting & Beveling Internal Part | 1d | 2025-05-06 | 2025-05-06 | 218 | 138d | 0d | 1404/2/16 | 1404/2/16 |
| 758 | 4.3.4.2 | Drilling Internal Part | 2d | 2025-05-07 | 2025-05-08 | 757 | 138d | 0d | 1404/2/17 | 1404/2/18 |
| 759 | 4.3.4.3 | Assembling of Internal parts together | 2d | 2025-05-10 | 2025-05-11 | 758 | 138d | 0d | 1404/2/20 | 1404/2/21 |
| 760 | 4.3.4.4 | Welding of Internal parts together | 4d | 2025-05-12 | 2025-05-15 | 759 | 138d | 98d | 1404/2/22 | 1404/2/25 |
| 761 | 4.3.5 | **Final Assembly** | 83d | 2025-06-12 | 2025-09-16 |  | 40d |  | 1404/3/22 | 1404/6/25 |
| 762 | 4.3.5.1 | Assembling Shell course & head | 5d | 2025-06-12 | 2025-06-17 | 742, 745, 1048 | 88d | 0d | 1404/3/22 | 1404/3/27 |
| 763 | 4.3.5.2 | Welding Shell course & head | 6d | 2025-06-18 | 2025-06-24 | 762 | 88d | 0d | 1404/3/28 | 1404/4/3 |
| 764 | 4.3.5.3 | Marking & Opening Nozzle | 2d | 2025-06-25 | 2025-06-26 | 763 | 88d | 48d | 1404/4/4 | 1404/4/5 |
| 765 | 4.3.5.4 | Assembling nozzel & manhole | 2d | 2025-08-23 | 2025-08-24 | 750, 764 | 40d | 0d | 1404/6/1 | 1404/6/2 |
| 766 | 4.3.5.5 | Welding of nozzel & manhole | 5d | 2025-08-25 | 2025-08-30 | 765, 1049 | 40d | 0d | 1404/6/3 | 1404/6/8 |
| 767 | 4.3.5.6 | Assembling of Lifting & Other External Part | 3d | 2025-08-31 | 2025-09-02 | 755, 766 | 40d | 0d | 1404/6/9 | 1404/6/11 |
| 768 | 4.3.5.7 | Welding of Lifting & Other External Part | 4d | 2025-09-03 | 2025-09-07 | 767 | 40d | 0d | 1404/6/12 | 1404/6/16 |
| 769 | 4.3.5.8 | Assembling of internal parts | 2d | 2025-09-08 | 2025-09-09 | 760, 768 | 40d | 0d | 1404/6/17 | 1404/6/18 |
| 770 | 4.3.5.9 | Welding of Internal parts | 4d | 2025-09-10 | 2025-09-14 | 769 | 40d | 0d | 1404/6/19 | 1404/6/23 |
| 771 | 4.3.5.10 | Final dimensional Inspection | 2d | 2025-09-15 | 2025-09-16 | 770, 1050 | 40d | 0d | 1404/6/24 | 1404/6/25 |
| 772 | 4.3.6 | **Final Activity** | 13d | 2025-09-17 | 2025-10-01 |  | 40d |  | 1404/6/26 | 1404/7/9 |
| 773 | 4.3.6.1 | prepare for PWHT | 2d | 2025-09-17 | 2025-09-18 | 771 | 40d | 0d | 1404/6/26 | 1404/6/27 |
| 774 | 4.3.6.2 | PWHT | 1d | 2025-09-20 | 2025-09-20 | 773, 24, 20 | 40d | 0d | 1404/6/29 | 1404/6/29 |
| 775 | 4.3.6.3 | NDT after PWHT | 1d | 2025-09-21 | 2025-09-21 | 774 | 40d | 0d | 1404/6/30 | 1404/6/30 |
| 776 | 4.3.6.4 | Prepare for Hydrotest | 1d | 2025-09-22 | 2025-09-22 | 775 | 40d | 0d | 1404/6/31 | 1404/6/31 |
| 777 | 4.3.6.5 | Hydrotest | 2d | 2025-09-23 | 2025-09-24 | 776, 28, 1051, 1052, 1054, 1055, 1056 | 40d | 0d | 1404/7/1 | 1404/7/2 |
| 778 | 4.3.6.6 | Sanblasting & Painting | 4d | 2025-09-28 | 2025-10-01 | 777, 264, 1058, 1059, 266 | 40d | 0d | 1404/7/6 | 1404/7/9 |
| 779 | 4.4 | **Skid of Gas Dehydration** | 163d | 2025-05-10 | 2025-11-15 |  | 2d |  | 1404/2/20 | 1404/8/24 |
| 780 | 4.4.1 | **Profile and Plate** | 70d | 2025-05-10 | 2025-07-29 |  | 89d |  | 1404/2/20 | 1404/5/7 |
| 781 | 4.4.1.1 | Marking & Cutting & Beveling of Profile and Plate | 15d | 2025-05-10 | 2025-05-26 | 139, 218, 251 | 89d | 0d | 1404/2/20 | 1404/3/5 |
| 782 | 4.4.1.2 | Drilling Profile and Plate | 15d | 2025-05-27 | 2025-06-12 | 781 | 89d | 0d | 1404/3/6 | 1404/3/22 |
| 783 | 4.4.1.3 | Assembling of Profile and Plate together | 20d | 2025-06-14 | 2025-07-06 | 782 | 89d | 0d | 1404/3/24 | 1404/4/15 |
| 784 | 4.4.1.4 | Welding of Profile and Plate together | 20d | 2025-07-07 | 2025-07-29 | 783 | 89d |  | 1404/4/16 | 1404/5/7 |

| ID | WBS | Task | Duration | Start | Finish | Predecessors | Total slack | Free slack | Constraint | شروع | پایان |
| --- | --- | --- | --- | --- | --- | --- | --- | --- | --- | --- | --- |
| 785 | 4.4.2 | **Final Activity** | 4d | 2025-11-11 | 2025-11-15 |  | 0d |  |  | 1404/8/20 | 1404/8/24 |
| 786 | 4.4.2.1 | Final dimensional Inspection | 2d | 2025-11-11 | 2025-11-12 | 784, 212, 233, 236, 242, 245, 248, 254, 257, 260 | 0d |  |  | 1404/8/20 | 1404/8/21 |
| 787 | 4.4.2.2 | Sanblasting & Painting | 2d | 2025-11-13 | 2025-11-15 | 786, 264, 1062, 266 | 2d |  |  | 1404/8/22 | 1404/8/24 |
| 788 | 4.5 | **Piping of Gas Dehydration** | 131d | 2025-06-18 | 2025-11-17 |  | 0d |  |  | 1404/3/28 | 1404/8/26 |
| 789 | 4.5.1 | **Piping and External support** | 85d | 2025-06-18 | 2025-09-24 |  | 22d |  |  | 1404/3/28 | 1404/7/2 |
| 790 | 4.5.1.1 | Cutting & Beveling Pipe | 20d | 2025-06-18 | 2025-07-10 | 144, 215 | 45d | 23d | start no earlier than 2024-10-09 | 1404/3/28 | 1404/4/19 |
| 791 | 4.5.1.2 | Assembling of Pipe To Flange | 10d | 2025-08-07 | 2025-08-18 | 790, 221, 227 | 22d | 0d |  | 1404/5/16 | 1404/5/27 |
| 792 | 4.5.1.3 | Welding of Pipe To Flange | 15d | 2025-08-19 | 2025-09-04 | 791 | 22d | 0d |  | 1404/5/28 | 1404/6/13 |
| 793 | 4.5.1.4 | Marking & Cutting & Beveling External Plate | 5d | 2025-09-06 | 2025-09-10 | 792, 218 | 22d | 0d |  | 1404/6/15 | 1404/6/19 |
| 794 | 4.5.1.5 | Assembling of External Plate To Pipe | 4d | 2025-09-11 | 2025-09-15 | 793 | 22d | 0d |  | 1404/6/20 | 1404/6/24 |
| 795 | 4.5.1.6 | Welding of External Plate To Pipe | 8d | 2025-09-16 | 2025-09-24 | 794 | 22d | 0d |  | 1404/6/25 | 1404/7/2 |
| 796 | 4.5.2 | **Final Activity** | 46d | 2025-09-25 | 2025-11-17 |  | 0d |  |  | 1404/7/3 | 1404/8/26 |
| 797 | 4.5.2.1 | prepare for PWHT | 3d | 2025-09-25 | 2025-09-28 | 795 | 22d | 0d |  | 1404/7/3 | 1404/7/6 |
| 798 | 4.5.2.2 | PWHT | 3d | 2025-09-29 | 2025-10-01 | 797, 24, 20 | 22d | 0d |  | 1404/7/7 | 1404/7/9 |
| 799 | 4.5.2.3 | NDT after PWHT | 3d | 2025-10-02 | 2025-10-05 | 798 | 22d | 0d |  | 1404/7/10 | 1404/7/13 |
| 800 | 4.5.2.4 | Prepare for Hydrotest | 5d | 2025-10-06 | 2025-10-11 | 799 | 22d | 0d |  | 1404/7/14 | 1404/7/19 |
| 801 | 4.5.2.5 | Hydrotest | 6d | 2025-10-12 | 2025-10-18 | 800, 28 | 22d |  |  | 1404/7/20 | 1404/7/26 |
| 802 | 4.5.2.6 | Sanblasting & Painting | 4d | 2025-11-13 | 2025-11-17 | 801, 264, 1064, 266 | 0d |  |  | 1404/8/22 | 1404/8/26 |
| 803 | 5 | **Test & Inspection** | 573d | 2023-12-16 | 2025-11-17 |  | 0d |  |  | 1402/9/25 | 1404/8/26 |
| 804 | 5.1 | **Material inspection** | 569d | 2023-12-16 | 2025-11-12 |  | 0d |  |  | 1402/9/25 | 1404/8/21 |
| 805 | 5.1.1 | **Field Instruments (Transmitter/ Switch/ Gauge/ Analyzer etc)** | 6d | 2025-08-21 | 2025-08-27 |  | 74d |  |  | 1404/5/30 | 1404/6/5 |
| 806 | 5.1.1.1 | Visual Dimensional Inspection(Appearance) | 1d | 2025-08-21 | 2025-08-21 | 212 | 74d | 0d |  | 1404/5/30 | 1404/5/30 |
| 807 | 5.1.1.2 | Calibration Check | 1d | 2025-08-23 | 2025-08-23 | 806 | 74d | 0d |  | 1404/6/1 | 1404/6/1 |
| 808 | 5.1.1.3 | Tag & Model No & Specification Check | 1d | 2025-08-24 | 2025-08-24 | 807 | 74d | 0d |  | 1404/6/2 | 1404/6/2 |
| 809 | 5.1.1.4 | Review Material, IP,ATEX Certificate | 1d | 2025-08-25 | 2025-08-25 | 808 | 74d | 0d |  | 1404/6/3 | 1404/6/3 |
| 810 | 5.1.1.5 | Pressure & Performance Test | 1d | 2025-08-26 | 2025-08-26 | 809, 56, 57, 58 | 74d | 0d |  | 1404/6/4 | 1404/6/4 |
| 811 | 5.1.1.6 | Packing Inspection& Painting | 1d | 2025-08-27 | 2025-08-27 | 810 | 74d |  |  | 1404/6/5 | 1404/6/5 |

| ID | WBS | Task | Duration | Start | Finish | Predecessors | Total slack | Free slack | شروع | پایان |
| --- | --- | --- | --- | --- | --- | --- | --- | --- | --- | --- |
| 812 | 5.1.2 | **Cable, Wires & tray** | 12d | 2025-10-30 | 2025-11-12 |  | 8d |  | 1404/8/8 | 1404/8/21 |
| 813 | 5.1.2.1 | **Cable & Wires** | 2d | 2025-10-30 | 2025-11-01 |  | 18d |  | 1404/8/8 | 1404/8/10 |
| 814 | 5.1.2.1.1 | Visual Inspection | 1d | 2025-10-30 | 2025-10-30 | 260 | 18d | 0d | 1404/8/8 | 1404/8/8 |
| 815 | 5.1.2.1.2 | Type Test Sertificate or Manufacturer Catalogue | 1d | 2025-11-01 | 2025-11-01 | 814 | 18d |  | 1404/8/10 | 1404/8/10 |
| 816 | 5.1.2.2 | **Tray** | 2d | 2025-11-11 | 2025-11-12 |  | 8d |  | 1404/8/20 | 1404/8/21 |
| 817 | 5.1.2.2.1 | Material Inspection | 1d | 2025-11-11 | 2025-11-11 | 257 | 8d | 0d | 1404/8/20 | 1404/8/20 |
| 818 | 5.1.2.2.2 | Visual & Dimensional Inspection | 1d | 2025-11-12 | 2025-11-12 | 817 | 8d |  | 1404/8/21 | 1404/8/21 |
| 819 | 5.1.3 | **Filter** | 1d | 2023-12-16 | 2023-12-16 |  |  |  | 1404/1/26 | 1404/1/26 |
| 820 | 5.1.3.1 | Inspection for visual and dimensional check | 1d | 2025-04-15 | 2025-04-15 | 263 | 189d |  | 1404/1/26 | 1404/1/26 |
| 821 | 5.1.4 | **Junction Box** | 4d | 2025-07-17 | 2025-07-21 |  | 106d |  | 1404/4/26 | 1404/4/30 |
| 822 | 5.1.4.1 | Review IP, ATEX Certificate | 1d | 2025-07-17 | 2025-07-17 | 248 | 106d | 0d | 1404/4/26 | 1404/4/26 |
| 823 | 5.1.4.2 | Tag & Model No Check | 1d | 2025-07-19 | 2025-07-19 | 822 | 106d | 0d | 1404/4/28 | 1404/4/28 |
| 824 | 5.1.4.3 | Review IP, ATEX certificate | 1d | 2025-07-20 | 2025-07-20 | 823 | 106d | 0d | 1404/4/29 | 1404/4/29 |
| 825 | 5.1.4.4 | Packing inspection and painting | 1d | 2025-07-21 | 2025-07-21 | 824 | 106d |  | 1404/4/30 | 1404/4/30 |
| 826 | 5.1.5 | **Local Panel (Outdoor, Hazardous Area)** | 5d | 2025-07-17 | 2025-07-22 |  | 105d |  | 1404/4/26 | 1404/4/31 |
| 827 | 5.1.5.1 | Visual Inspection & Dimenslonal Check | 1d | 2025-07-17 | 2025-07-17 | 248 | 105d | 0d | 1404/4/26 | 1404/4/26 |
| 828 | 5.1.5.2 | Accessories Tag & Model No Check | 1d | 2025-07-19 | 2025-07-19 | 827 | 105d | 0d | 1404/4/28 | 1404/4/28 |
| 829 | 5.1.5.3 | Construction | 1d | 2025-07-20 | 2025-07-20 | 828 | 105d | 0d | 1404/4/29 | 1404/4/29 |
| 830 | 5.1.5.4 | Review IP, ATEX Certificate | 1d | 2025-07-21 | 2025-07-21 | 829 | 105d | 0d | 1404/4/30 | 1404/4/30 |
| 831 | 5.1.5.5 | Packing Inspection & Painting | 1d | 2025-07-22 | 2025-07-22 | 830 | 105d |  | 1404/4/31 | 1404/4/31 |
| 832 | 5.1.6 | **Control Panel (Indoor, Safe Area)** | 4d | 2025-10-13 | 2025-10-16 |  | 31d |  | 1404/7/21 | 1404/7/24 |
| 833 | 5.1.6.1 | Visual Inspection/ QTY & Dimensional Check | 1d | 2025-10-13 | 2025-10-13 | 209 | 31d | 0d | 1404/7/21 | 1404/7/21 |
| 834 | 5.1.6.2 | Tag & Model No Check | 1d | 2025-10-14 | 2025-10-14 | 833 | 31d | 0d | 1404/7/22 | 1404/7/22 |
| 835 | 5.1.6.3 | Function & Performance test (Power & Start-up Check, I/O Check) | 1d | 2025-10-15 | 2025-10-15 | 834 | 31d | 0d | 1404/7/23 | 1404/7/23 |
| 836 | 5.1.6.4 | Main equipment & Accessories Certificate IP , ATEX, SIL Certificate Check) | 1d | 2025-10-16 | 2025-10-16 | 835 | 31d |  | 1404/7/24 | 1404/7/24 |

| ID | WBS | Task | Duration | Start | Finish | Predecessors | Total slack | Free slack | Constraint | شروع | پایان |
| --- | --- | --- | --- | --- | --- | --- | --- | --- | --- | --- | --- |
| 837 | 5.1.7 | **Valves** | 7d | 2025-10-18 | 2025-10-25 |  | 24d |  |  | 1404/7/26 | 1404/8/3 |
| 838 | 5.1.7.1 | **Manual Valves** | 3d | 2025-10-18 | 2025-10-20 |  | 28d |  |  | 1404/7/26 | 1404/7/28 |
| 839 | 5.1.7.1.1 | Material Inspection | 1d | 2025-10-18 | 2025-10-18 | 233 | 28d | 0d |  | 1404/7/26 | 1404/7/26 |
| 840 | 5.1.7.1.2 | Visual and Dimensional Inspection | 1d | 2025-10-19 | 2025-10-19 | 839 | 28d | 0d |  | 1404/7/27 | 1404/7/27 |
| 841 | 5.1.7.1.3 | Other Required Tests | 1d | 2025-10-20 | 2025-10-20 | 840 | 28d |  |  | 1404/7/28 | 1404/7/28 |
| 842 | 5.1.7.2 | **Inst.Valves (Shut Down, On/Off, Control & Safety Valves)** | 7d | 2025-10-18 | 2025-10-25 |  | 24d |  |  | 1404/7/26 | 1404/8/3 |
| 843 | 5.1.7.2.1 | Material Inspection | 1d | 2025-10-18 | 2025-10-18 | 233 | 24d | 0d |  | 1404/7/26 | 1404/7/26 |
| 844 | 5.1.7.2.2 | Visual and Dimensional & QTY Inspection | 1d | 2025-10-19 | 2025-10-19 | 843 | 24d | 0d |  | 1404/7/27 | 1404/7/27 |
| 845 | 5.1.7.2.3 | Construction | 1d | 2025-10-20 | 2025-10-20 | 844 | 24d | 0d |  | 1404/7/28 | 1404/7/28 |
| 846 | 5.1.7.2.4 | Accessory | 1d | 2025-10-21 | 2025-10-21 | 845 | 24d | 0d |  | 1404/7/29 | 1404/7/29 |
| 847 | 5.1.7.2.5 | Pressure Test | 1d | 2025-10-22 | 2025-10-22 | 846 | 24d | 0d |  | 1404/7/30 | 1404/7/30 |
| 848 | 5.1.7.2.6 | Calibration | 1d | 2025-10-23 | 2025-10-23 | 847 | 24d | 0d |  | 1404/8/1 | 1404/8/1 |
| 849 | 5.1.7.2.7 | Performance test | 1d | 2025-10-25 | 2025-10-25 | 848 | 24d |  |  | 1404/8/3 | 1404/8/3 |
| 850 | 5.1.8 | **Strainers** | 3d | 2025-05-06 | 2025-05-08 |  | 169d |  |  | 1404/2/16 | 1404/2/18 |
| 851 | 5.1.8.1 | Material Inspection | 1d | 2025-05-06 | 2025-05-06 | 215 | 169d | 0d | start no earlier than 2024-10-09 | 1404/2/16 | 1404/2/16 |
| 852 | 5.1.8.2 | Visual and Dimensional Inspection | 1d | 2025-05-07 | 2025-05-07 | 851 | 169d | 0d | start no earlier than 2024-10-09 | 1404/2/17 | 1404/2/17 |
| 853 | 5.1.8.3 | Hydro Test | 1d | 2025-05-08 | 2025-05-08 | 852 | 169d |  | start no earlier than 2024-10-09 | 1404/2/18 | 1404/2/18 |
| 854 | 5.1.9 | **Piping Items (Pipe, Flange, Fitting, Gasket, Bolt & Nut)** | 6d | 2025-09-20 | 2025-09-25 |  | 49d |  |  | 1404/6/29 | 1404/7/3 |
| 855 | 5.1.9.1 | Material Inspection | 1d | 2025-09-20 | 2025-09-20 | 215, 221, 224, 227, 230 | 49d | 0d |  | 1404/6/29 | 1404/6/29 |
| 856 | 5.1.9.2 | Visual and Dimensional Inspection | 1d | 2025-09-21 | 2025-09-21 | 855 | 49d | 0d |  | 1404/6/30 | 1404/6/30 |
| 857 | 5.1.9.3 | Weld Preparation and Fit-Up | 1d | 2025-09-22 | 2025-09-22 | 856 | 49d | 0d |  | 1404/6/31 | 1404/6/31 |
| 858 | 5.1.9.4 | Welding | 1d | 2025-09-23 | 2025-09-23 | 857 | 49d | 0d |  | 1404/7/1 | 1404/7/1 |
| 859 | 5.1.9.5 | NDT( VT, MT, PT, UT, RT) | 1d | 2025-09-24 | 2025-09-24 | 858 | 49d | 0d |  | 1404/7/2 | 1404/7/2 |
| 860 | 5.1.9.6 | Hydrostatic Test | 1d | 2025-09-25 | 2025-09-25 | 859 | 49d |  |  | 1404/7/3 | 1404/7/3 |

| ID | WBS | Task | Duration | Start | Finish | Predecessors | Total slack | Free slack | Constraint | شروع | پایان |
| --- | --- | --- | --- | --- | --- | --- | --- | --- | --- | --- | --- |
| 861 | 5.1.10 | **Pump** | 2d | 2025-08-04 | 2025-08-05 |  | 93d |  |  | 1404/5/13 | 1404/5/14 |
| 862 | 5.1.10.1 | Final Visual and Dimensional Inspection | 1d | 2025-08-04 | 2025-08-04 | 236 | 93d | 0d |  | 1404/5/13 | 1404/5/13 |
| 863 | 5.1.10.2 | Performance test | 1d | 2025-08-05 | 2025-08-05 | 862 | 93d |  |  | 1404/5/14 | 1404/5/14 |
| 864 | 5.1.11 | **Chemical Injection Package** | 7d | 2025-08-04 | 2025-08-11 |  | 88d |  |  | 1404/5/13 | 1404/5/20 |
| 865 | 5.1.11.1 | Raw Material for Tank | 1d | 2025-08-04 | 2025-08-04 | 236 | 88d | 0d | start no earlier than 2024-10-09 | 1404/5/13 | 1404/5/13 |
| 866 | 5.1.11.2 | Final Inspection For Fabricated Tank | 1d | 2025-08-05 | 2025-08-05 | 865 | 88d | 0d | start no earlier than 2024-10-09 | 1404/5/14 | 1404/5/14 |
| 867 | 5.1.11.3 | Piping & Structure Works | 1d | 2025-08-06 | 2025-08-06 | 866 | 88d | 0d | start no earlier than 2024-10-09 | 1404/5/15 | 1404/5/15 |
| 868 | 5.1.11.4 | Performance test | 1d | 2025-08-07 | 2025-08-07 | 867 | 88d | 0d | start no earlier than 2024-10-09 | 1404/5/16 | 1404/5/16 |
| 869 | 5.1.11.5 | Packing Inspection | 1d | 2025-08-09 | 2025-08-09 | 868 | 88d | 0d | start no earlier than 2024-10-09 | 1404/5/18 | 1404/5/18 |
| 870 | 5.1.11.6 | IRN | 1d | 2025-08-10 | 2025-08-10 | 869 | 88d | 0d | start no earlier than 2024-10-09 | 1404/5/19 | 1404/5/19 |
| 871 | 5.1.11.7 | Final Book | 1d | 2025-08-11 | 2025-08-11 | 870 | 88d |  | start no earlier than 2024-10-09 | 1404/5/20 | 1404/5/20 |
| 872 | 5.1.12 | **Reboiler Burner** | 2d | 2025-08-16 | 2025-08-17 |  | 83d |  |  | 1404/5/25 | 1404/5/26 |
| 873 | 5.1.12.1 | Final Visual and Dimensional Inspection | 1d | 2025-08-16 | 2025-08-16 | 254 | 83d | 0d |  | 1404/5/25 | 1404/5/25 |
| 874 | 5.1.12.2 | Burner Test | 1d | 2025-08-17 | 2025-08-17 | 873 | 83d |  |  | 1404/5/26 | 1404/5/26 |
| 875 | 5.2 | **Constraction inspection** | 168d | 2025-05-06 | 2025-11-17 |  | 0d |  |  | 1404/2/16 | 1404/8/26 |
| 876 | 5.2.1 | **Vessel** | 150d | 2025-05-06 | 2025-10-27 |  | 18d |  |  | 1404/2/16 | 1404/8/5 |
| 877 | 5.2.1.1 | **C-100 Glycol Contactor** | 148d | 2025-05-08 | 2025-10-27 |  | 18d |  |  | 1404/2/18 | 1404/8/5 |
| 878 | 5.2.1.1.1 | Inspection for marking & cutting | 1d | 2025-05-08 | 2025-05-08 | 271FS-1d | 76d | 0d |  | 1404/2/18 | 1404/2/18 |
| 879 | 5.2.1.1.2 | Inspection for rolling & forming | 1d | 2025-06-14 | 2025-06-14 | 273FS-1d, 278FS-1d | 53d | 0d |  | 1404/3/24 | 1404/3/24 |
| 880 | 5.2.1.1.3 | Inspection for weld preparation and fit up (shell , nozzle , …) | 1d | 2025-08-16 | 2025-08-16 | 295FS-1d, 298FS-1d | 18d | 0d |  | 1404/5/25 | 1404/5/25 |
| 881 | 5.2.1.1.4 | Inspection for welding | 1d | 2025-06-30 | 2025-06-30 | 274FS-1d, 296FS-1d | 53d | 0d |  | 1404/4/9 | 1404/4/9 |
| 882 | 5.2.1.1.5 | Inspection for ferrite check for welding part | 1d | 2025-05-17 | 2025-05-17 | 274FS-1d | 77d | 24d |  | 1404/2/27 | 1404/2/27 |
| 883 | 5.2.1.1.6 | Inspection for NDT (VT, MT, PT, UT, RT) | 1d | 2025-10-09 | 2025-10-09 | 299FS-1d, 308FS-1d | 21d | 3d |  | 1404/7/17 | 1404/7/17 |
| 884 | 5.2.1.1.7 | Inspection for final visual and dimensional | 1d | 2025-09-28 | 2025-09-28 | 304FS-1d | 31d | 13d |  | 1404/7/6 | 1404/7/6 |
| 885 | 5.2.1.1.8 | Inspection for PWHT | 1d | 2025-10-05 | 2025-10-05 | 307FS-1d | 24d | 0d |  | 1404/7/13 | 1404/7/13 |
| 886 | 5.2.1.1.9 | Inspection for hardness check | 1d | 2025-10-06 | 2025-10-06 | 885 | 24d | 6d |  | 1404/7/14 | 1404/7/14 |
| 887 | 5.2.1.1.10 | Inspection for pneumatic test (pad test) | 1d | 2025-09-11 | 2025-09-11 | 301FS-1d | 45d | 27d |  | 1404/6/20 | 1404/6/20 |
| 888 | 5.2.1.1.11 | Inspection for hydrostatic test water quality | 1d | 2025-10-11 | 2025-10-11 | 309SS | 20d | 2d |  | 1404/7/19 | 1404/7/19 |
| 889 | 5.2.1.1.12 | Inspection for hydrostatic test | 1d | 2025-10-19 | 2025-10-19 | 310FS-1d | 18d | 0d |  | 1404/7/27 | 1404/7/27 |
| 890 | 5.2.1.1.13 | Inspection for draining & drying | 1d | 2025-10-20 | 2025-10-20 | 889 | 18d | 0d |  | 1404/7/28 | 1404/7/28 |
| 891 | 5.2.1.1.14 | Inspection for abrasive & paint material | 1d | 2025-10-21 | 2025-10-21 | 890 | 18d | 0d | start no earlier than 2024-10-09 | 1404/7/29 | 1404/7/29 |
| 892 | 5.2.1.1.15 | Inspection for blasting & painting (each layer DFT) | 1d | 2025-10-27 | 2025-10-27 | 311FS-1d | 18d | 0d |  | 1404/8/5 | 1404/8/5 |

| ID | WBS | Task | Duration | Start | Finish | Predecessors | Total slack | Free slack | Constraint | شروع | پایان |
| --- | --- | --- | --- | --- | --- | --- | --- | --- | --- | --- | --- |
| 893 | 5.2.1.2 | **C-200 Still Column** | 124d | 2025-05-07 | 2025-09-28 |  | 43d |  |  | 1404/2/17 | 1404/7/6 |
| 894 | 5.2.1.2.1 | Inspection for marking & cutting | 1d | 2025-05-07 | 2025-05-07 | 314FS-1d | 115d | 0d |  | 1404/2/17 | 1404/2/17 |
| 895 | 5.2.1.2.2 | Inspection for rolling & forming | 1d | 2025-06-14 | 2025-06-14 | 316FS-1d, 321FS-1d | 88d | 0d |  | 1404/3/24 | 1404/3/24 |
| 896 | 5.2.1.2.3 | Inspection for weld preparation and fit up (shell , nozzle , …) | 1d | 2025-08-16 | 2025-08-16 | 338FS-1d, 341FS-1d | 43d | 0d |  | 1404/5/25 | 1404/5/25 |
| 897 | 5.2.1.2.4 | Inspection for welding | 1d | 2025-06-19 | 2025-06-19 | 317FS-1d, 339FS-1d | 113d | 70d |  | 1404/3/29 | 1404/3/29 |
| 898 | 5.2.1.2.5 | Inspection for NDT (VT, MT, PT, UT, RT) | 1d | 2025-09-16 | 2025-09-16 | 342FS-1d, 351FS-1d | 45d | 2d |  | 1404/6/25 | 1404/6/25 |
| 899 | 5.2.1.2.6 | Inspection for final visual and dimensional | 1d | 2025-09-11 | 2025-09-11 | 347FS-1d | 49d | 6d |  | 1404/6/20 | 1404/6/20 |
| 900 | 5.2.1.2.7 | Inspection for PWHT | 1d | 2025-09-14 | 2025-09-14 | 350FS-1d | 46d | 0d |  | 1404/6/23 | 1404/6/23 |
| 901 | 5.2.1.2.8 | Inspection for hardness check | 1d | 2025-09-15 | 2025-09-15 | 900 | 46d | 3d |  | 1404/6/24 | 1404/6/24 |
| 902 | 5.2.1.2.9 | Inspection for pneumatic test (pad test) | 1d | 2025-09-02 | 2025-09-02 | 344FS-1d | 57d | 14d |  | 1404/6/11 | 1404/6/11 |
| 903 | 5.2.1.2.10 | Inspection for hydrostatic test water quality | 1d | 2025-09-17 | 2025-09-17 | 352SS | 44d | 1d |  | 1404/6/26 | 1404/6/26 |
| 904 | 5.2.1.2.11 | Inspection for hydrostatic test | 1d | 2025-09-21 | 2025-09-21 | 353FS-1d | 43d | 0d |  | 1404/6/30 | 1404/6/30 |
| 905 | 5.2.1.2.12 | Inspection for draining & drying | 1d | 2025-09-22 | 2025-09-22 | 904 | 43d | 0d |  | 1404/6/31 | 1404/6/31 |
| 906 | 5.2.1.2.13 | Inspection for abrasive & paint material | 1d | 2025-09-23 | 2025-09-23 | 905 | 43d | 0d | start no earlier than 2024-10-09 | 1404/7/1 | 1404/7/1 |
| 907 | 5.2.1.2.14 | Inspection for blasting & painting (each layer DFT) | 1d | 2025-09-28 | 2025-09-28 | 354FS-1d | 43d | 12d |  | 1404/7/6 | 1404/7/6 |
| 908 | 5.2.1.3 | **Lean Glycol Filter (F-300)** | 116d | 2025-05-06 | 2025-09-17 |  | 52d |  |  | 1404/2/16 | 1404/6/26 |
| 909 | 5.2.1.3.1 | Inspection for marking & cutting | 1d | 2025-05-06 | 2025-05-06 | 357FS-1d | 118d | 0d |  | 1404/2/16 | 1404/2/16 |
| 910 | 5.2.1.3.2 | Inspection for rolling & forming | 1d | 2025-06-10 | 2025-06-10 | 359FS-1d, 364FS-1d | 101d | 0d |  | 1404/3/20 | 1404/3/20 |
| 911 | 5.2.1.3.3 | Inspection for weld preparation and fit up (shell , nozzle , …) | 1d | 2025-08-12 | 2025-08-12 | 381FS-1d, 384FS-1d | 68d | 14d |  | 1404/5/21 | 1404/5/21 |
| 912 | 5.2.1.3.4 | Inspection for welding | 1d | 2025-06-15 | 2025-06-15 | 360FS-1d, 382FS-1d | 118d | 64d |  | 1404/3/25 | 1404/3/25 |
| 913 | 5.2.1.3.5 | Inspection for NDT (VT, MT, PT, UT, RT) | 1d | 2025-09-04 | 2025-09-04 | 385FS-1d, 394FS-1d | 55d | 1d |  | 1404/6/13 | 1404/6/13 |
| 914 | 5.2.1.3.6 | Inspection for final visual and dimensional | 1d | 2025-08-31 | 2025-08-31 | 390FS-1d | 59d | 5d |  | 1404/6/9 | 1404/6/9 |
| 915 | 5.2.1.3.7 | Inspection for PWHT | 1d | 2025-09-02 | 2025-09-02 | 393FS-1d | 56d | 0d |  | 1404/6/11 | 1404/6/11 |
| 916 | 5.2.1.3.8 | Inspection for hardness check | 1d | 2025-09-03 | 2025-09-03 | 915 | 56d | 2d |  | 1404/6/12 | 1404/6/12 |
| 917 | 5.2.1.3.9 | Inspection for pneumatic test (pad test) | 1d | 2025-08-23 | 2025-08-23 | 387FS-1d | 66d | 12d |  | 1404/6/1 | 1404/6/1 |
| 918 | 5.2.1.3.10 | Inspection for hydrostatic test water quality | 1d | 2025-09-06 | 2025-09-06 | 395SS | 54d | 0d |  | 1404/6/15 | 1404/6/15 |
| 919 | 5.2.1.3.11 | Inspection for hydrostatic test | 1d | 2025-09-08 | 2025-09-08 | 396FS-1d | 54d | 0d |  | 1404/6/17 | 1404/6/17 |
| 920 | 5.2.1.3.12 | Inspection for draining & drying | 1d | 2025-09-09 | 2025-09-09 | 919 | 54d | 0d |  | 1404/6/18 | 1404/6/18 |
| 921 | 5.2.1.3.13 | Inspection for abrasive & paint material | 1d | 2025-09-10 | 2025-09-10 | 920 | 54d | 2d | start no earlier than 2024-10-09 | 1404/6/19 | 1404/6/19 |
| 922 | 5.2.1.3.14 | Inspection for blasting & painting (each layer DFT) | 1d | 2025-09-17 | 2025-09-17 | 397FS-1d | 52d | 21d |  | 1404/6/26 | 1404/6/26 |

| ID | WBS | Task | Duration | Start | Finish | Predecessors | Total slack | Free slack | Constraint | شروع | پایان |
| --- | --- | --- | --- | --- | --- | --- | --- | --- | --- | --- | --- |
| 923 | 5.2.1.4 | **V-120 Glycol Flash Drum** | 129d | 2025-05-07 | 2025-10-04 |  | 38d |  |  | 1404/2/17 | 1404/7/12 |
| 924 | 5.2.1.4.1 | Inspection for marking & cutting | 1d | 2025-05-07 | 2025-05-07 | 400FS-1d | 103d | 0d |  | 1404/2/17 | 1404/2/17 |
| 925 | 5.2.1.4.2 | Inspection for rolling & forming | 1d | 2025-06-12 | 2025-06-12 | 402FS-1d, 407FS-1d | 83d | 0d |  | 1404/3/22 | 1404/3/22 |
| 926 | 5.2.1.4.3 | Inspection for weld preparation and fit up (shell , nozzle , …) | 1d | 2025-08-19 | 2025-08-19 | 424FS-1d, 427FS-1d | 61d | 23d |  | 1404/5/28 | 1404/5/28 |
| 927 | 5.2.1.4.4 | Inspection for welding | 1d | 2025-06-23 | 2025-06-23 | 403FS-1d, 425FS-1d | 110d | 72d |  | 1404/4/2 | 1404/4/2 |
| 928 | 5.2.1.4.5 | Inspection for NDT (VT, MT, PT, UT, RT) | 1d | 2025-09-23 | 2025-09-23 | 428FS-1d, 437FS-1d | 39d | 1d |  | 1404/7/1 | 1404/7/1 |
| 929 | 5.2.1.4.6 | Inspection for final visual and dimensional | 1d | 2025-09-17 | 2025-09-17 | 433FS-1d | 44d | 6d |  | 1404/6/26 | 1404/6/26 |
| 930 | 5.2.1.4.7 | Inspection for PWHT | 1d | 2025-09-21 | 2025-09-21 | 436FS-1d | 40d | 0d |  | 1404/6/30 | 1404/6/30 |
| 931 | 5.2.1.4.8 | Inspection for hardness check | 1d | 2025-09-22 | 2025-09-22 | 930 | 40d | 2d |  | 1404/6/31 | 1404/6/31 |
| 932 | 5.2.1.4.9 | Inspection for pneumatic test (pad test) | 1d | 2025-09-06 | 2025-09-06 | 430FS-1d | 54d | 16d |  | 1404/6/15 | 1404/6/15 |
| 933 | 5.2.1.4.10 | Inspection for hydrostatic test water quality | 1d | 2025-09-24 | 2025-09-24 | 438SS | 38d | 0d |  | 1404/7/2 | 1404/7/2 |
| 934 | 5.2.1.4.11 | Inspection for hydrostatic test | 1d | 2025-09-27 | 2025-09-27 | 439FS-1d | 38d | 0d |  | 1404/7/5 | 1404/7/5 |
| 935 | 5.2.1.4.12 | Inspection for draining & drying | 1d | 2025-09-28 | 2025-09-28 | 934 | 38d | 0d |  | 1404/7/6 | 1404/7/6 |
| 936 | 5.2.1.4.13 | Inspection for abrasive & paint material | 1d | 2025-09-29 | 2025-09-29 | 935 | 38d | 0d | start no earlier than 2024-10-09 | 1404/7/7 | 1404/7/7 |
| 937 | 5.2.1.4.14 | Inspection for blasting & painting (each layer DFT) | 1d | 2025-10-04 | 2025-10-04 | 440FS-1d | 38d | 7d |  | 1404/7/12 | 1404/7/12 |
| 938 | 5.2.1.5 | **F-100A Particle Glycol Filter** | 121d | 2025-05-10 | 2025-09-27 |  | 44d |  |  | 1404/2/20 | 1404/7/5 |
| 939 | 5.2.1.5.1 | Inspection for marking & cutting | 1d | 2025-05-10 | 2025-05-10 | 443FS-1d | 112d | 0d |  | 1404/2/20 | 1404/2/20 |
| 940 | 5.2.1.5.2 | Inspection for rolling & forming | 1d | 2025-05-12 | 2025-05-12 | 445FS-1d | 115d | 28d |  | 1404/2/22 | 1404/2/22 |
| 941 | 5.2.1.5.3 | Inspection for weld preparation and fit up (shell , nozzle , …) | 1d | 2025-08-17 | 2025-08-17 | 467FS-1d, 470FS-1d | 57d | 13d |  | 1404/5/26 | 1404/5/26 |
| 942 | 5.2.1.5.4 | Inspection for welding | 1d | 2025-06-21 | 2025-06-21 | 446FS-1d, 468FS-1d | 106d | 62d |  | 1404/3/31 | 1404/3/31 |
| 943 | 5.2.1.5.5 | Inspection for NDT (VT, MT, PT, UT, RT) | 1d | 2025-09-13 | 2025-09-13 | 471FS-1d, 480FS-1d | 45d | 1d |  | 1404/6/22 | 1404/6/22 |
| 944 | 5.2.1.5.6 | Inspection for final visual and dimensional | 1d | 2025-09-06 | 2025-09-06 | 476FS-1d | 51d | 7d |  | 1404/6/15 | 1404/6/15 |
| 945 | 5.2.1.5.7 | Inspection for PWHT | 1d | 2025-09-10 | 2025-09-10 | 479FS-1d | 46d | 0d |  | 1404/6/19 | 1404/6/19 |
| 946 | 5.2.1.5.8 | Inspection for hardness check | 1d | 2025-09-11 | 2025-09-11 | 945 | 46d | 2d |  | 1404/6/20 | 1404/6/20 |
| 947 | 5.2.1.5.9 | Inspection for pneumatic test (pad test) | 1d | 2025-08-26 | 2025-08-26 | 473FS-1d | 60d | 16d |  | 1404/6/4 | 1404/6/4 |
| 948 | 5.2.1.5.10 | Inspection for hydrostatic test water quality | 1d | 2025-09-14 | 2025-09-14 | 481SS | 44d | 0d |  | 1404/6/23 | 1404/6/23 |
| 949 | 5.2.1.5.11 | Inspection for hydrostatic test | 1d | 2025-09-18 | 2025-09-18 | 482FS-1d | 44d | 0d |  | 1404/6/27 | 1404/6/27 |
| 950 | 5.2.1.5.12 | Inspection for draining & drying | 1d | 2025-09-20 | 2025-09-20 | 949 | 44d | 0d |  | 1404/6/29 | 1404/6/29 |
| 951 | 5.2.1.5.13 | Inspection for abrasive & paint material | 1d | 2025-09-21 | 2025-09-21 | 950 | 44d | 0d | start no earlier than 2024-10-09 | 1404/6/30 | 1404/6/30 |
| 952 | 5.2.1.5.14 | Inspection for blasting & painting (each layer DFT) | 1d | 2025-09-27 | 2025-09-27 | 483FS-1d | 44d | 13d |  | 1404/7/5 | 1404/7/5 |

| ID | WBS | Task | Duration | Start | Finish | Predecessors | Total slack | Free slack | Constraint | شروع | پایان |
| --- | --- | --- | --- | --- | --- | --- | --- | --- | --- | --- | --- |
| 953 | 5.2.1.6 | **F-100B Particle Glycol Filter** | 114d | 2025-05-06 | 2025-09-15 |  | 54d |  |  | 1404/2/16 | 1404/6/24 |
| 954 | 5.2.1.6.1 | Inspection for marking & cutting | 1d | 2025-05-06 | 2025-05-06 | 486FS-1d | 139d | 0d |  | 1404/2/16 | 1404/2/16 |
| 955 | 5.2.1.6.2 | Inspection for rolling & forming | 1d | 2025-06-10 | 2025-06-10 | 488FS-1d, 493FS-1d | 114d | 0d |  | 1404/3/20 | 1404/3/20 |
| 956 | 5.2.1.6.3 | Inspection for weld preparation and fit up (shell , nozzle , …) | 1d | 2025-08-13 | 2025-08-13 | 510FS-1d, 513FS-1d | 70d | 7d |  | 1404/5/22 | 1404/5/22 |
| 957 | 5.2.1.6.4 | Inspection for welding | 1d | 2025-06-12 | 2025-06-12 | 489FS-1d, 511FS-1d | 123d | 60d |  | 1404/3/22 | 1404/3/22 |
| 958 | 5.2.1.6.5 | Inspection for NDT (VT, MT, PT, UT, RT) | 1d | 2025-08-27 | 2025-08-27 | 514FS-1d, 523FS-1d | 64d | 1d |  | 1404/6/5 | 1404/6/5 |
| 959 | 5.2.1.6.6 | Inspection for final visual and dimensional | 1d | 2025-08-24 | 2025-08-24 | 519FS-1d | 67d | 4d |  | 1404/6/2 | 1404/6/2 |
| 960 | 5.2.1.6.7 | Inspection for PWHT | 1d | 2025-08-26 | 2025-08-26 | 522FS-1d | 64d | 0d |  | 1404/6/4 | 1404/6/4 |
| 961 | 5.2.1.6.8 | Inspection for hardness check | 1d | 2025-08-27 | 2025-08-27 | 960 | 64d | 1d |  | 1404/6/5 | 1404/6/5 |
| 962 | 5.2.1.6.9 | Inspection for pneumatic test (pad test) | 1d | 2025-08-19 | 2025-08-19 | 516FS-1d | 71d | 8d |  | 1404/5/28 | 1404/5/28 |
| 963 | 5.2.1.6.10 | Inspection for hydrostatic test water quality | 1d | 2025-08-28 | 2025-08-28 | 524SS | 63d | 0d |  | 1404/6/6 | 1404/6/6 |
| 964 | 5.2.1.6.11 | Inspection for hydrostatic test | 1d | 2025-08-31 | 2025-08-31 | 525FS-1d | 63d | 0d |  | 1404/6/9 | 1404/6/9 |
| 965 | 5.2.1.6.12 | Inspection for draining & drying | 1d | 2025-09-01 | 2025-09-01 | 964 | 63d | 0d |  | 1404/6/10 | 1404/6/10 |
| 966 | 5.2.1.6.13 | Inspection for abrasive & paint material | 1d | 2025-09-02 | 2025-09-02 | 965 | 63d | 9d | start no earlier than 2024-10-09 | 1404/6/11 | 1404/6/11 |
| 967 | 5.2.1.6.14 | Inspection for blasting & painting (each layer DFT) | 1d | 2025-09-15 | 2025-09-15 | 526FS-1d | 54d | 23d |  | 1404/6/24 | 1404/6/24 |
| 968 | 5.2.1.7 | **F-200 Carbon Glycol Filter** | 113d | 2025-05-10 | 2025-09-17 |  | 52d |  |  | 1404/2/20 | 1404/6/26 |
| 969 | 5.2.1.7.1 | Inspection for marking & cutting | 1d | 2025-05-10 | 2025-05-10 | 529FS-1d | 131d | 0d |  | 1404/2/20 | 1404/2/20 |
| 970 | 5.2.1.7.2 | Inspection for rolling & forming | 1d | 2025-06-14 | 2025-06-14 | 531FS-1d, 536FS-1d | 106d | 0d |  | 1404/3/24 | 1404/3/24 |
| 971 | 5.2.1.7.3 | Inspection for weld preparation and fit up (shell , nozzle , …) | 1d | 2025-08-17 | 2025-08-17 | 556FS-1d, 553FS-1d | 62d | 7d |  | 1404/5/26 | 1404/5/26 |
| 972 | 5.2.1.7.4 | Inspection for welding | 1d | 2025-06-16 | 2025-06-16 | 532FS-1d, 554FS-1d | 115d | 60d |  | 1404/3/26 | 1404/3/26 |
| 973 | 5.2.1.7.5 | Inspection for NDT (VT, MT, PT, UT, RT) | 1d | 2025-09-01 | 2025-09-01 | 557FS-1d, 566FS-1d | 57d | 2d |  | 1404/6/10 | 1404/6/10 |
| 974 | 5.2.1.7.6 | Inspection for final visual and dimensional | 1d | 2025-08-27 | 2025-08-27 | 562FS-1d | 61d | 6d |  | 1404/6/5 | 1404/6/5 |
| 975 | 5.2.1.7.7 | Inspection for PWHT | 1d | 2025-08-31 | 2025-08-31 | 565FS-1d | 57d | 0d |  | 1404/6/9 | 1404/6/9 |
| 976 | 5.2.1.7.8 | Inspection for hardness check | 1d | 2025-09-01 | 2025-09-01 | 975 | 57d | 2d |  | 1404/6/10 | 1404/6/10 |
| 977 | 5.2.1.7.9 | Inspection for pneumatic test (pad test) | 1d | 2025-08-23 | 2025-08-23 | 559FS-1d | 65d | 10d |  | 1404/6/1 | 1404/6/1 |
| 978 | 5.2.1.7.10 | Inspection for hydrostatic test water quality | 1d | 2025-09-02 | 2025-09-02 | 567SS | 56d | 1d |  | 1404/6/11 | 1404/6/11 |
| 979 | 5.2.1.7.11 | Inspection for hydrostatic test | 1d | 2025-09-07 | 2025-09-07 | 568FS-1d | 55d | 0d |  | 1404/6/16 | 1404/6/16 |
| 980 | 5.2.1.7.12 | Inspection for draining & drying | 1d | 2025-09-08 | 2025-09-08 | 979 | 55d | 0d |  | 1404/6/17 | 1404/6/17 |
| 981 | 5.2.1.7.13 | Inspection for abrasive & paint material | 1d | 2025-09-09 | 2025-09-09 | 980 | 55d | 3d | start no earlier than 2024-10-09 | 1404/6/18 | 1404/6/18 |
| 982 | 5.2.1.7.14 | Inspection for blasting & painting (each layer DFT) | 1d | 2025-09-17 | 2025-09-17 | 569FS-1d | 52d | 21d |  | 1404/6/26 | 1404/6/26 |

| ID | WBS | Task | Duration | Start | Finish | Predecessors | Total slack | Free slack | Constraint | شروع | پایان |
| --- | --- | --- | --- | --- | --- | --- | --- | --- | --- | --- | --- |
| 983 | 5.2.1.8 | **E-100 Glycol reflux condenser COIL TYPE** | 119d | 2025-05-18 | 2025-10-02 |  | 39d |  |  | 1404/2/28 | 1404/7/10 |
| 984 | 5.2.1.8.1 | Inspection for marking & cutting | 1d | 2025-05-18 | 2025-05-18 | 572FS-1d | 101d | 0d |  | 1404/2/28 | 1404/2/28 |
| 985 | 5.2.1.8.2 | Inspection for rolling & forming | 1d | 2025-05-20 | 2025-05-20 | 574FS-1d | 103d | 2d |  | 1404/2/30 | 1404/2/30 |
| 986 | 5.2.1.8.3 | Inspection for weld preparation and fit up (shell , nozzle , …) | 1d | 2025-08-14 | 2025-08-14 | 592FS-1d, 595FS-1d | 39d | 0d |  | 1404/5/23 | 1404/5/23 |
| 987 | 5.2.1.8.4 | Inspection for welding | 1d | 2025-05-27 | 2025-05-27 | 573FS-1d, 593FS-1d, 590FS-1d | 131d | 92d |  | 1404/3/6 | 1404/3/6 |
| 988 | 5.2.1.8.5 | Inspection for NDT (VT, MT, PT, UT, RT) | 1d | 2025-09-18 | 2025-09-18 | 596FS-1d, 605FS-1d | 41d | 2d |  | 1404/6/27 | 1404/6/27 |
| 989 | 5.2.1.8.6 | Inspection for final visual and dimensional | 1d | 2025-09-14 | 2025-09-14 | 601FS-1d | 45d | 6d |  | 1404/6/23 | 1404/6/23 |
| 990 | 5.2.1.8.7 | Inspection for PWHT | 1d | 2025-09-17 | 2025-09-17 | 604FS-1d | 41d | 0d |  | 1404/6/26 | 1404/6/26 |
| 991 | 5.2.1.8.8 | Inspection for hardness check | 1d | 2025-09-18 | 2025-09-18 | 990 | 41d | 2d |  | 1404/6/27 | 1404/6/27 |
| 992 | 5.2.1.8.9 | Inspection for pneumatic test (pad test) | 1d | 2025-08-20 | 2025-08-20 | 598FS-1d | 66d | 27d |  | 1404/5/29 | 1404/5/29 |
| 993 | 5.2.1.8.10 | Inspection for hydrostatic test water quality | 1d | 2025-09-20 | 2025-09-20 | 606SS | 40d | 1d |  | 1404/6/29 | 1404/6/29 |
| 994 | 5.2.1.8.11 | Inspection for hydrostatic test | 1d | 2025-09-25 | 2025-09-25 | 607FS-1d, 608FS-1d | 39d | 0d |  | 1404/7/3 | 1404/7/3 |
| 995 | 5.2.1.8.12 | Inspection for draining & drying | 1d | 2025-09-27 | 2025-09-27 | 994 | 39d | 0d |  | 1404/7/5 | 1404/7/5 |
| 996 | 5.2.1.8.13 | Inspection for abrasive & paint material | 1d | 2025-09-28 | 2025-09-28 | 995 | 39d | 0d | start no earlier than 2024-10-09 | 1404/7/6 | 1404/7/6 |
| 997 | 5.2.1.8.14 | Inspection for blasting & painting (each layer DFT) | 1d | 2025-10-02 | 2025-10-02 | 609FS-1d | 39d | 8d |  | 1404/7/10 | 1404/7/10 |
| 998 | 5.2.1.9 | **V-130 Surge Tank** | 135d | 2025-05-07 | 2025-10-11 |  | 32d |  |  | 1404/2/17 | 1404/7/19 |
| 999 | 5.2.1.9.1 | Inspection for marking & cutting | 1d | 2025-05-07 | 2025-05-07 | 612FS-1d | 100d | 0d |  | 1404/2/17 | 1404/2/17 |
| 1000 | 5.2.1.9.2 | Inspection for rolling & forming | 1d | 2025-06-16 | 2025-06-16 | 614FS-1d, 619FS-1d | 80d | 0d |  | 1404/3/26 | 1404/3/26 |
| 1001 | 5.2.1.9.3 | Inspection for weld preparation and fit up (shell , nozzle , …) | 1d | 2025-08-20 | 2025-08-20 | 636FS-1d, 639FS-1d | 32d | 0d |  | 1404/5/29 | 1404/5/29 |
| 1002 | 5.2.1.9.4 | Inspection for welding | 1d | 2025-06-21 | 2025-06-21 | 615FS-1d, 637FS-1d | 111d | 79d |  | 1404/3/31 | 1404/3/31 |
| 1003 | 5.2.1.9.5 | Inspection for NDT (VT, MT, PT, UT, RT) | 1d | 2025-09-29 | 2025-09-29 | 640FS-1d, 649FS-1d | 33d | 1d |  | 1404/7/7 | 1404/7/7 |
| 1004 | 5.2.1.9.6 | Inspection for final visual and dimensional | 1d | 2025-09-23 | 2025-09-23 | 645FS-1d | 38d | 6d |  | 1404/7/1 | 1404/7/1 |
| 1005 | 5.2.1.9.7 | Inspection for PWHT | 1d | 2025-09-27 | 2025-09-27 | 648FS-1d | 34d | 0d |  | 1404/7/5 | 1404/7/5 |
| 1006 | 5.2.1.9.8 | Inspection for hardness check | 1d | 2025-09-28 | 2025-09-28 | 1005 | 34d | 2d |  | 1404/7/6 | 1404/7/6 |
| 1007 | 5.2.1.9.9 | Inspection for pneumatic test (pad test) | 1d | 2025-09-15 | 2025-09-15 | 642FS-1d | 45d | 13d |  | 1404/6/24 | 1404/6/24 |
| 1008 | 5.2.1.9.10 | Inspection for hydrostatic test water quality | 1d | 2025-09-30 | 2025-09-30 | 650SS | 32d | 0d |  | 1404/7/8 | 1404/7/8 |
| 1009 | 5.2.1.9.11 | Inspection for hydrostatic test | 1d | 2025-10-02 | 2025-10-02 | 651FS-1d | 32d | 0d |  | 1404/7/10 | 1404/7/10 |
| 1010 | 5.2.1.9.12 | Inspection for draining & drying | 1d | 2025-10-04 | 2025-10-04 | 1009 | 32d | 0d |  | 1404/7/12 | 1404/7/12 |
| 1011 | 5.2.1.9.13 | Inspection for abrasive & paint material | 1d | 2025-10-05 | 2025-10-05 | 1010 | 32d | 0d | start no earlier than 2024-10-09 | 1404/7/13 | 1404/7/13 |
| 1012 | 5.2.1.9.14 | Inspection for blasting & painting (each layer DFT) | 1d | 2025-10-11 | 2025-10-11 | 652FS-1d | 32d | 1d |  | 1404/7/19 | 1404/7/19 |

| ID | WBS | Task | Duration | Start | Finish | Predecessors | Total slack | Free slack | Constraint | شروع | پایان |
| --- | --- | --- | --- | --- | --- | --- | --- | --- | --- | --- | --- |
| 1013 | 5.2.2 | **Heat Exchanger** | 138d | 2025-05-06 | 2025-10-13 |  | 30d |  |  | 1404/2/16 | 1404/7/21 |
| 1014 | 5.2.2.1 | **E -200 Rich-Lean HE** | 127d | 2025-05-15 | 2025-10-09 |  | 33d |  |  | 1404/2/25 | 1404/7/17 |
| 1015 | 5.2.2.1.1 | Inspection for marking & cutting | 1d | 2025-05-15 | 2025-05-15 | 656FS-1d | 100d | 0d |  | 1404/2/25 | 1404/2/25 |
| 1016 | 5.2.2.1.2 | Inspection for rolling & forming | 1d | 2025-05-18 | 2025-05-18 | 658FS-1d | 102d | 2d |  | 1404/2/28 | 1404/2/28 |
| 1017 | 5.2.2.1.3 | Inspection for tube to tube sheet joint (expansion) | 1d | 2025-08-14 | 2025-08-14 | 680FS-1d | 63d | 30d |  | 1404/5/23 | 1404/5/23 |
| 1018 | 5.2.2.1.4 | Inspection for weld preparation and fit up (shell , nozzle , …) | 1d | 2025-08-11 | 2025-08-11 | 675FS-1d, 678FS-1d | 33d | 0d |  | 1404/5/20 | 1404/5/20 |
| 1019 | 5.2.2.1.5 | Inspection for welding | 1d | 2025-05-22 | 2025-05-22 | 676FS-1d, 659FS-1d | 135d | 102d |  | 1404/3/1 | 1404/3/1 |
| 1020 | 5.2.2.1.6 | Inspection for NDT (VT, MT, PT, UT, RT) | 1d | 2025-09-25 | 2025-09-25 | 679FS-1d, 688FS-1d | 35d | 2d |  | 1404/7/3 | 1404/7/3 |
| 1021 | 5.2.2.1.7 | Inspection for final visual and dimensional | 1d | 2025-09-21 | 2025-09-21 | 684FS-1d | 39d | 6d |  | 1404/6/30 | 1404/6/30 |
| 1022 | 5.2.2.1.8 | Inspection for PWHT | 1d | 2025-09-24 | 2025-09-24 | 687FS-1d | 35d | 0d |  | 1404/7/2 | 1404/7/2 |
| 1023 | 5.2.2.1.9 | Inspection for hardness check | 1d | 2025-09-25 | 2025-09-25 | 1022 | 35d | 2d |  | 1404/7/3 | 1404/7/3 |
| 1024 | 5.2.2.1.10 | Inspection for pneumatic test (pad test) | 1d | 2025-08-17 | 2025-08-17 | 681FS-1d | 69d | 36d |  | 1404/5/26 | 1404/5/26 |
| 1025 | 5.2.2.1.11 | Inspection for hydrostatic test water quality | 1d | 2025-09-27 | 2025-09-27 | 689SS | 34d | 1d |  | 1404/7/5 | 1404/7/5 |
| 1026 | 5.2.2.1.12 | Inspection for hydrostatic test | 1d | 2025-10-02 | 2025-10-02 | 691FS-1d | 33d | 0d |  | 1404/7/10 | 1404/7/10 |
| 1027 | 5.2.2.1.13 | Inspection for draining & drying | 1d | 2025-10-04 | 2025-10-04 | 1026 | 33d | 0d |  | 1404/7/12 | 1404/7/12 |
| 1028 | 5.2.2.1.14 | Inspection for abrasive & paint material | 1d | 2025-10-05 | 2025-10-05 | 1027 | 33d | 0d | start no earlier than 2024-10-09 | 1404/7/13 | 1404/7/13 |
| 1029 | 5.2.2.1.15 | Inspection for blasting & painting (each layer DFT) | 1d | 2025-10-09 | 2025-10-09 | 692FS-1d | 33d | 2d |  | 1404/7/17 | 1404/7/17 |
| 1030 | 5.2.2.2 | **E -300 LEAN TEG - DRY GAS EXCH** | 138d | 2025-05-06 | 2025-10-13 |  | 30d |  |  | 1404/2/16 | 1404/7/21 |
| 1031 | 5.2.2.2.1 | Inspection for marking & cutting | 1d | 2025-05-06 | 2025-05-06 | 695FS-1d | 105d | 0d |  | 1404/2/16 | 1404/2/16 |
| 1032 | 5.2.2.2.2 | Inspection for rolling & forming | 1d | 2025-05-08 | 2025-05-08 | 697FS-1d | 107d | 2d |  | 1404/2/18 | 1404/2/18 |
| 1033 | 5.2.2.2.3 | Inspection for tube to tube sheet joint (expansion) | 1d | 2025-09-22 | 2025-09-22 | 726FS-1d | 30d | 0d |  | 1404/6/31 | 1404/6/31 |
| 1034 | 5.2.2.2.4 | Inspection for weld preparation and fit up (shell , nozzle , …) | 1d | 2025-08-11 | 2025-08-11 | 716FS-1d, 719FS-1d | 30d | 0d |  | 1404/5/20 | 1404/5/20 |
| 1035 | 5.2.2.2.5 | Inspection for welding | 1d | 2025-05-13 | 2025-05-13 | 717FS-1d, 698FS-1d | 143d | 113d |  | 1404/2/23 | 1404/2/23 |
| 1036 | 5.2.2.2.6 | Inspection for NDT (VT, MT, PT, UT, RT) | 1d | 2025-09-29 | 2025-09-29 | 720FS-1d, 731FS-1d | 32d | 2d |  | 1404/7/7 | 1404/7/7 |
| 1037 | 5.2.2.2.7 | Inspection for final visual and dimensional | 1d | 2025-09-24 | 2025-09-24 | 727FS-1d | 36d | 6d |  | 1404/7/2 | 1404/7/2 |
| 1038 | 5.2.2.2.8 | Inspection for PWHT | 1d | 2025-09-28 | 2025-09-28 | 730FS-1d | 32d | 0d |  | 1404/7/6 | 1404/7/6 |
| 1039 | 5.2.2.2.9 | Inspection for hardness check | 1d | 2025-09-29 | 2025-09-29 | 1038 | 32d | 2d |  | 1404/7/7 | 1404/7/7 |
| 1040 | 5.2.2.2.10 | Inspection for pneumatic test (pad test) | 1d | 2025-08-17 | 2025-08-17 | 722FS-1d | 69d | 39d |  | 1404/5/26 | 1404/5/26 |
| 1041 | 5.2.2.2.11 | Inspection for hydrostatic test water quality | 1d | 2025-09-30 | 2025-09-30 | 732SS | 31d | 1d |  | 1404/7/8 | 1404/7/8 |
| 1042 | 5.2.2.2.12 | Inspection for hydrostatic test | 1d | 2025-10-06 | 2025-10-06 | 733FS-1d, 734FS-1d | 30d | 0d |  | 1404/7/14 | 1404/7/14 |
| 1043 | 5.2.2.2.13 | Inspection for draining & drying | 1d | 2025-10-07 | 2025-10-07 | 1042 | 30d | 0d |  | 1404/7/15 | 1404/7/15 |
| 1044 | 5.2.2.2.14 | Inspection for abrasive & paint material | 1d | 2025-10-08 | 2025-10-08 | 1043 | 30d | 0d | start no earlier than 2024-10-09 | 1404/7/16 | 1404/7/16 |
| 1045 | 5.2.2.2.15 | Inspection for blasting & painting (each layer DFT) | 1d | 2025-10-13 | 2025-10-13 | 735FS-1d | 30d | 0d |  | 1404/7/21 | 1404/7/21 |

| ID | WBS | Task | Duration | Start | Finish | Predecessors | Total slack | Free slack | Constraint | شروع | پایان |
| --- | --- | --- | --- | --- | --- | --- | --- | --- | --- | --- | --- |
| 1046 | 5.2.3 | **Reboiler** | 128d | 2025-05-06 | 2025-10-01 |  | 40d |  |  | 1404/2/16 | 1404/7/9 |
| 1047 | 5.2.3.1 | Inspection for marking & cutting | 1d | 2025-05-06 | 2025-05-06 | 738FS-1d | 113d | 0d |  | 1404/2/16 | 1404/2/16 |
| 1048 | 5.2.3.2 | Inspection for rolling & forming | 1d | 2025-06-11 | 2025-06-11 | 740FS-1d, 745FS-1d | 88d | 0d |  | 1404/3/21 | 1404/3/21 |
| 1049 | 5.2.3.3 | Inspection for weld preparation and fit up (shell , nozzle , …) | 1d | 2025-08-24 | 2025-08-24 | 762FS-1d, 765FS-1d | 40d | 0d |  | 1404/6/2 | 1404/6/2 |
| 1050 | 5.2.3.4 | Inspection for welding | 1d | 2025-06-24 | 2025-06-24 | 741FS-1d, 763FS-1d | 110d | 70d |  | 1404/4/3 | 1404/4/3 |
| 1051 | 5.2.3.5 | Inspection for NDT (VT, MT, PT, UT, RT) | 1d | 2025-09-21 | 2025-09-21 | 766FS-1d, 775FS-1d | 41d | 1d |  | 1404/6/30 | 1404/6/30 |
| 1052 | 5.2.3.6 | Inspection for final visual and dimensional | 1d | 2025-09-16 | 2025-09-16 | 771FS-1d | 45d | 5d |  | 1404/6/25 | 1404/6/25 |
| 1053 | 5.2.3.7 | Inspection for PWHT | 1d | 2025-09-20 | 2025-09-20 | 774FS-1d | 41d | 0d |  | 1404/6/29 | 1404/6/29 |
| 1054 | 5.2.3.8 | Inspection for hardness check | 1d | 2025-09-21 | 2025-09-21 | 1053 | 41d | 1d |  | 1404/6/30 | 1404/6/30 |
| 1055 | 5.2.3.9 | Inspection for pneumatic test (pad test) | 1d | 2025-09-07 | 2025-09-07 | 768FS-1d | 53d | 13d |  | 1404/6/16 | 1404/6/16 |
| 1056 | 5.2.3.10 | Inspection for hydrostatic test water quality | 1d | 2025-09-22 | 2025-09-22 | 776SS | 40d | 0d |  | 1404/6/31 | 1404/6/31 |
| 1057 | 5.2.3.11 | Inspection for hydrostatic test | 1d | 2025-09-24 | 2025-09-24 | 777FS-1d | 40d | 0d |  | 1404/7/2 | 1404/7/2 |
| 1058 | 5.2.3.12 | Inspection for draining & drying | 1d | 2025-09-25 | 2025-09-25 | 1057 | 40d | 0d |  | 1404/7/3 | 1404/7/3 |
| 1059 | 5.2.3.13 | Inspection for abrasive & paint material | 1d | 2025-09-27 | 2025-09-27 | 1058 | 40d | 0d | start no earlier than 2024-10-09 | 1404/7/5 | 1404/7/5 |
| 1060 | 5.2.3.14 | Inspection for blasting & painting (each layer DFT) | 1d | 2025-10-01 | 2025-10-01 | 778FS-1d | 40d | 9d |  | 1404/7/9 | 1404/7/9 |
| 1061 | 5.2.4 | **L&P** | 1d | 2025-11-12 | 2025-11-12 |  | 0d |  |  | 1404/8/21 | 1404/8/21 |
| 1062 | 5.2.4.1 | Inspection for visual and dimensional check after welding | 1d | 2025-11-12 | 2025-11-12 | 786FS-1d | 0d |  |  | 1404/8/21 | 1404/8/21 |
| 1063 | 5.2.5 | **Painting Of Package Assembly (Piping, Structure)** | 5d | 2025-11-12 | 2025-11-17 |  | 0d |  |  | 1404/8/21 | 1404/8/26 |
| 1064 | 5.2.5.1 | Inspection for abrasive & paint material | 1d | 2025-11-12 | 2025-11-12 | 1062SS | 0d |  | start no earlier than 2024-10-09 | 1404/8/21 | 1404/8/21 |
| 1065 | 5.2.5.2 | Inspection for blasting & painting (each layer DFT) | 1d | 2025-11-17 | 2025-11-17 | 802FS-1d | 0d |  |  | 1404/8/26 | 1404/8/26 |
| 1066 | 5.2.6 | **Pickling (For Stailess Steel Part)** | 1d | 2025-09-11 | 2025-09-11 |  | 49d |  |  | 1404/6/20 | 1404/6/20 |
| 1067 | 5.2.6.1 | Inspection for pickling and passivation | 1d | 2025-09-11 | 2025-09-11 | 347FS-1d | 49d | 6d |  | 1404/6/20 | 1404/6/20 |
| 1068 | 6 | **Final Inspection & Releas note** | 33d | 2025-10-13 | 2025-11-19 |  | 0d |  |  | 1404/7/21 | 1404/8/28 |
| 1069 | 6.1 | **C-100 Glycol Contactor** | 2d | 2025-10-28 | 2025-10-29 |  | 18d |  |  | 1404/8/6 | 1404/8/7 |
| 1070 | 6.1.1 | Final Inspection & Releas note | 2d | 2025-10-28 | 2025-10-29 | 311, 892, 209, 224, 230 | 18d | 0d |  | 1404/8/6 | 1404/8/7 |

| ID | WBS | Task | Duration | Start | Finish | Predecessors | Total slack | Free slack | شروع | پایان |
| --- | --- | --- | --- | --- | --- | --- | --- | --- | --- | --- |
| 1071 | 6.2 | **C-200 Still Column** | 2d | 2025-10-13 | 2025-10-14 |  | 31d |  | 1404/7/21 | 1404/7/22 |
| 1072 | 6.2.1 | Final Inspection & Releas note | 2d | 2025-10-13 | 2025-10-14 | 354, 907, 209, 224, 230 | 31d | 0d | 1404/7/21 | 1404/7/22 |
| 1073 | 6.3 | **Lean Glycol Filter (F-300)** | 2d | 2025-10-13 | 2025-10-14 |  | 31d |  | 1404/7/21 | 1404/7/22 |
| 1074 | 6.3.1 | Final Inspection & Releas note | 2d | 2025-10-13 | 2025-10-14 | 397, 922, 209, 224, 230 | 31d | 0d | 1404/7/21 | 1404/7/22 |
| 1075 | 6.4 | **V-120 Glycol Flash Drum** | 2d | 2025-10-13 | 2025-10-14 |  | 31d |  | 1404/7/21 | 1404/7/22 |
| 1076 | 6.4.1 | Final Inspection & Releas note | 2d | 2025-10-13 | 2025-10-14 | 440, 937, 209, 224, 230 | 31d | 0d | 1404/7/21 | 1404/7/22 |
| 1077 | 6.5 | **F-100A Particle Glycol Filter** | 2d | 2025-10-13 | 2025-10-14 |  | 31d |  | 1404/7/21 | 1404/7/22 |
| 1078 | 6.5.1 | Final Inspection & Releas note | 2d | 2025-10-13 | 2025-10-14 | 483, 952, 209, 224, 230 | 31d | 0d | 1404/7/21 | 1404/7/22 |
| 1079 | 6.6 | **F-100B Particle Glycol Filter** | 2d | 2025-10-13 | 2025-10-14 |  | 31d |  | 1404/7/21 | 1404/7/22 |
| 1080 | 6.6.1 | Final Inspection & Releas note | 2d | 2025-10-13 | 2025-10-14 | 526, 967, 209, 224, 230 | 31d | 0d | 1404/7/21 | 1404/7/22 |
| 1081 | 6.7 | **F-200 Carbon Glycol Filter** | 2d | 2025-10-13 | 2025-10-14 |  | 31d |  | 1404/7/21 | 1404/7/22 |
| 1082 | 6.7.1 | Final Inspection & Releas note | 2d | 2025-10-13 | 2025-10-14 | 569, 982, 209, 224, 230 | 31d | 0d | 1404/7/21 | 1404/7/22 |
| 1083 | 6.8 | **E-100 Glycol reflux condenser COIL TYPE** | 2d | 2025-10-13 | 2025-10-14 |  | 31d |  | 1404/7/21 | 1404/7/22 |
| 1084 | 6.8.1 | Final Inspection & Releas note | 2d | 2025-10-13 | 2025-10-14 | 609, 997, 209, 224, 230 | 31d | 0d | 1404/7/21 | 1404/7/22 |
| 1085 | 6.9 | **E -200 Rich-Lean HE** | 2d | 2025-10-13 | 2025-10-14 |  | 31d |  | 1404/7/21 | 1404/7/22 |
| 1086 | 6.9.1 | Final Inspection & Releas note | 2d | 2025-10-13 | 2025-10-14 | 692, 1029, 209, 224, 230 | 31d | 0d | 1404/7/21 | 1404/7/22 |
| 1087 | 6.10 | **E -300 LEAN TEG - DRY GAS EXCH** | 2d | 2025-10-14 | 2025-10-15 |  | 30d |  | 1404/7/22 | 1404/7/23 |
| 1088 | 6.10.1 | Final Inspection & Releas note | 2d | 2025-10-14 | 2025-10-15 | 735, 1045, 209, 224, 230 | 30d | 0d | 1404/7/22 | 1404/7/23 |
| 1089 | 6.11 | **V-130 Surge Tank** | 2d | 2025-10-13 | 2025-10-14 |  | 31d |  | 1404/7/21 | 1404/7/22 |
| 1090 | 6.11.1 | Final Inspection & Releas note | 2d | 2025-10-13 | 2025-10-14 | 652, 1012, 209, 224, 230 | 31d | 0d | 1404/7/21 | 1404/7/22 |
| 1091 | 6.12 | **R-100 Reboiler** | 2d | 2025-10-13 | 2025-10-14 |  | 31d |  | 1404/7/21 | 1404/7/22 |
| 1092 | 6.12.1 | Final Inspection & Releas note | 2d | 2025-10-13 | 2025-10-14 | 778, 1060, 209, 224, 230 | 31d | 0d | 1404/7/21 | 1404/7/22 |
| 1093 | 6.13 | **Skid of Gas Dehydration** | 2d | 2025-11-18 | 2025-11-19 |  | 0d |  | 1404/8/27 | 1404/8/28 |
| 1094 | 6.13.1 | Final Inspection & Releas note | 2d | 2025-11-18 | 2025-11-19 | 787, 1065, 209, 224, 230 | 0d |  | 1404/8/27 | 1404/8/28 |

| ID | WBS | Task | Duration | Start | Finish | Predecessors | Total slack | شروع | پایان |
| --- | --- | --- | --- | --- | --- | --- | --- | --- | --- |
| 1095 | 6.14 | **Piping of Gas Dehydration** | 2d | 2025-11-18 | 2025-11-19 |  | 0d | 1404/8/27 | 1404/8/28 |
| 1096 | 6.14.1 | Final Inspection & Releas note | 2d | 2025-11-18 | 2025-11-19 | 802, 209, 224, 230 | 0d | 1404/8/27 | 1404/8/28 |
| 1097 | 7 | **Ready for Shipment** | 33d | 2025-10-15 | 2025-11-22 |  | 0d | 1404/7/23 | 1404/9/1 |
| 1098 | 7.1 | **C-100 Glycol Contactor** | 2d | 2025-10-30 | 2025-11-01 |  | 18d | 1404/8/8 | 1404/8/10 |
| 1099 | 7.1.1 | Preparing and shipment | 2d | 2025-10-30 | 2025-11-01 | 1070 | 18d | 1404/8/8 | 1404/8/10 |
| 1100 | 7.2 | **C-200 Still Column** | 2d | 2025-10-15 | 2025-10-16 |  | 31d | 1404/7/23 | 1404/7/24 |
| 1101 | 7.2.1 | Preparing and shipment | 2d | 2025-10-15 | 2025-10-16 | 1072 | 31d | 1404/7/23 | 1404/7/24 |
| 1102 | 7.3 | **Lean Glycol Filter (F-300)** | 2d | 2025-10-15 | 2025-10-16 |  | 31d | 1404/7/23 | 1404/7/24 |
| 1103 | 7.3.1 | Preparing and shipment | 2d | 2025-10-15 | 2025-10-16 | 1074 | 31d | 1404/7/23 | 1404/7/24 |
| 1104 | 7.4 | **V-120 Glycol Flash Drum** | 2d | 2025-10-15 | 2025-10-16 |  | 31d | 1404/7/23 | 1404/7/24 |
| 1105 | 7.4.1 | Preparing and shipment | 2d | 2025-10-15 | 2025-10-16 | 1076 | 31d | 1404/7/23 | 1404/7/24 |
| 1106 | 7.5 | **F-100A Particle Glycol Filter** | 2d | 2025-10-15 | 2025-10-16 |  | 31d | 1404/7/23 | 1404/7/24 |
| 1107 | 7.5.1 | Preparing and shipment | 2d | 2025-10-15 | 2025-10-16 | 1078 | 31d | 1404/7/23 | 1404/7/24 |
| 1108 | 7.6 | **F-100B Particle Glycol Filter** | 2d | 2025-10-15 | 2025-10-16 |  | 31d | 1404/7/23 | 1404/7/24 |
| 1109 | 7.6.1 | Preparing and shipment | 2d | 2025-10-15 | 2025-10-16 | 1080 | 31d | 1404/7/23 | 1404/7/24 |
| 1110 | 7.7 | **F-200 Carbon Glycol Filter** | 2d | 2025-10-15 | 2025-10-16 |  | 31d | 1404/7/23 | 1404/7/24 |
| 1111 | 7.7.1 | Preparing and shipment | 2d | 2025-10-15 | 2025-10-16 | 1082 | 31d | 1404/7/23 | 1404/7/24 |
| 1112 | 7.8 | **E-100 Glycol reflux condenser COIL TYPE** | 2d | 2025-10-15 | 2025-10-16 |  | 31d | 1404/7/23 | 1404/7/24 |
| 1113 | 7.8.1 | Preparing and shipment | 2d | 2025-10-15 | 2025-10-16 | 1084 | 31d | 1404/7/23 | 1404/7/24 |
| 1114 | 7.9 | **E -200 Rich-Lean HE** | 2d | 2025-10-15 | 2025-10-16 |  | 31d | 1404/7/23 | 1404/7/24 |
| 1115 | 7.9.1 | Preparing and shipment | 2d | 2025-10-15 | 2025-10-16 | 1086 | 31d | 1404/7/23 | 1404/7/24 |
| 1116 | 7.10 | **E -300 LEAN TEG - DRY GAS EXCH** | 2d | 2025-10-16 | 2025-10-18 |  | 30d | 1404/7/24 | 1404/7/26 |
| 1117 | 7.10.1 | Preparing and shipment | 2d | 2025-10-16 | 2025-10-18 | 1088 | 30d | 1404/7/24 | 1404/7/26 |
| 1118 | 7.11 | **V-130 Surge Tank** | 2d | 2025-10-15 | 2025-10-16 |  | 31d | 1404/7/23 | 1404/7/24 |
| 1119 | 7.11.1 | Preparing and shipment | 2d | 2025-10-15 | 2025-10-16 | 1090 | 31d | 1404/7/23 | 1404/7/24 |

| ID | WBS | Task | Duration | Start | Finish | Predecessors | Total slack | شروع | پایان |
| --- | --- | --- | --- | --- | --- | --- | --- | --- | --- |
| 1120 | 7.12 | **R-100 Reboiler** | 2d | 2025-10-15 | 2025-10-16 |  | 31d | 1404/7/23 | 1404/7/24 |
| 1121 | 7.12.1 | Preparing and shipment | 2d | 2025-10-15 | 2025-10-16 | 1092 | 31d | 1404/7/23 | 1404/7/24 |
| 1122 | 7.13 | **Skid of Gas Dehydration** | 2d | 2025-11-20 | 2025-11-22 |  | 0d | 1404/8/29 | 1404/9/1 |
| 1123 | 7.13.1 | Preparing and shipment | 2d | 2025-11-20 | 2025-11-22 | 1094 | 0d | 1404/8/29 | 1404/9/1 |
| 1124 | 7.14 | **Piping of Gas Dehydration** | 1d | 2025-11-20 | 2025-11-20 |  | 1d | 1404/8/29 | 1404/8/29 |
| 1125 | 7.14.1 | Preparing and shipment | 1d | 2025-11-20 | 2025-11-20 | 1096 | 1d | 1404/8/29 | 1404/8/29 |
| 1126 | 8 | **Final data book** | 539d? | 2024-01-29 | 2025-11-22 |  | 0d | 1402/11/9 | 1404/9/1 |
| 1127 | 8.1 | Final data book | 4d | 2025-11-18 | 2025-11-22 | 1072SS, 1074SS, 1076SS, 1078SS, 1080SS, 1082SS, 1084SS, 1086SS, 1088SS, 1090SS, 1092SS, 1094SS, 1096SS, 13SS, 1070SS | 0d | 1404/8/27 | 1404/9/1 |
